# BOOM I & T

Schedule from MS Project, 2002-07-01 to 2004-07-13, status date 2003-05-31, A marks actual dates.
BOOM Suite I & T
NASA GSFC
Status Date: 05/31/2003 / Baseline Date: 01/31/2003 R1

## Calendars

- Standard w/ 10 Gov't Holidays: Mon-Fri 08:00-12:00, 13:00-17:00; Sat-Sun off. Exceptions (off unless hours are given): 2002-07-04, 2002-09-02, 2002-10-07, 2002-11-11, 2002-11-28, 2002-12-25, 2003-01-01, 2003-01-13, 2003-02-17, 2003-05-26, 2003-07-04, 2003-09-01, 2003-10-06, 2003-11-10, 2003-11-27, 2003-12-25, 2004-01-01, 2004-01-12, 2004-02-16, 2004-05-31, 2004-07-05.

## Resources

| Resource |
| --- |
| UCB-BOOM |

## Schedule

| ID | WBS | Task | Type | Duration | Start | Finish | Predecessors | Complete | Remaining | Baseline start | Baseline finish | Baseline duration | Total slack | Free slack | Constraint | Text11 | Text12 | Text13 | Text14 | Text16 | Text28 | Text20 | Text22 | Text23 | Text17 |
| --- | --- | --- | --- | --- | --- | --- | --- | --- | --- | --- | --- | --- | --- | --- | --- | --- | --- | --- | --- | --- | --- | --- | --- | --- | --- |
| 1 | 1 | **Management** |  | 510.75d | 2002-07-01 A | 2004-07-13 |  |  | 510.75d | 2002-07-01 | 2004-07-27 | 521d | 0d |  |  | STEREO | IMPACT | Boom Suite | Boom | Boom | UC-B |  |  |  |  |
| 2 | 1.1 | **Contingency Blocks** |  | 53.75d | 2004-04-12 | 2004-06-28 |  |  |  | 2004-04-01 | 2004-07-27 | 81d | 0d |  |  | STEREO | IMPACT | Boom Suite | Boom | Boom | UC-B |  |  |  |  |
| 3 | 1.1.1 | BOOM Suite FM 1 Contingency Prior to IMPACT Suite EMC Testing | milestone | 0d | 2004-04-12 | 2004-04-12 | 68 |  |  | 2004-04-01 | 2004-04-01 | 0d | 19d | 0d |  | STEREO | IMPACT | Boom Suite | Boom | Boom | UC-B |  |  |  |  |
| 4 | 1.1.2 | Boom Suite FM 1 Contingency Prior to Ready for Delivery |  | 7d | 2004-06-15 | 2004-06-24 | 71 |  |  | 2004-06-09 | 2004-07-14 | 25d | 2d | 0d |  | STEREO | IMPACT | Boom Suite | Boom | Boom | UC-B |  |  |  |  |
| 5 | 1.1.3 | BOOM Suite FM 2 Contingency Prior to IMPACT Suite EMC Testing | milestone | 0d | 2004-05-19 | 2004-05-19 | 75 |  |  | 2004-06-08 | 2004-06-08 | 0d | 1.75d | 0d |  | STEREO | IMPACT | Boom Suite | Boom | Boom | UC-B |  |  |  |  |
| 6 | 1.1.4 | Boom Suite FM 2 Contingency Prior to Ready for Delivery | milestone | 0d | 2004-06-28 | 2004-06-28 | 77 |  |  | 2004-07-15 | 2004-07-27 | 9d | 0d |  |  | STEREO | IMPACT | Boom Suite | Boom | Boom | UC-B |  |  |  |  |
| 7 | 1.2 | **Milestones** |  | 510.75d | 2002-07-01 A | 2004-07-13 |  |  | 510.75d | 2002-07-01 | 2004-07-27 | 521d | 0d |  |  | STEREO | IMPACT | Boom Suite | Boom | Boom | UC-B |  |  |  |  |
| 8 | 1.2.1 | FM 1 Boom Suite I & T Complete | milestone | 0d | 2004-04-12 | 2004-04-12 | 68 |  |  | 2004-04-01 | 2004-04-01 | 0d | 19d | 0d |  | STEREO | IMPACT | Boom Suite | Boom | Boom | UC-B | FM 1 I & T | Boom Suite - FM 1 I & T Complete | FM 1 Boom Suite I & T Complete |  |
| 9 | 1.2.2 | FM 1 Boom Suite Environmental Testing Complete | milestone | 0d | 2004-05-25 | 2004-05-25 | 69 |  |  | 2004-05-18 | 2004-05-18 | 0d | 33d |  |  | STEREO | IMPACT | Boom Suite | Boom | Boom | UC-B | FM1 Envt | Boom Suite - FM 1 Environmental Testing Complete | FM 1 Boom Suite Environmental Testing Complete |  |
| 10 | 1.2.3 | FM 2 Boom Suite I & T Complete | milestone | 0d | 2004-05-17 | 2004-05-17 | 74 |  |  | 2004-06-04 | 2004-06-04 | 0d | 1.75d | 0d |  | STEREO | IMPACT | Boom Suite | Boom | Boom | UC-B | FM 2 I & T | Boom Suite - FM 2 I & T Complete | FM 2 Boom Suite I & T Complete |  |
| 11 | 1.2.4 | FM 2 Boom Suite Environmental Testing Complete | milestone | 0d | 2004-05-19 | 2004-05-19 | 75 |  |  | 2004-06-08 | 2004-06-08 | 0d | 36.75d |  |  | STEREO | IMPACT | Boom Suite | Boom | Boom | UC-B | FM 2 Envt | Boom Suite - FM 2 Environmental Testing Complete | FM 2 Boom Suite Environmental Testing Complete |  |
| 12 | 1.2.5 | **Receivables** |  | 323.75d | 2003-03-31 A | 2004-07-13 |  |  | 323.75d | 2003-02-01 | 2004-07-06 | 359d | 0d |  |  | STEREO | IMPACT | Boom Suite | Boom | Boom | UC-B |  |  |  |  |
| 13 | 1.2.5.1 | Receive RFAs From Instrument CDR | milestone | 0d | 2003-03-31 A | 2003-05-31 | 46FS+10d | 90% | 0d | 2003-02-01 | 2003-02-01 | 0d | 290d |  | start no earlier than 2003-03-31 | STEREO | IMPACT | Boom Suite | Boom | Boom | UC-B |  |  |  |  |
| 14 | 1.2.5.2 | **FM 1** |  | 125.75d | 2003-12-12 | 2004-06-14 |  |  |  | 2003-02-01 | 2004-06-07 | 339d | 10d |  |  | STEREO | IMPACT | Boom Suite | Boom | Boom | UC-B |  |  |  |  |
| 15 | 1.1.10.6 | Delivery FM 1 Boom Structure | milestone | 0d | 2004-06-14 | 2004-06-14 |  |  |  | 2004-06-07 | 2004-06-07 | 0d | 8.25d | 0d | finish no later than 2004-06-25 | STEREO | IMPACT | Boom Suite | Boom | Boom | UC-B |  |  |  |  |
| 16 | 1.2.5.2.2 | Receive BOOM FM 1 For BOOM Suite I & T | milestone | 0d | 2004-06-14 | 2004-06-14 | 15 |  |  | 2004-06-07 | 2004-06-07 | 0d | 23.55d |  |  | STEREO | IMPACT | Boom Suite | Boom | Boom | UC-B |  |  |  |  |
| 17 | 1.1.10.3 | Deliver Protoflight Boom for I & T | milestone | 0d | 2003-12-31 | 2003-12-31 |  |  |  | 2003-12-30 | 2003-12-30 | 0d | 0.25d | 0d | finish no later than 2003-12-31 | STEREO | IMPACT | Boom Suite | Boom | Boom | UC-B |  |  |  |  |
| 18 | 1.2.5.2.4 | Receive Protoflight BOOM for FM 1 BOOM Suite I & T | milestone | 0d | 2004-01-08 | 2004-01-08 | 17FS+5d |  |  | 2004-01-07 | 2004-01-07 | 0d | 44.25d |  |  | STEREO | IMPACT | Boom Suite | Boom | Boom | UC-B |  |  |  |  |
| 19 | 1.1.8.3 | Deliver STE-U FM 1 For STE-U BOOM Suite I & T | milestone | 0d | 2004-01-08 | 2004-01-08 |  |  |  | 2004-01-07 | 2004-01-07 | 0d | 0d |  | finish no later than 2004-01-08 | STEREO | IMPACT | Boom Suite | Boom | Boom | UC-B |  |  |  | Boom |
| 20 | 1.2.5.2.6 | Receive STE-U FM 1 For BOOM Suite I & T | milestone | 0d | 2004-01-16 | 2004-01-16 | 19FF+5d |  |  | 2004-01-15 | 2004-01-15 | 0d | 39d | 20d |  | STEREO | IMPACT | Boom Suite | Boom | Boom | UC-B |  |  |  |  |
| 21 | 1.1.3.3 | Deliver SWEA/STE-D FM 1 For FM 1 BOOM Suite I & T | milestone | 0d | 2004-02-23 | 2004-02-23 |  |  |  | 2004-01-28 | 2004-01-28 | 0d | 19d | 0d |  | STEREO | IMPACT | Boom Suite | Boom | Boom | UC-B |  |  |  | Boom |
| 22 | 1.2.5.2.8 | Receive SWEA/STE-D FM 1 For BOOM Suite I & T | milestone | 0d | 2004-02-24 | 2004-02-24 | 21FS+1d |  |  | 2004-02-04 | 2004-02-04 | 0d | 19d | 0d |  | STEREO | IMPACT | Boom Suite | Boom | Boom | UC-B |  |  |  |  |
| 23 | 1.1.5.43 | Deliver FM 1 MAG For FM 1 Boom Suite I & T | milestone | 0d | 2003-12-12 | 2003-12-12 |  |  |  | 2003-11-05 | 2003-11-05 | 0d | 58d | 0d |  | STEREO | IMPACT | Boom Suite | Boom | Boom | UC-B |  |  |  |  |
| 24 | 1.2.5.2.10 | Receive MAG FM 1 For BOOM Suite I & T | milestone | 0d | 2003-12-12 | 2003-12-12 | 23 |  |  | 2003-11-05 | 2003-11-05 | 0d | 61d |  |  | STEREO | IMPACT | Boom Suite | Boom | Boom | UC-B |  |  |  |  |
| 25 | 1.1.5.29 | Deliver IDPU FM 1 For BOOM Suite I & T | milestone | 0d | 2004-02-10 | 2004-02-10 |  |  |  | 2004-02-10 | 2004-02-10 | 0d | 0d |  | finish no later than 2004-02-10 | STEREO | IMPACT | Boom Suite | Boom | Boom | UC-B |  |  |  |  |
| 26 | 1.2.5.2.12 | Receive IDPU FM 1 For BOOM Suite/IDPU I & T | milestone | 0d | 2004-02-18 | 2004-02-18 | 25FS+5d |  |  | 2004-02-18 | 2004-02-18 | 0d | 37d | 18d |  | STEREO | IMPACT | Boom Suite | Boom | Boom | UC-B |  |  |  |  |
| 27 | 1.1.67.1 | Deliver BOOM Suite FM 1 After EMC Testing | milestone | 0d | 2004-05-14 | 2004-05-14 |  |  |  | 2004-05-07 | 2004-05-07 | 0d | 2d | 0d |  | STEREO | IMPACT | Boom Suite | Boom | Boom | UC-B |  |  |  | Boom |
| 28 | 1.2.5.2.14 | Receive BOOM Suite FM 1 From IMPACT Suite EMC Testing | milestone | 0d | 2004-05-21 | 2004-05-21 | 27FS+5d |  |  | 2004-05-14 | 2004-05-14 | 0d | 2d | 0d |  | STEREO | IMPACT | Boom Suite | Boom | Boom | UC-B |  |  |  |  |
| 29 | 1.1.5.35 | Deliver IDPU FM 1 For Final BOOM Suite I & T | milestone | 0d | 2004-02-10 | 2004-02-10 |  |  |  | 2000-01-01 | 2000-01-01 | 0d | 79d | 0d | start no earlier than 2003-04-30 | STEREO | IMPACT | Boom Suite | Boom | Boom | UC-B |  |  |  |  |
| 30 | 1.2.5.2.16 | Receive IDPU FM 1 For Final BOOM Suite I & T | milestone | 0d | 2004-02-18 | 2004-02-18 | 29FS+5d |  |  | 2003-02-01 | 2003-02-01 | 0d | 79d |  | start no earlier than 2003-05-31 | STEREO | IMPACT | Boom Suite | Boom | Boom | UC-B |  |  |  |  |

Notes:
- 4: March 03 Status - Removed 7 days of contingency. Dropped to 10 days from 17 days.

| ID | WBS | Task | Type | Duration | Start | Finish | Predecessors | Complete | Remaining | Baseline start | Baseline finish | Baseline duration | Total slack | Free slack | Constraint | Text11 | Text12 | Text13 | Text14 | Text16 | Text28 | Text17 | Text20 | Text22 | Text23 |
| --- | --- | --- | --- | --- | --- | --- | --- | --- | --- | --- | --- | --- | --- | --- | --- | --- | --- | --- | --- | --- | --- | --- | --- | --- | --- |
| 31 | 1.2.5.3 | **FM 2** |  | 102.75d | 2004-02-17 | 2004-07-13 |  |  |  | 2003-02-01 | 2004-07-06 | 359d | 0d |  |  | STEREO | IMPACT | Boom Suite | Boom | Boom | UC-B |  |  |  |  |
| 32 | 1.1.10.9 | Delivery FM 2 Boom Structure | milestone | 0d | 2004-07-13 | 2004-07-13 |  |  |  | 2004-07-06 | 2004-07-06 | 0d | 0d |  | finish no later than 2004-07-30 | STEREO | IMPACT | Boom Suite | Boom | Boom | UC-B |  |  |  |  |
| 33 | 1.2.5.3.2 | Receive BOOM FM 2 For BOOM Suite I & T | milestone | 0d | 2004-07-13 | 2004-07-13 | 32 |  |  | 2004-07-06 | 2004-07-06 | 0d | 0d |  |  | STEREO | IMPACT | Boom Suite | Boom | Boom | UC-B |  |  |  |  |
| 34 | 1.1.8.5 | Deliver STE-U FM 2 For STE-U BOOM Suite I & T | milestone | 0d | 2004-04-19 | 2004-04-19 |  |  |  | 2004-04-19 | 2004-04-19 | 0d | 0d |  | finish no later than 2004-04-19 | STEREO | IMPACT | Boom Suite | Boom | Boom | UC-B | Boom |  |  |  |
| 35 | 1.2.5.3.4 | Receive STE-U FM 2 For BOOM Suite I & T | milestone | 0d | 2004-04-19 | 2004-04-19 | 34FF |  |  | 2004-04-19 | 2004-04-19 | 0d | 1.75d | 0d |  | STEREO | IMPACT | Boom Suite | Boom | Boom | UC-B |  |  |  |  |
| 36 | 1.1.5.45 | Deliver FM 2 MAG For FM 2 Boom Suite I & T | milestone | 0d | 2004-02-17 | 2004-02-17 |  |  |  | 2004-01-19 | 2004-01-19 | 0d | 65d | 0d |  | STEREO | IMPACT | Boom Suite | Boom | Boom | UC-B |  |  |  |  |
| 37 | 1.2.5.3.6 | Receive MAG FM 2 For BOOM Suite I & T | milestone | 0d | 2004-02-17 | 2004-02-17 | 36 |  |  | 2004-01-19 | 2004-01-19 | 0d | 65d |  |  | STEREO | IMPACT | Boom Suite | Boom | Boom | UC-B |  |  |  |  |
| 38 | 1.1.5.31 | Deliver IDPU FM 2 For BOOM Suite I & T | milestone | 0d | 2004-04-21 | 2004-04-21 |  |  |  | 2004-04-08 | 2004-04-08 | 0d | -8.75d | 0d | finish no later than 2004-04-08 | STEREO | IMPACT | Boom Suite | Boom | Boom | UC-B |  |  |  |  |
| 39 | 1.2.5.3.8 | Receive IDPU FM 2 For BOOM Suite/IDPU I & T | milestone | 0d | 2004-04-21 | 2004-04-21 | 38 |  |  | 2004-04-08 | 2004-04-08 | 0d | 10d | 8.25d |  | STEREO | IMPACT | Boom Suite | Boom | Boom | UC-B |  |  |  |  |
| 40 | 1.1.67.3 | Deliver BOOM Suite FM 2 After EMC Testing | milestone | 0d | 2004-05-28 | 2004-05-28 |  |  |  | 2004-06-09 | 2004-06-09 | 0d | 0d |  |  | STEREO | IMPACT | Boom Suite | Boom | Boom | UC-B | Boom |  |  |  |
| 41 | 1.2.5.3.10 | Receive BOOM Suite FM 2 From IMPACT Suite EMC Testing | milestone | 0d | 2004-06-07 | 2004-06-07 | 40FS+5d |  |  | 2004-06-22 | 2004-06-22 | 0d | 0d |  |  | STEREO | IMPACT | Boom Suite | Boom | Boom | UC-B |  |  |  |  |
| 42 | 1.1.5.37 | Deliver IDPU FM 2 For Final BOOM Suite I & T | milestone | 0d | 2004-03-30 | 2004-03-30 |  |  |  | 2000-01-01 | 2000-01-01 | 0d | 68d | 0d | start no earlier than 2003-04-30 | STEREO | IMPACT | Boom Suite | Boom | Boom | UC-B |  |  |  |  |
| 43 | 1.2.5.3.12 | Receive IDPU FM 2 For Final BOOM Suite I & T | milestone | 0d | 2004-03-30 | 2004-03-30 | 42 |  |  | 2003-02-01 | 2003-02-01 | 0d | 68d |  | start no earlier than 2003-05-31 | STEREO | IMPACT | Boom Suite | Boom | Boom | UC-B |  |  |  |  |
| 44 | 1.1.3.7 | Deliver SWEA/STE-D FM 2 For FM 2 BOOM Suite I & T | milestone | 0d | 2004-05-03 | 2004-05-03 |  |  |  | 2004-05-04 | 2004-05-04 | 0d | 0d |  |  | STEREO | IMPACT | Boom Suite | Boom | Boom | UC-B | Boom |  |  |  |
| 45 | 1.2.5.3.14 | Receive SWEA/STE-D FM 2 For BOOM Suite I & T | milestone | 0d | 2004-05-03 | 2004-05-03 | 44FF |  |  | 2004-05-04 | 2004-05-04 | 0d | 29d | 0d |  | STEREO | IMPACT | Boom Suite | Boom | Boom | UC-B |  |  |  |  |
| 46 | 1.1.13 | Instrument CDR | milestone | 3d | 2002-11-20 A | 2002-11-22 A |  | 100% |  | 2002-11-20 | 2002-11-22 | 3d |  |  | finish no earlier than 2002-11-22 | STEREO | IMPACT | Boom Suite | Boom | Boom | UC-B | Boom |  |  |  |
| 47 | 1.2.6 | **Deliverables** |  | 500.75d | 2002-07-01 A | 2004-06-28 |  |  | 500.75d | 2002-07-01 | 2004-07-27 | 521d | 9.25d |  |  | STEREO | IMPACT | Boom Suite | Boom | Boom | UC-B |  |  |  |  |
| 48 | 1.2.6.1 | Deliver Thermal Models | milestone | 0d | 2002-07-01 A | 2002-07-01 A |  | 100% |  | 2002-07-01 | 2002-07-01 | 0d |  |  | start no earlier than 2002-07-01 | STEREO | IMPACT | Boom Suite | Boom | Boom | UC-B |  |  |  |  |
| 49 | 1.2.6.2 | **FM 1** |  | 51.75d | 2004-04-12 | 2004-06-24 |  |  |  | 2004-04-01 | 2004-07-14 | 72d | 8.75d |  |  | STEREO | IMPACT | Boom Suite | Boom | Boom | UC-B |  |  |  |  |
| 50 | 1.2.6.2.1 | Deliver IDPU FM 1 After BOOM Suite/IDPU I & T | milestone | 0d | 2004-04-19 | 2004-04-19 | 68FS+5d |  |  | 2004-04-08 | 2004-04-08 | 0d | 58d | 0d |  | STEREO | IMPACT | Boom Suite | Boom | Boom | UC-B |  |  |  |  |
| 51 | 1.1.4.28 | Receive IDPU FM 1 From BOOM Suite/IDPU I & T | milestone | 0d | 2004-04-19 | 2004-04-19 | 50 |  |  | 2004-04-08 | 2004-04-08 | 0d | -19d | 0d |  | STEREO | IMPACT | Boom Suite | Boom | Boom | UC-B |  |  |  |  |
| 52 | 1.2.6.2.3 | Deliver BOOM Suite FM 1 For EMC Testing | milestone | 0d | 2004-04-12 | 2004-04-12 | 3, 8 |  |  | 2004-04-01 | 2004-04-01 | 0d | 19d | 0d |  | STEREO | IMPACT | Boom Suite | Boom | Boom | UC-B |  |  |  |  |
| 53 | 1.1.66.2 | Receive BOOM Suite FM 1 For EMC Testing | milestone | 0d | 2004-04-19 | 2004-04-19 | 52FS+5d |  |  | 2004-04-08 | 2004-04-08 | 0d | -19d | 0d |  | STEREO | IMPACT | Boom Suite | Boom | Boom | UC-B | Boom |  |  |  |
| 54 | 1.2.6.2.5 | BOOM Suite FM 1 Complete | milestone | 0d | 2004-06-24 | 2004-06-24 | 4, 16 |  |  | 2004-07-14 | 2004-07-14 | 0d | 2d | 0d |  | STEREO | IMPACT | Boom Suite | Boom | Boom | UC-B |  | FM1 Rdy | BOOM Suite - FM 1 Ready For Delivery | BOOM Suite FM 1 Complete |
| 55 | 1.1.2.2 | Receive BOOM FM 1 For BOOM Suite Delivery | milestone | 0d | 2004-06-24 | 2004-06-24 | 54 |  |  | 2004-07-14 | 2004-07-14 | 0d | -15.55d | 0d |  | STEREO | IMPACT | Boom Suite | Boom | Boom | UC-B |  |  |  |  |

| ID | WBS | Task | Type | Duration | Start | Finish | Predecessors | Baseline start | Baseline finish | Baseline duration | Total slack | Free slack | Constraint | Text11 | Text12 | Text13 | Text14 | Text16 | Text28 | Text17 | Text20 | Text22 | Text23 | Text21 |
| --- | --- | --- | --- | --- | --- | --- | --- | --- | --- | --- | --- | --- | --- | --- | --- | --- | --- | --- | --- | --- | --- | --- | --- | --- |
| 56 | 1.2.6.3 | **FM 2** |  | 28.75d | 2004-05-17 | 2004-06-28 |  | 2004-06-04 | 2004-07-27 | 36d | 3.75d |  |  | STEREO | IMPACT | Boom Suite | Boom | Boom | UC-B |  |  |  |  |  |
| 57 | 1.2.6.3.1 | Deliver IDPU FM 2 After BOOM Suite/IDPU I & T | milestone | 0d | 2004-05-17 | 2004-05-17 | 74 | 2004-06-04 | 2004-06-04 | 0d | 38d | 0d |  | STEREO | IMPACT | Boom Suite | Boom | Boom | UC-B |  |  |  |  |  |
| 58 | 1.1.4.30 | Receive IDPU FM 2 From BOOM Suite/IDPU I & T | milestone | 0d | 2004-05-17 | 2004-05-17 | 57 | 2004-06-09 | 2004-06-09 | 0d | 38d |  |  | STEREO | IMPACT | Boom Suite | Boom | Boom | UC-B |  |  |  |  |  |
| 59 | 1.2.6.3.3 | Deliver BOOM Suite FM 2 For EMC Testing | milestone | 0d | 2004-05-19 | 2004-05-19 | 5 | 2004-06-08 | 2004-06-08 | 0d | 1.75d | 0d |  | STEREO | IMPACT | Boom Suite | Boom | Boom | UC-B |  |  |  |  |  |
| 60 | 1.1.66.4 | Receive BOOM Suite FM 2 For EMC Testing | milestone | 0d | 2004-05-19 | 2004-05-19 | 59 | 2004-06-02 | 2004-06-02 | 0d | 1.75d |  |  | STEREO | IMPACT | Boom Suite | Boom | Boom | UC-B | Boom |  |  |  |  |
| 61 | 1.2.6.3.5 | BOOM Suite FM 2 Complete | milestone | 0d | 2004-06-28 | 2004-06-28 | 6 | 2004-07-27 | 2004-07-27 | 0d | 0d |  |  | STEREO | IMPACT | Boom Suite | Boom | Boom | UC-B |  | FM2 Rdy | BOOM Suite - FM 2 Ready For Delivery | BOOM Suite FM 2 Complete |  |
| 62 | 1.1.2.4 | Receive BOOM FM 2 For BOOM Suite Delivery | milestone | 0d | 2004-06-28 | 2004-06-28 | 61 | 2004-07-23 | 2004-07-23 | 0d | 0d |  |  | STEREO | IMPACT | Boom Suite | Boom | Boom | UC-B |  |  |  |  |  |
| 63 | 1.3 | **Documentation** |  | 5d | 2003-06-02 | 2003-06-06 |  | 2003-02-03 | 2003-02-07 | 5d | 275.75d |  |  | STEREO | IMPACT | Boom Suite | Boom | Boom | UC-B |  |  |  |  |  |
| 64 | 1.3.1 | Test Plan |  | 5d | 2003-06-02 | 2003-06-06 |  | 2003-02-03 | 2003-02-07 | 5d | 285d |  | start no earlier than 2003-05-31 | STEREO | IMPACT | Boom Suite | Boom | Boom | UC-B |  |  |  |  |  |
| 65 | 2 | **Integration & Test** |  | 93.75d | 2004-02-17 | 2004-06-28 |  | 2004-02-05 | 2004-07-14 | 112d | 0d |  |  | STEREO | IMPACT | Boom Suite | Boom | Boom | UC-B |  |  |  |  |  |
| 66 | 2.1 | **FM 1** |  | 84.75d | 2004-02-17 | 2004-06-15 |  | 2004-02-05 | 2004-06-08 | 87d | 2d |  |  | STEREO | IMPACT | Boom Suite | Boom | Boom | UC-B |  |  |  |  |  |
| 67 | 2.1.1 | FM 1 Boom/SWEA/STE/MAG I&T |  | 20d | 2004-02-17 | 2004-03-15 | 22FS-6d, 20, 24, 18 | 2004-02-05 | 2004-03-04 | 20d | 19d | 0d |  | STEREO | IMPACT | Boom Suite | Boom | Boom | UC-B |  | Begin FM 1 I & T |  |  | Begin FM 1 I & T / Boom/SWEA/STE/MAG |
| 68 | 2.1.2 | FM 1 Integrated Boom/IDPU I&T |  | 20d | 2004-03-16 | 2004-04-12 | 26, 67 | 2004-03-05 | 2004-04-01 | 20d | 19d | 0d |  | STEREO | IMPACT | Boom Suite | Boom | Boom | UC-B |  |  |  |  | BOOM/IDPU |
| 69 | 2.1.3 | BOOM Suite FM 1 Vib |  | 2d | 2004-05-21 | 2004-05-25 | 28 | 2004-05-17 | 2004-05-18 | 2d | 2d | 0d |  | STEREO | IMPACT | Boom Suite | Boom | Boom | UC-B |  |  |  |  |  |
| 70 | 2.1.4 | BOOM Suite FM 1 Bakeout |  | 5d | 2004-05-25 | 2004-06-02 | 69, 30 | 2004-05-19 | 2004-05-25 | 5d | 2d | 0d |  | STEREO | IMPACT | Boom Suite | Boom | Boom | UC-B |  |  |  |  |  |
| 71 | 2.1.5 | Final BOOM Suite FM 1 I & T |  | 9d | 2004-06-02 | 2004-06-15 | 70 | 2004-05-26 | 2004-06-08 | 9d | 2d | 0d |  | STEREO | IMPACT | Boom Suite | Boom | Boom | UC-B |  |  |  |  | Final BOOM I&T |
| 72 | 2.2 | **FM 2** |  | 48.75d | 2004-04-20 | 2004-06-28 |  | 2004-05-07 | 2004-07-14 | 47d | 0d |  |  | STEREO | IMPACT | Boom Suite | Boom | Boom | UC-B |  |  |  |  |  |
| 73 | 2.2.1 | FM 2 Boom/SWEA/STE/MAG I&T |  | 10d | 2004-04-20 | 2004-05-03 | 45FF-8d, 35, 37 | 2004-05-07 | 2004-05-20 | 10d | 1.75d | 0d |  | STEREO | IMPACT | Boom Suite | Boom | Boom | UC-B |  | Begin FM 2 I & T |  |  | Begin FM 2 I & T / Boom/SWEA/STE/MAG |
| 74 | 2.2.2 | FM 2 Integrated Boom/IDPU I&T |  | 10d | 2004-05-04 | 2004-05-17 | 39, 73 | 2004-05-21 | 2004-06-04 | 10d | 1.75d | 0d |  | STEREO | IMPACT | Boom Suite | Boom | Boom | UC-B |  |  |  |  | BOOM/IDPU |
| 75 | 2.2.3 | BOOM Suite FM 2 Vib |  | 2d | 2004-05-18 | 2004-05-19 | 74, 10 | 2004-06-07 | 2004-06-08 | 2d | 1.75d | 0d |  | STEREO | IMPACT | Boom Suite | Boom | Boom | UC-B |  |  |  |  |  |
| 76 | 2.2.4 | BOOM Suite FM 2 Bakeout |  | 5d | 2004-06-07 | 2004-06-14 | 43, 41 | 2004-06-23 | 2004-06-29 | 5d | 0d |  |  | STEREO | IMPACT | Boom Suite | Boom | Boom | UC-B |  |  |  |  |  |
| 77 | 2.2.5 | Final BOOM Suite FM 2 I & T |  | 10d | 2004-06-14 | 2004-06-28 | 76, 41 | 2004-06-30 | 2004-07-14 | 10d | 0d |  |  | STEREO | IMPACT | Boom Suite | Boom | Boom | UC-B |  |  |  |  | Final BOOM I & T |

Notes:
- 67: March 03 Status - place a 6 day lag into the I & T effort before the SWEA/STE-D are integrated into the suite.
- 73: March 03 Status - Delayed need of SWEA/STE-D FM 2 till 8 days into Boom Suite FM 2 I & T
