# PC - Power Converters

Schedule from MS Project, 2000-07-31 to 2004-02-19, status date 2003-05-31, A marks actual dates.
Common Power Converters Development Schedule
NASA GSFC
Status Date: 05/31/2003 / Baseline Date: 01/31/2003 R1

## Calendars

- Standard w/ 10 Gov't Holidays: Mon-Fri 08:00-12:00, 13:00-17:00; Sat-Sun off. Exceptions (off unless hours are given): 2000-09-04, 2000-10-09, 2000-11-13, 2000-11-23, 2000-12-25, 2001-01-01, 2001-01-15, 2001-02-19, 2001-05-28, 2001-07-04, 2001-09-03, 2001-10-08, 2001-11-12, 2001-11-22, 2001-12-25, 2002-01-01, 2002-01-14, 2002-02-18, 2002-05-27, 2002-07-04, 2002-09-02, 2002-10-07, 2002-11-11, 2002-11-28, 2002-12-25, 2003-01-01, 2003-01-13, 2003-02-17, 2003-05-26, 2003-07-04, 2003-09-01, 2003-10-06, 2003-11-10, 2003-11-27, 2003-12-25, 2004-01-01, 2004-01-12, 2004-02-16.

## Schedule

| ID | WBS | Task | Type | Duration | Start | Finish | Predecessors | Complete | Remaining | Baseline start | Baseline finish | Baseline duration | Total slack | Free slack | Constraint | Text11 | Text12 | Text28 | Text13 | Text14 | Text15 | Text16 | Text17 |
| --- | --- | --- | --- | --- | --- | --- | --- | --- | --- | --- | --- | --- | --- | --- | --- | --- | --- | --- | --- | --- | --- | --- | --- |
| 1 | 1 | **Management** |  | 890.75d | 2000-07-31 A | 2004-02-19 |  | 99% | 0d | 2000-07-31 | 2004-01-09 | 864d | 0d |  |  | STEREO | IMPACT | UC-B |  |  |  |  |  |
| 2 | 1.1 | **Milestones** |  | 890.75d | 2000-07-31 A | 2004-02-19 |  | 99% | 0d | 2000-07-31 | 2004-01-09 | 864d | 0d |  |  | STEREO | IMPACT | UC-B |  |  |  |  |  |
| 3 | 1.1.1 | **Contingency Blocks** |  | 345.75d | 2002-10-01 A | 2004-02-19 |  | 99% | 0d | 2002-10-01 | 2004-01-09 | 319d | -26.75d | 0d |  | STEREO | IMPACT | UC-B |  |  |  |  |  |
| 4 | 1.1.1.1 | IDPU ETU LVPS Contingency |  | 1d | 2003-02-05 A | 2003-02-05 A | 158 | 100% |  | 2003-02-04 | 2003-02-10 | 5d |  |  |  | STEREO | IMPACT | UC-B | IDPU | PS | LVPS Card | IDPU | LVPS |
| 5 | 1.1.1.2 | IDPU FM 1 LVPS Contingency | milestone | 0d | 2003-08-20 | 2003-08-20 | 178 |  |  | 2003-06-02 | 2003-10-08 | 90d | 37d | 0d |  | STEREO | IMPACT | UC-B | IDPU | PS | LVPS Card | IDPU | LVPS |
| 6 | 1.1.1.3 | IDPU FM 2 LVPS Contingency | milestone | 0d | 2003-11-17 | 2003-11-17 | 189 |  |  | 2003-08-26 | 2004-01-05 | 89d | 36d | 0d |  | STEREO | IMPACT | UC-B | IDPU | PS | LVPS Card | IDPU | LVPS |
| 7 | 1.1.1.4 | SEP ETU LVPS Contingency | milestone | 0d | 2003-07-21 | 2003-07-21 | 159 |  |  | 2003-05-05 | 2003-05-05 | 0d | -31.75d | 0d |  | STEREO | IMPACT | UC-B | SEP Package | PS | LVPS Card | SEP DPU | LVPS |
| 8 | 1.1.1.5 | SEP FM 1 LVPS Contingency | milestone | 0d | 2003-11-20 | 2003-11-20 | 179 |  |  | 2003-09-16 | 2003-10-13 | 19d | -25.75d | 0d |  | STEREO | IMPACT | UC-B | SEP Package | PS | LVPS Card | SEP DPU | LVPS |
| 9 | 1.1.1.6 | SEP FM 2 LVPS Contingency | milestone | 0d | 2004-02-19 | 2004-02-19 | 193 |  |  | 2003-12-12 | 2003-12-17 | 4d | -31.75d | 0d |  | STEREO | IMPACT | UC-B | SEP Package | PS | LVPS Card | SEP DPU | LVPS |
| 10 | 1.1.1.7 | SWEA/STE-D ETU LVPS Contingency | milestone | 0d | 2003-05-14 A | 2003-05-14 A | 160 | 100% |  | 2003-04-18 | 2003-04-18 | 0d |  |  | start no earlier than 2003-05-31 | STEREO | IMPACT | UC-B | Boom Suite | PS | LVPS Card | SWEA/STE-D | LVPS |
| 11 | 1.1.1.8 | SWEA/STE-D FM 1 LVPS Contingency | milestone | 0d | 2003-10-21 | 2003-10-21 | 180 |  |  | 2003-08-26 | 2003-10-14 | 34d | -5d | 0d |  | STEREO | IMPACT | UC-B | Boom Suite | PS | LVPS Card | SWEA/STE-D | LVPS |
| 12 | 1.1.1.9 | SWEA/STE-D FM 2 LVPS Contingency | milestone | 0d | 2004-01-20 | 2004-01-20 | 197 |  |  | 2003-11-21 | 2004-01-09 | 33d | -6d | 0d |  | STEREO | IMPACT | UC-B | Boom Suite | PS | LVPS Card | SWEA/STE-D | LVPS |
| 13 | 1.1.1.10 | PLASTIC ETU LVPS Contingency | milestone | 0d | 2003-06-20 | 2003-06-20 | 161 |  |  | 2003-04-22 | 2003-06-09 | 34d | -8.5d | 0d |  | STEREO | PLASTIC | UC-B | PLASTIC | PS | LVPS Card |  | LVPS |
| 14 | 1.1.1.11 | PLASTIC FM 1 LVPS Contingency | milestone | 0d | 2003-10-08 | 2003-10-08 | 181 |  |  | 2003-10-08 | 2003-10-08 | 0d | 4d | 0d |  | STEREO | PLASTIC | UC-B | PLASTIC | PS | LVPS Card |  | LVPS |
| 15 | 1.1.1.12 | PLASTIC FM 2 LVPS Contingency | milestone | 0d | 2004-01-05 | 2004-01-05 | 201 |  |  | 2004-01-05 | 2004-01-05 | 0d | 4d | 0d |  | STEREO | PLASTIC | UC-B | PLASTIC | PS | LVPS Card |  | LVPS |
| 16 | 1.1.1.13 | SIT ETU HVPS Contingency | milestone | 0d | 2002-10-01 A | 2002-10-01 A | 162 | 100% |  | 2002-10-01 | 2002-10-01 | 0d |  |  | start no earlier than 2002-09-30 | STEREO | IMPACT | UC-B | SEP Package | PS | HVPS Card | SIT | HVPS |
| 17 | 1.1.1.14 | SIT FM 1 HVPS Contingency | milestone | 0d | 2003-06-30 | 2003-06-30 | 184 |  |  | 2003-03-31 | 2003-03-31 | 0d | 19.25d | 0d |  | STEREO | IMPACT | UC-B | SEP Package | PS | HVPS Card | SIT | HVPS |
| 18 | 1.1.1.15 | SIT FM 2 HVPS Contingency | milestone | 0d | 2003-09-09 | 2003-09-09 | 205 |  |  | 2003-08-05 | 2003-08-05 | 0d | 15d | 0d |  | STEREO | IMPACT | UC-B | SEP Package | PS | HVPS Card | SIT | HVPS |
| 19 | 1.1.2 | **Receivables** |  | 204.75d | 2002-10-17 A | 2003-08-11 |  | 99% | 0d | 2002-10-17 | 2003-06-27 | 175d | -4.75d | 0d |  | STEREO | IMPACT | UC-B |  |  |  |  |  |
| 20 | 1.1.3.1 | Deliver SIT ETU/SIT HVPS ETU I/F Test Results to UC-B |  | 1d | 2002-10-16 A | 2002-10-16 A |  | 100% |  | 2002-10-16 | 2002-10-16 | 1d |  |  |  | STEREO | IMPACT |  |  |  |  |  |  |
| 21 | 1.1.2.2 | Receive SIT HVPS ETU/SIT ETU I/F Test Results from UMD | milestone | 0d | 2002-10-17 A | 2002-10-17 A | 20 | 100% |  | 2002-10-17 | 2002-10-17 | 0d |  |  |  | STEREO | IMPACT |  |  |  |  |  |  |
| 22 | 1.1.5.20 | Deliver IDPU ETU/IDPU LVPS I/F Test Results |  | 1d | 2003-02-10 A | 2003-02-10 A |  | 100% |  | 2003-02-25 | 2003-02-25 | 1d |  |  |  | STEREO | IMPACT |  |  |  |  |  |  |
| 23 | 1.1.2.4 | Receive IDPU LVPS ETU/IDPU ETU I/F Test Results |  | 1d | 2003-02-14 A | 2003-02-14 A | 22 | 100% |  | 2003-02-25 | 2003-02-25 | 1d |  |  |  | STEREO | IMPACT |  |  |  |  |  |  |
| 24 | 1.1.6.6 | Deliver SEP ETU LVPS Test Feedback to UC-B | milestone | 0d | 2003-08-11 | 2003-08-11 |  |  |  | 2003-06-05 | 2003-06-05 | 0d | -31.75d | 0d |  | STEREO | IMPACT |  |  |  |  |  |  |
| 25 | 1.1.2.6 | Receive SEP LVPS ETU/SEP Central ETU I/F Test Results | milestone | 0d | 2003-08-11 | 2003-08-11 | 24 |  |  | 2003-06-05 | 2003-06-05 | 0d | -31.75d | 0d |  | STEREO | IMPACT |  |  |  |  |  |  |
| 26 | 1.1.3.17 | Deliver SWEA/STE-D ETU/SWEA LVPS ETU I/F Test Results | milestone | 0d | 2003-07-14 | 2003-07-14 |  |  |  | 2003-05-16 | 2003-05-16 | 0d | -23d | 0d |  | STEREO | IMPACT |  |  |  |  |  |  |
| 27 | 1.1.2.8 | Receive SWEA LVPS ETU/SWEA I/F Test Results | milestone | 0d | 2003-07-14 | 2003-07-14 | 26 |  |  | 2003-05-16 | 2003-05-16 | 0d | -23d | 0d |  | STEREO | IMPACT |  |  |  |  |  |  |
| 28 | 1.1.2.9 | Receive PLASTIC LVPS ETU/PLASTIC ETU I/F Test Results | milestone | 0d | 2003-06-27 | 2003-06-27 |  |  |  | 2003-06-27 | 2003-06-27 | 0d | 4d | 0d | finish no earlier than 2003-06-27 | STEREO | IMPACT |  |  |  |  |  |  |
| 29 | 1.1.3.2 | Deliver SIT ETU / SIT HVPS FM 1 I/F Test Results to UC-B | milestone | 0d | 2003-07-14 | 2003-07-14 |  |  |  | 2003-06-09 | 2003-06-09 | 0d | 15d | 0d |  | STEREO | IMPACT |  |  |  |  |  |  |
| 30 | 1.1.2.11 | Receive SIT HVPS FM 1/SIT ETU I/F Test Results from UMD | milestone | 0d | 2003-07-14 | 2003-07-14 | 29 |  |  | 2003-06-09 | 2003-06-09 | 0d | 15d | 0d |  | STEREO | IMPACT |  |  |  |  |  |  |

Notes:
- 5: March 03 Status - Removed 17 days of contingency. Dropped from 90 to 73 days.
- 6: March 03 Status - Removed 17 days of contingency. Dropped from 89 to 72 days.
- 8: March 03 Status - Removed 18 days of contingency. Dropped it to 1 day.
- 9: March 03 Status - Removed 4 days of contingency.
- 11: March 03 Status - Removed 16 days of contingency. Dropped from 34 to 18 days.
- 12: March 03 Status - Removed 16 days of contingency. Dropped from 33 to 17 days.
- 13: Mar 03 status - Removed 8 days duration. Check with Dave Curtis.
- 28: Created arbitrary date of 6/27/03 based on e-mail in January from Kevin Milligan stating the PLASTIC EM testing was going to occur the week of 6/16. I've assumed that the test is 1 week and than a week to report the results.

| ID | WBS | Task | Type | Duration | Start | Finish | Predecessors | Complete | Remaining | Baseline start | Baseline finish | Baseline duration | Total slack | Free slack | Constraint | Text11 | Text12 | Text28 | Text14 | Text15 | Text16 | Text13 | Text17 | Text20 | Text21 | Text22 | Text23 |
| --- | --- | --- | --- | --- | --- | --- | --- | --- | --- | --- | --- | --- | --- | --- | --- | --- | --- | --- | --- | --- | --- | --- | --- | --- | --- | --- | --- |
| 31 | 1.1.3 | **Deliverables** |  | 890.75d | 2000-07-31 A | 2004-02-19 |  | 99% | 0d | 2000-07-31 | 2004-01-09 | 864d | 0d |  |  | STEREO | IMPACT | UC-B |  |  |  |  |  |  |  |  |  |
| 32 | 1.1.3.1 | Deliver Draft LVPS Requirements | milestone | 0d | 2000-07-31 A | 2000-07-31 A |  | 100% |  | 2000-07-31 | 2000-07-31 | 0d |  |  | finish no earlier than 2000-07-31 | STEREO | IMPACT | UC-B | PS | LVPS Card | LVPS |  |  |  |  |  |  |
| 33 | 1.1.3.2 | Deliver Final (Frozen) LVPS Requirements | milestone | 0d | 2001-12-15 A | 2001-12-15 A |  | 100% |  | 2001-12-15 | 2001-12-15 | 0d |  |  | finish no earlier than 2001-12-15 | STEREO | IMPACT | UC-B | PS | LVPS Card | LVPS |  |  |  |  |  |  |
| 34 | 1.1.3.3 | **ETU** |  | 200.75d | 2002-10-01 A | 2003-07-21 |  | 99% | 0d | 2002-10-01 | 2003-06-09 | 172d | 145d |  |  | STEREO | IMPACT |  |  |  |  |  |  |  |  |  |  |
| 35 | 1.1.3.3.1 | Deliver IDPU ETU LVPS |  | 1d | 2003-02-05 A | 2003-02-05 A | 4 | 100% |  | 2003-02-10 | 2003-02-10 | 1d |  |  | finish no later than 2003-02-10 | STEREO | IMPACT | UC-B | PS | LVPS Card | IDPU | Boom Suite | LVPS | IDPU ETU LVPS | ETU IDPU LVPS | IDPU - ETU LVPS Available | IDPU ETU LVPS Delivered |
| 36 | 1.1.4.2 | Receive ETU IDPU LVPS From UC-B | milestone | 0d | 2003-02-05 A | 2003-02-05 A | 35 | 100% |  | 2003-02-10 | 2003-02-10 | 0d |  |  |  | STEREO | IMPACT |  |  |  |  |  |  |  |  |  |  |
| 37 | 1.1.3.3.3 | Deliver SEP ETU LVPS to CIT | milestone | 0d | 2003-07-21 | 2003-07-21 | 7 |  |  | 2003-05-05 | 2003-05-05 | 0d | -31.75d | 0d | finish no later than 2003-07-21 | STEREO | IMPACT | UC-B | PS | LVPS Card | SEP DPU | SEP Package | LVPS | SEP ETU LVPS | ETU SEP LVPS | SEP - ETU LVPS Available | SEP ETU LVPS Delivered |
| 38 | 1.1.5.4.2 | Receive SEP LVPS ETU From UC-B | milestone | 0d | 2003-07-21 | 2003-07-21 | 37 |  |  |  |  |  | -31.75d | 0d |  | STEREO | IMPACT |  |  |  |  |  |  |  |  |  |  |
| 39 | 1.1.3.3.5 | Deliver SWEA/STE-D ETU LVPS | milestone | 0d | 2003-05-14 A | 2003-05-14 A | 10 | 100% |  | 2003-04-18 | 2003-04-18 | 0d |  |  | start no earlier than 2003-05-31 | STEREO | IMPACT | UC-B | PS | LVPS Card | SWEA/STE-D | Boom Suite | LVPS | SWEA ETU LVPS | ETU SWEA/STE LVPS | SWEA/STE-D - ETU LVPS Available | SWEA/STE-D ETU LVPS Delivered |
| 40 | 1.1.2.8 | Receive SWEA/STE-D ETU LVPS From UC-B | milestone | 0d | 2003-05-14 A | 2003-05-14 A | 39 | 100% |  | 2003-04-18 | 2003-04-18 | 0d |  |  |  | STEREO | IMPACT |  |  |  |  |  |  |  |  |  |  |
| 41 | 1.1.3.3.7 | Deliver PLASTIC ETU LVPS | milestone | 0d | 2003-06-20 | 2003-06-20 | 13 |  |  | 2003-06-09 | 2003-06-09 | 0d | -8.5d | 0d | finish no later than 2003-06-09 | STEREO | PLASTIC | UC-B | PS | LVPS Card |  | PLASTIC |  |  | ETU PLASTIC LVPS to UNH | PLASTIC - ETU LVPS Available | PLASTIC ETU LVPS Delivered |
| 42 | 1.1.3.3.8 | Deliver SIT ETU HVPS | milestone | 0d | 2002-10-01 A | 2002-10-01 A | 16 | 100% |  | 2002-10-01 | 2002-10-01 | 0d |  |  | start no earlier than 2002-09-30 | STEREO | IMPACT | UC-B | PS | HVPS Card | SIT | SEP Package | HVPS |  | ETU SIT HVPS | SIT - ETU HVPS Available | SIT ETU HVPS Delivered |
| 43 | 1.1.3.3.9 | IMPACT Suite ETU Power Supplies Complete | milestone | 0d | 2003-07-21 | 2003-07-21 | 35, 37, 39, 42 |  |  | 2003-05-05 | 2003-05-05 | 0d | 145d |  |  | STEREO | IMPACT |  |  |  |  |  |  |  |  |  |  |
| 44 | 1.1.2.9 | Receive ETU HVPS From UC-B |  | 1d | 2002-10-01 A | 2002-10-01 A | 42 | 100% |  | 2002-10-01 | 2002-10-01 | 1d |  |  | start no earlier than 2002-09-30 | STEREO | IMPACT |  |  |  |  |  |  |  |  |  |  |
| 45 | 1.1.3.4 | **FM 1** |  | 99d | 2003-06-30 | 2003-11-20 |  |  |  | 2003-03-31 | 2003-10-14 | 137d | -25.75d | 0d |  | STEREO | IMPACT |  |  |  |  |  |  |  |  |  |  |
| 46 | 1.1.3.4.1 | FM 1 Power Supplies Complete | milestone | 0d | 2003-11-20 | 2003-11-20 | 47, 49, 51, 53, 54 |  |  | 2003-10-14 | 2003-10-14 | 0d | -25.75d | 0d | finish no later than 2003-10-14 | STEREO | IMPACT |  | PS |  |  |  |  | FM 1 PWR Supplies | FM 1 Pwr Supplies / Bar 3 FM 1 Power Supplies | IMPACT - FM 1 Power Supplies Complete | FM 1 Power Supplies Complete |
| 47 | 1.1.3.4.2 | Deliver IDPU FM 1 LVPS | milestone | 0d | 2003-08-20 | 2003-08-20 | 5 |  |  | 2003-10-08 | 2003-10-08 | 0d | 37d | 0d |  | STEREO | IMPACT | UC-B | PS | LVPS Card | IDPU | Boom Suite | LVPS | IDPU FM 1 LVPS | FM1 Power Supplies |  | IDPU FM 1 LVPS Delivered |
| 48 | 1.1.4.4 | Receive FM 1 IDPU LVPS From UC-B | milestone | 0d | 2003-08-20 | 2003-08-20 | 47 |  |  | 2003-10-08 | 2003-10-08 | 0d | 58d |  |  | STEREO | IMPACT |  |  |  |  |  |  |  |  |  |  |
| 49 | 1.1.3.4.4 | Deliver SEP FM 1 LVPS to CIT | milestone | 0d | 2003-11-20 | 2003-11-20 | 8 |  |  | 2003-10-13 | 2003-10-13 | 0d | -25.75d | 0d |  | STEREO | IMPACT | UC-B | PS | LVPS Card | SEP DPU | SEP Package | LVPS | SEP FM 1 LVPS | FM1 Power Supplies |  | SEP FM 1 LVPS Delivered |
| 50 | 1.1.5.4.4 | Receive SEP LVPS FM 1 From UC-B | milestone | 0d | 2003-11-20 | 2003-11-20 | 49 |  |  | 2003-10-13 | 2003-10-13 | 0d | 18.25d |  | start no earlier than 2003-10-13 | STEREO | IMPACT |  |  |  |  |  |  |  |  |  |  |
| 51 | 1.1.3.4.6 | Deliver SWEA/STE-D FM 1 LVPS | milestone | 0d | 2003-10-21 | 2003-10-21 | 11 |  |  | 2003-10-14 | 2003-10-14 | 0d | -5d | 0d |  | STEREO | IMPACT | UC-B | PS | LVPS Card | SWEA/STE-D | Boom Suite | LVPS | SWEA FM 1 LVPS | FM1 Power Supplies |  | SWEA/STE-D FM 1 LVPS Delivered |
| 52 | 1.1.2.10 | Receive SWEA/STE-D FM 1 LVPS From UC-B | milestone | 0d | 2003-10-21 | 2003-10-21 | 51 |  |  | 2003-10-14 | 2003-10-14 | 0d | 27d |  |  | STEREO | IMPACT |  |  |  |  |  |  |  |  |  |  |
| 53 | 1.1.3.4.8 | Deliver PLASTIC FM 1 LVPS | milestone | 0d | 2003-10-08 | 2003-10-08 | 14 |  |  | 2003-10-08 | 2003-10-08 | 0d | 4d |  |  | STEREO | PLASTIC | UC-B | PS | LVPS Card |  | PLASTIC |  |  | FM1 Power Supplies |  | PLASTIC FM 1 LVPS Delivered |
| 54 | 1.1.3.4.9 | Deliver SIT FM 1 HVPS | milestone | 0d | 2003-06-30 | 2003-06-30 | 17 |  |  | 2003-03-31 | 2003-03-31 | 0d | 19.25d | 0d |  | STEREO | IMPACT | UC-B | PS | HVPS Card | SIT | SEP Package | HVPS |  | FM 2 Power Supplies |  | SIT FM 1 HVPS Delivered |
| 55 | 1.1.2.11 | Receive FM 1 HVPS From UC-B | milestone | 0d | 2003-06-30 | 2003-06-30 | 54 |  |  | 2003-03-31 | 2003-03-31 | 0d | 19.25d |  |  | STEREO | IMPACT |  |  |  |  |  |  |  |  |  |  |

Notes:
- 37: Changed Delivery date from 10/8/02 to 3/31/03 based on comment from CIT, 1/8/03 / 2003 May Status - Delivery date moved to 7/21/03
- 39: FNL of 8/31/02 removed 1/9/03
- 41: FNL of 11/1/02 removed 1/9/03
- 42: This activity at one time was a critical milestone however with the new way Tom Parr wants to do the chart it can't remain tagged as critical, therfore for historical purposes Bob Palfy created this note.
- 46: FNL of 6/3/03 removed 1/9/03
- 47: FNL of 6/3/03 removed 1/9/03
- 49: FNL of 6/3/03 removed 1/9/03
- 51: FNL of 6/3/03 removed 1/9/03
- 53: FNL of 6/3/03 removed 1/9/03
- 54: FNL of 6/3/03 removed 1/9/03

| ID | WBS | Task | Type | Duration | Start | Finish | Predecessors | Complete | Remaining | Baseline start | Baseline finish | Baseline duration | Total slack | Free slack | Constraint | Text11 | Text12 | Text14 | Text20 | Text21 | Text22 | Text23 | Text13 | Text15 | Text16 | Text17 | Text28 |
| --- | --- | --- | --- | --- | --- | --- | --- | --- | --- | --- | --- | --- | --- | --- | --- | --- | --- | --- | --- | --- | --- | --- | --- | --- | --- | --- | --- |
| 56 | 1.1.3.5 | **FM 2** |  | 109.75d | 2003-09-09 | 2004-02-19 |  |  |  | 2003-08-05 | 2004-01-09 | 107.8d | -26.75d | 0d |  | STEREO | IMPACT |  |  |  |  |  |  |  |  |  |  |
| 57 | 1.1.3.5.1 | FM 2 Power Supplies Complete | milestone | 0d | 2004-02-19 | 2004-02-19 | 58, 60, 62, 64, 65 |  |  | 2004-01-09 | 2004-01-09 | 0d | -26.75d | 0d | finish no later than 2004-01-09 | STEREO | IMPACT | PS | FM 2 PWR Supplies | FM 2 Pwr Supplies / Bar 3 FM 2 Power Supplies | IMPACT - FM 2 Power Supplies Complete | FM 2 Power Supplies Complete |  |  |  |  |  |
| 58 | 1.1.3.5.2 | Deliver IDPU FM 2 LVPS | milestone | 0d | 2003-11-17 | 2003-11-17 | 6 |  |  | 2004-01-05 | 2004-01-05 | 0d | 36d | 0d |  | STEREO | IMPACT | PS | IDPU FM 2 LVPS | FM2 Power Supplies |  | IDPU FM 2 LVPS Delivered | Boom Suite | LVPS Card | IDPU | LVPS | UC-B |
| 59 | 1.1.4.6 | Receive FM 2 IDPU LVPS From UC-B | milestone | 0d | 2003-11-17 | 2003-11-17 | 58 |  |  | 2004-01-05 | 2004-01-05 | 0d | 118d |  |  | STEREO | IMPACT |  |  |  |  |  |  |  |  |  |  |
| 60 | 1.1.3.5.4 | Deliver SEP FM 2 LVPS to CIT | milestone | 0d | 2004-02-19 | 2004-02-19 | 9 |  |  | 2003-12-17 | 2003-12-17 | 0d | -31.75d | 0d |  | STEREO | IMPACT | PS | SEP FM 2 LVPS | FM2 Power Supplies |  | SEP FM 2 LVPS Delivered | SEP Package | LVPS Card | SEP DPU | LVPS | UC-B |
| 61 | 1.1.5.4.6 | Receive SEP LVPS FM 2 From UC-B | milestone | 0d | 2004-02-19 | 2004-02-19 | 60 |  |  | 2003-12-17 | 2003-12-17 | 0d | -8.75d | 0d | start no earlier than 2003-12-17 | STEREO | IMPACT |  |  |  |  |  |  |  |  |  |  |
| 62 | 1.1.3.5.6 | Deliver SWEA/STE-D FM 2 LVPS | milestone | 0d | 2004-01-20 | 2004-01-20 | 12 |  |  | 2004-01-09 | 2004-01-09 | 0d | -6d | 0d |  | STEREO | IMPACT | PS | SWEA FM 2 LVPS | FM2 Power Supplies |  | SWEA/STE-D FM 2 LVPS Delivered | Boom Suite | LVPS Card | SWEA/STE-D | LVPS | UC-B |
| 63 | 1.1.2.12 | Receive SWEA/STE-D FM 2 LVPS From UC-B | milestone | 0d | 2004-01-20 | 2004-01-20 | 62 |  |  | 2004-01-09 | 2004-01-09 | 0d | 8d |  |  | STEREO | IMPACT |  |  |  |  |  |  |  |  |  |  |
| 64 | 1.1.3.5.8 | Deliver PLASTIC FM 2 LVPS | milestone | 0d | 2004-01-05 | 2004-01-05 | 15 |  |  | 2004-01-05 | 2004-01-05 | 0d | 4d |  |  | STEREO | PLASTIC | PS |  | FM2 Power Supplies |  | PLASTIC FM 2 LVPS Delivered | PLASTIC | LVPS Card |  |  | UC-B |
| 65 | 1.1.3.5.9 | Deliver SIT FM 2 HVPS | milestone | 0d | 2003-09-09 | 2003-09-09 | 18 |  |  | 2003-08-05 | 2003-08-05 | 0d | 15d | 0d |  | STEREO | IMPACT | PS |  | FM2 Power Supplies |  | SIT FM 2 HVPS Delivered | SEP Package | HVPS Card | SIT | HVPS | UC-B |
| 66 | 1.1.2.13 | Receive FM 2 HVPS From UC-B | milestone | 0d | 2003-09-09 | 2003-09-09 | 65 |  |  | 2003-08-05 | 2003-08-05 | 0d | 15d |  |  | STEREO | IMPACT |  |  |  |  |  |  |  |  |  |  |
| 67 | 2 | **Power** |  | 890.75d | 2000-07-31 A | 2004-02-19 |  | 60% | 360.74d | 2000-07-31 | 2004-01-05 | 860d | 0d |  |  | STEREO | IMPACT | PS |  |  |  |  |  |  |  |  | UC-B |
| 68 | 2.1 | **Design, Manufacture, Assembly and Test** |  | 890.75d | 2000-07-31 A | 2004-02-19 |  | 60% | 360.74d | 2000-07-31 | 2004-01-05 | 860d | 0d |  |  | STEREO | IMPACT | PS |  |  |  |  |  |  |  |  | UC-B |
| 69 | 2.1.1 | **Procurements** |  | 432.75d | 2001-12-19 A | 2003-09-09 |  | 90% | 41.15d | 2001-12-19 | 2003-07-28 | 403d | -21.75d | 0d |  | STEREO | IMPACT | PS |  |  |  |  |  |  |  |  | UC-B |
| 70 | 2.1.1.1 | **ETU** |  | 135d | 2001-12-19 A | 2002-07-02 A |  | 100% |  | 2001-12-19 | 2002-07-02 | 135d |  |  |  | STEREO | IMPACT | PS |  |  |  |  |  |  |  |  | UC-B |
| 71 | 2.1.1.1.1 | Procure ETU Parts |  | 66d | 2001-12-19 A | 2002-03-26 A | 85 | 100% |  | 2001-12-19 | 2002-03-26 | 66d |  |  |  | STEREO | IMPACT | PS |  |  |  |  |  | LVPS Card |  |  | UC-B |
| 72 | 2.1.1.1.2 | Procure HVPS Printed Wiring Boards |  | 9.55d | 2002-06-19 A | 2002-07-02 A | 117 | 100% |  | 2002-06-19 | 2002-07-02 | 9.55d |  |  | start no earlier than 2002-05-31 | STEREO | IMPACT | PS |  |  |  |  |  | HVPS Card |  |  | UC-B |
| 73 | 2.1.1.2 | **FM 1 & FM 2** |  | 277.75d | 2002-08-01 A | 2003-09-09 |  | 88% | 33.49d | 2002-08-01 | 2003-07-28 | 248d | -21.75d | 0d |  | STEREO | IMPACT | PS |  |  |  |  |  |  |  |  | UC-B |
| 74 | 2.1.1.2.1 | Procure LVPS Flight Long Lead Parts (and Screen) |  | 139d | 2002-08-01 A | 2003-06-17 | 71 | 97% | 4d | 2002-08-01 | 2003-03-12 | 139d | 36d | 3d | finish no earlier than 2003-06-17 | STEREO | IMPACT | PS |  |  |  |  |  |  |  |  | UC-B |
| 75 | 2.1.1.2.2 | Procure HVPS Flight Long Lead Parts (and Screen) |  | 93d | 2002-08-01 A | 2002-12-13 A | 71 | 100% |  | 2002-08-01 | 2002-12-13 | 93d |  |  |  | STEREO | IMPACT |  |  |  |  |  |  |  |  |  |  |
| 76 | 2.1.1.2.3 | Procure SIT HVPS Flight Printed Wire Board |  | 10d | 2003-04-01 A | 2003-04-14 A | 124 | 100% |  | 2003-02-04 | 2003-02-18 | 10d |  |  | start no earlier than 2003-03-31 | STEREO | IMPACT | PS |  |  |  | SIT Flight HVPS Printed Wiring Boards Ordered |  |  |  |  | UC-B |
| 77 | 2.1.1.2.4 | Procure IDPU Flight Printed Wiring Board |  | 10d | 2003-05-12 A | 2003-05-23 A | 120 | 100% |  | 2003-03-12 | 2003-03-25 | 10d |  |  | start no earlier than 2003-05-31 | STEREO | IMPACT |  |  |  |  | IDPU Flight LVPS Printed Wiring Boards Ordered |  |  |  |  |  |
| 78 | 2.1.1.2.5 | Procure SEP Flight Printed Wiring Board |  | 10d | 2003-08-25 | 2003-09-09 | 121 |  |  | 2003-06-20 | 2003-07-03 | 10d | -31.75d | 0d |  | STEREO | IMPACT |  |  |  |  | SEP Flight LVPS Printed Wiring Boards Ordered |  |  |  |  |  |
| 79 | 2.1.1.2.6 | Procure SWEA Flight Printed Wiring Board |  | 10d | 2003-07-29 | 2003-08-11 | 122 |  |  | 2003-06-03 | 2003-06-16 | 10d | -6d | 0d |  | STEREO | IMPACT |  |  |  |  | SWEA/STE-D Flight LVPS Printed Wiring Boards Ordered |  |  |  |  |  |
| 80 | 2.1.1.2.7 | Procure PLASTIC Flight Printed Wiring Board |  | 10d | 2003-07-15 | 2003-07-28 | 123 |  |  | 2003-07-15 | 2003-07-28 | 10d | 4d | 0d |  | STEREO | IMPACT |  |  |  |  | PLASTIC Flight LVPS Printed Wiring Boards Ordered |  |  |  |  |  |

Notes:
- 58: FNL of 12/3/03 removed 1/9/03
- 60: FNL of 12/3/03 removed 1/9/03
- 62: FNL of 12/3/03 removed 1/9/03
- 64: FNL of 12/3/03 removed 1/9/03
- 65: FNL of 12/3/03 removed 1/9/03

| ID | WBS | Task | Type | Duration | Start | Finish | Predecessors | Complete | Remaining | Baseline start | Baseline finish | Baseline duration | Total slack | Free slack | Constraint | Text11 | Text12 | Text14 | Text16 | Text28 | Text15 | Text17 | Text13 | Text23 |
| --- | --- | --- | --- | --- | --- | --- | --- | --- | --- | --- | --- | --- | --- | --- | --- | --- | --- | --- | --- | --- | --- | --- | --- | --- |
| 81 | 2.1.2 | **Design** |  | 670d | 2000-07-31 A | 2003-04-02 A |  | 100% |  | 2000-07-31 | 2003-02-25 | 644d |  |  |  | STEREO | IMPACT | PS | LVPS | UC-B |  |  |  |  |
| 82 | 2.1.2.1 | Develop Low Voltage Topology |  | 96d | 2000-07-31 A | 2000-12-15 A | 32 | 100% |  | 2000-07-31 | 2000-12-15 | 96d |  |  |  | STEREO | IMPACT | PS | LVPS | UC-B | LVPS Card |  |  |  |
| 83 | 2.1.2.2 | Breadboard Different Topologies |  | 76d | 2000-12-18 A | 2001-04-06 A | 82 | 100% |  | 2000-12-18 | 2001-04-06 | 76d |  |  |  | STEREO | IMPACT | PS | LVPS | UC-B | LVPS Card |  |  |  |
| 84 | 2.1.2.3 | Test Different Topologies |  | 78d | 2001-04-09 A | 2001-07-27 A | 83 | 100% |  | 2001-04-09 | 2001-07-27 | 78d |  |  |  | STEREO | IMPACT | PS | LVPS | UC-B | LVPS Card |  |  |  |
| 85 | 2.1.2.4 | Design IDPU LVPS |  | 68d | 2001-09-11 A | 2001-12-18 A | 84, 33 | 100% |  | 2001-09-11 | 2001-12-18 | 68d |  |  |  | STEREO | IMPACT | PS | IDPU | UC-B | LVPS Card | LVPS |  |  |
| 86 | 2.1.2.5 | Design SEP LVPS |  | 9d | 2001-12-19 A | 2002-01-02 A | 85 | 100% |  | 2001-12-19 | 2002-01-02 | 9d |  |  |  | STEREO | IMPACT | PS | SEP DPU | UC-B | LVPS Card | LVPS | SEP Package |  |
| 87 | 2.1.2.6 | Design SWEA LVPS |  | 9d | 2002-01-02 A | 2002-01-15 A | 86 | 100% |  | 2002-01-02 | 2002-01-15 | 9d |  |  |  | STEREO | IMPACT | PS | SWEA/STE-D | UC-B | LVPS Card | LVPS | Boom Suite |  |
| 88 | 2.1.2.7 | Design PLASTIC LVPS |  | 10d | 2002-01-16 A | 2002-01-29 A | 87 | 100% |  | 2002-01-16 | 2002-01-29 | 10d |  |  |  | STEREO | PLASTIC | PS |  | UC-B | LVPS Card |  | PLASTIC |  |
| 89 | 2.1.2.8 | Design SIT HVPS |  | 24d | 2000-07-31 A | 2000-08-31 A |  | 100% |  | 2000-07-31 | 2000-08-31 | 24d |  |  | start no earlier than 2000-07-31 | STEREO | IMPACT | PS | SIT | UC-B | HVPS Card | HVPS | SEP Package |  |
| 90 | 2.1.2.9 | Design SIT Box Internal |  | 10.5d | 2002-05-01 A | 2002-06-07 A |  | 100% |  | 2002-05-01 | 2002-06-07 | 10.5d |  |  | start no earlier than 2002-04-30 | STEREO | IMPACT | PS | SIT | UC-B | HVPS Card | HVPS | SEP Package |  |
| 91 | 2.1.2.10 | Final mods to PLASTIC, SEP, and SWEA LVPS designs |  | 10d | 2003-02-06 A | 2003-04-02 A | 35 | 100% |  | 2003-02-11 | 2003-02-25 | 10d |  |  |  | STEREO | IMPACT |  |  |  |  |  |  |  |
| 92 | 2.1.3 | **Fabrication** |  | 403.75d | 2002-05-06 A | 2003-12-12 |  | 49% | 206.5d | 2002-05-06 | 2003-10-29 | 374d | 45d |  |  | STEREO | IMPACT | PS |  | UC-B |  |  |  |  |
| 93 | 2.1.3.1 | **ETU** |  | 283.75d | 2002-05-06 A | 2003-06-20 |  | 81% | 53.85d | 2002-05-06 | 2003-04-07 | 231d | -8.75d | 0d |  | STEREO | IMPACT | PS |  | UC-B |  |  |  |  |
| 94 | 2.1.3.1.1 | **IDPU** |  | 133d | 2002-05-06 A | 2002-11-13 A |  | 100% |  | 2002-05-06 | 2002-11-13 | 133d |  |  |  | STEREO | IMPACT |  |  |  |  |  |  |  |
| 95 | 2.1.3.1.1.1 | IDPU LVPS Form Factor |  | 1d | 2002-05-06 A | 2002-05-06 A |  | 100% |  | 2002-05-06 | 2002-05-06 | 1d |  |  | start no earlier than 2002-05-06 | STEREO | IMPACT | PS |  | UC-B | LVPS Card |  | IDPU |  |
| 96 | 2.1.3.1.1.2 | Fabricate ETU IDPU LVPS Tray |  | 10d | 2002-06-03 A | 2002-06-14 A | 95 | 100% |  | 2002-06-03 | 2002-06-14 | 10d |  |  | start no earlier than 2002-05-31 | STEREO | IMPACT | PS | IDPU | UC-B | LVPS Card | LVPS | IDPU |  |
| 97 | 2.1.3.1.1.3 | Layout IDPU LVPS |  | 15.5d | 2002-06-03 A | 2002-09-12 A | 95 | 100% |  | 2002-06-03 | 2002-09-12 | 15.5d |  |  | start no earlier than 2002-05-31 | STEREO | IMPACT | PS | IDPU | UC-B | LVPS Card | LVPS | IDPU |  |
| 98 | 2.1.3.1.1.4 | Fabricate IDPU LVPS PWB |  | 9d | 2002-10-01 A | 2002-10-14 A | 97 | 100% |  | 2002-10-01 | 2002-10-14 | 9d |  |  | start no earlier than 2002-09-30 | STEREO | IMPACT | PS | IDPU | UC-B | LVPS Card | LVPS | IDPU |  |
| 99 | 2.1.3.1.1.5 | Wind IDPU ETU LVPS Magnetics |  | 9.8d | 2002-10-01 A | 2002-11-13 A | 116 | 100% |  | 2002-10-01 | 2002-11-13 | 9.8d |  |  | start no earlier than 2002-09-30 | STEREO | IMPACT | PS | IDPU | UC-B | LVPS Card | LVPS | IDPU |  |
| 100 | 2.1.3.1.2 | SEP LVPS Form Factor |  | 1d | 2003-03-31 A | 2003-03-31 A |  | 100% |  | 2003-02-01 | 2003-02-01 | 0d |  |  | start no earlier than 2003-03-01 | STEREO | IMPACT | PS | IDPU | UC-B | LVPS Card | LVPS | SEP Package |  |
| 101 | 2.1.3.1.3 | Fabricate ETU SEP LVPS Box |  | 20d | 2002-10-01 A | 2002-10-29 A | 100 | 100% |  | 2002-10-01 | 2002-10-29 | 20d |  |  | start no earlier than 2002-09-30 | STEREO | IMPACT | PS | IDPU | UC-B | LVPS Card | LVPS | SEP Package |  |
| 102 | 2.1.3.1.4 | Layout SEP LVPS |  | 19d | 2003-04-03 A | 2003-06-06 | 91, 100 | 75% | 4.75d | 2003-02-26 | 2003-03-24 | 19d | -26.75d | 0d |  | STEREO | IMPACT |  |  |  |  |  |  |  |
| 103 | 2.1.3.1.5 | Fabricate SEP LVPS PWB |  | 10d | 2003-06-06 | 2003-06-20 | 102 |  |  | 2003-03-25 | 2003-04-07 | 10d | -31.75d | 0d | start no earlier than 2003-06-01 | STEREO | IMPACT | PS | SEP DPU | UC-B | LVPS Card | LVPS | SEP Package | SEP ETU LVPS Printed Wiring Board Fabricated |
| 104 | 2.1.3.1.6 | Wind SEP ETU LVPS Magnetics |  | 20d | 2003-05-01 | 2003-05-29 | 91 |  |  | 2003-02-26 | 2003-03-25 | 20d | -16d | 0d | start no earlier than 2003-05-01 | STEREO | IMPACT | PS | SEP DPU | UC-B | LVPS Card | LVPS | SEP Package |  |
| 105 | 2.1.3.1.7 | SWEA LVPS Form Factor | milestone | 0d | 2003-01-24 A | 2003-01-24 A |  | 100% |  | 2003-01-24 | 2003-01-24 | 0d |  |  | start no earlier than 2002-11-30 | STEREO | IMPACT | PS | SWEA/STE-D | UC-B | LVPS Card | LVPS | Boom Suite |  |
| 106 | 2.1.3.1.8 | Fabricate ETU SWEA Interface Box |  | 10d | 2003-01-27 A | 2003-02-07 A | 105 | 100% |  | 2003-01-27 | 2003-02-07 | 10d |  |  |  | STEREO | IMPACT | PS | SWEA/STE-D | UC-B | LVPS Card | LVPS | Boom Suite |  |
| 107 | 2.1.3.1.9 | Layout SWEA LVPS |  | 9d | 2003-03-05 A | 2003-03-17 A | 105, 87, 91 | 100% |  | 2003-02-26 | 2003-03-10 | 9d |  |  | start no earlier than 2003-03-01 | STEREO | IMPACT | PS | SWEA/STE-D | UC-B | LVPS Card | LVPS | Boom Suite |  |
| 108 | 2.1.3.1.10 | Fabricate SWEA LVPS PWB |  | 10d | 2003-04-01 A | 2003-04-14 A | 107 | 100% |  | 2003-03-11 | 2003-03-24 | 10d |  |  | start no earlier than 2003-03-31 | STEREO | IMPACT | PS | SWEA/STE-D | UC-B | LVPS Card | LVPS | Boom Suite | SWEA/STE-D ETU LVPS Printed Wiring Board Fabricated |
| 109 | 2.1.3.1.11 | Wind SWEA ETU LVPS Magnetics |  | 10d | 2003-04-03 A | 2003-04-16 A | 91 | 100% |  | 2003-02-26 | 2003-03-11 | 10d |  |  | start no earlier than 2003-03-31 | STEREO | IMPACT | PS | SWEA/STE-D | UC-B | LVPS Card | LVPS | Boom Suite |  |
| 110 | 2.1.3.1.12 | PLASTIC LVPS Form Factor |  | 1d | 2003-02-03 A | 2003-02-03 A |  | 100% |  | 2003-02-01 | 2003-02-01 | 1d |  |  | start no earlier than 2003-02-01 | STEREO | PLASTIC | PS |  | UC-B | LVPS Card | LVPS | PLASTIC |  |
| 111 | 2.1.3.1.13 | Fabricate ETU PLASTIC LVPS Box |  | 10d | 2003-05-01 | 2003-05-14 | 110 |  |  | 2003-02-03 | 2003-02-14 | 10d | 17d |  | start no earlier than 2003-05-01 | STEREO | PLASTIC | PS |  | UC-B | LVPS Card | LVPS | PLASTIC |  |
| 112 | 2.1.3.1.14 | Layout PLASTIC LVPS |  | 10d | 2003-03-05 A | 2003-03-18 A | 110, 91 | 100% |  | 2003-02-26 | 2003-03-11 | 10d |  |  | start no earlier than 2003-03-01 | STEREO | PLASTIC | PS |  | UC-B | LVPS Card | LVPS | PLASTIC |  |
| 113 | 2.1.3.1.15 | Fabricate PLASTIC LVPS PWB |  | 10d | 2003-04-01 A | 2003-04-14 A | 112 | 100% |  | 2003-03-12 | 2003-03-25 | 10d |  |  | start no earlier than 2003-03-31 | STEREO | PLASTIC | PS |  | UC-B | LVPS Card | LVPS | PLASTIC | PLASTIC ETU LVPS Printed Wiring Board Fabricated |
| 114 | 2.1.3.1.16 | Wind PLASTIC ETU LVPS Magnetics |  | 10d | 2003-05-01 A | 2003-05-14 A | 91 | 100% |  | 2003-02-26 | 2003-03-11 | 10d |  |  | start no earlier than 2003-05-01 | STEREO | PLASTIC | PS |  | UC-B | LVPS Card | LVPS | PLASTIC |  |
| 115 | 2.1.3.1.17 | Fabricate SIT ETU HVPS Box |  | 11d | 2002-06-07 A | 2002-06-21 A | 90 | 100% |  | 2002-06-07 | 2002-06-21 | 11d |  |  | start no earlier than 2002-05-31 | STEREO | IMPACT | PS | SIT | UC-B | HVPS Card | HVPS | SEP Package |  |
| 116 | 2.1.3.1.18 | Wind SIT ETU HVPS Magnetics |  | 15d | 2002-07-02 A | 2002-07-23 A |  | 100% |  | 2002-07-02 | 2002-07-23 | 15d |  |  | start no earlier than 2002-07-01 | STEREO | IMPACT | PS | SIT | UC-B | HVPS Card | HVPS | SEP Package |  |
| 117 | 2.1.3.1.19 | Layout SIT ETU HVPS Boards |  | 14.5d | 2002-05-06 A | 2002-06-18 A | 90 | 100% |  | 2002-05-06 | 2002-06-18 | 14.5d |  |  |  | STEREO | IMPACT | PS | SIT | UC-B | HVPS Card | HVPS | SEP Package |  |

Notes:
- 90: Need to check this one with DWC is this actually a GSFC activity? / No we decided to rename it to internals and have the box design out of sit for the externals be a pred to this activity

| ID | WBS | Task | Type | Duration | Start | Finish | Predecessors | Complete | Remaining | Baseline start | Baseline finish | Baseline duration | Total slack | Free slack | Constraint | Text11 | Text12 | Text14 | Text28 | Text15 | Text16 | Text17 | Text23 | Text13 |
| --- | --- | --- | --- | --- | --- | --- | --- | --- | --- | --- | --- | --- | --- | --- | --- | --- | --- | --- | --- | --- | --- | --- | --- | --- |
| 118 | 2.1.3.2 | **FM 1 & FM 2** |  | 226.75d | 2003-01-21 A | 2003-12-12 |  | 9% | 207.45d | 2003-01-21 | 2003-10-29 | 197d | 45d |  |  | STEREO | IMPACT | PS | UC-B |  |  |  |  |  |
| 119 | 2.1.3.2.1 | FM 1 & FM 2 LVPS Boxes | milestone | 0d | 2003-05-01 | 2003-05-01 |  |  |  | 2003-02-01 | 2003-02-01 | 0d | 43d | 36d | start no earlier than 2003-05-01 | STEREO | IMPACT | PS | UC-B | LVPS Card | LVPS | LVPS |  |  |
| 120 | 2.1.3.2.2 | Re-layout IDPU LVPS Flight Printed Wiring Board |  | 10d | 2003-02-26 A | 2003-06-10 | 23 | 30% | 7d | 2003-02-26 | 2003-03-11 | 10d | 172.75d |  |  | STEREO | IMPACT |  |  |  |  |  |  |  |
| 121 | 2.1.3.2.3 | Re-layout SEP LVPS Flight Printed Wiring Board |  | 10d | 2003-08-11 | 2003-08-25 | 25 |  |  | 2003-06-06 | 2003-06-19 | 10d | -31.75d | 0d |  | STEREO | IMPACT |  |  |  |  |  |  |  |
| 122 | 2.1.3.2.4 | Re-layout SWEA LVPS Flight Printed Wiring Board |  | 10d | 2003-07-15 | 2003-07-28 | 27 |  |  | 2003-05-19 | 2003-06-02 | 10d | -6d | 0d |  | STEREO | IMPACT |  |  |  |  |  |  |  |
| 123 | 2.1.3.2.5 | Re-layout PLASTIC LVPS Flight Printed Wiring Board |  | 10d | 2003-06-30 | 2003-07-14 | 28 |  |  | 2003-06-30 | 2003-07-14 | 10d | 4d | 0d |  | STEREO | IMPACT |  |  |  |  |  |  |  |
| 124 | 2.1.3.2.6 | Re-layout SIT HVPS Flight Printed Wiring Board |  | 10d | 2003-01-21 A | 2003-03-03 A | 21 | 100% |  | 2003-01-21 | 2003-02-03 | 10d |  |  |  | STEREO | IMPACT |  |  |  |  |  |  |  |
| 125 | 2.1.3.2.7 | **FM 1** |  | 150.75d | 2003-01-29 A | 2003-09-02 |  | 5% | 143.57d | 2003-01-29 | 2003-07-21 | 121d | -13.75d | 0d |  | STEREO | IMPACT | PS | UC-B |  | LVPS | LVPS |  |  |
| 126 | 2.1.3.2.7.1 | Wind HVPS FM 1 Magnets |  | 3d | 2003-01-29 A | 2003-05-16 A | 21 | 100% |  | 2003-01-29 | 2003-02-19 | 15d |  |  |  | STEREO | IMPACT |  |  |  |  |  |  |  |
| 127 | 2.1.3.2.7.2 | Wind IDPU LVPS FM 1 Magnets |  | 15d | 2003-06-02 | 2003-06-20 | 23 |  |  | 2003-02-26 | 2003-03-18 | 15d | 7d | 0d | start no earlier than 2003-06-01 | STEREO | IMPACT |  |  |  |  |  |  |  |
| 128 | 2.1.3.2.7.3 | Wind SEP LVPS FM 1 Magnets |  | 15d | 2003-08-11 | 2003-09-02 | 25 |  |  | 2003-06-06 | 2003-06-26 | 15d | -21.75d | 0d |  | STEREO | IMPACT |  |  |  |  |  |  |  |
| 129 | 2.1.3.2.7.4 | Wind SWEA LVPS FM 1 Magnets |  | 15d | 2003-07-15 | 2003-08-04 | 27 |  |  | 2003-05-19 | 2003-06-09 | 15d | 4d |  |  | STEREO | IMPACT |  |  |  |  |  |  |  |
| 130 | 2.1.3.2.7.5 | Wind PLASTIC LVPS FM 1 Magnets |  | 15d | 2003-06-30 | 2003-07-21 | 28 |  |  | 2003-06-30 | 2003-07-21 | 15d | 14d | 10d |  | STEREO | IMPACT | PS | UC-B |  | LVPS | LVPS |  |  |
| 131 | 2.1.3.2.8 | **FM 2** |  | 104.75d | 2003-07-15 | 2003-12-12 |  |  |  | 2003-06-02 | 2003-10-29 | 105d | -25.75d | 0d |  | STEREO | IMPACT | PS | UC-B |  | LVPS | LVPS |  |  |
| 132 | 2.1.3.2.8.1 | Wind HVPS FM 2 Magnets |  | 15d | 2003-07-15 | 2003-08-04 | 30 |  |  | 2003-06-09 | 2003-06-30 | 15d | 15d | 0d |  | STEREO | IMPACT |  |  |  |  |  |  |  |
| 133 | 2.1.3.2.8.2 | Wind IDPU LVPS FM 2 Magnets |  | 15d | 2003-08-21 | 2003-09-11 | 178 |  |  | 2003-06-02 | 2003-06-20 | 15d | 7d | 0d |  | STEREO | IMPACT |  |  |  |  |  |  |  |
| 134 | 2.1.3.2.8.3 | Wind SEP LVPS FM 2 Magnets |  | 15d | 2003-11-20 | 2003-12-12 | 179 |  |  | 2003-09-16 | 2003-10-07 | 15d | -31.75d | 0d |  | STEREO | IMPACT |  |  |  |  |  |  |  |
| 135 | 2.1.3.2.8.4 | Wind SWEA LVPS FM 2 Magnets |  | 15d | 2003-10-22 | 2003-11-12 | 180 |  |  | 2003-08-26 | 2003-09-16 | 15d | -6d | 0d |  | STEREO | IMPACT |  |  |  |  |  |  |  |
| 136 | 2.1.3.2.8.5 | Wind PLASTIC LVPS FM 2 Magnets |  | 15d | 2003-10-09 | 2003-10-29 | 181 |  |  | 2003-10-09 | 2003-10-29 | 15d | 4d | 0d |  | STEREO | IMPACT | PS | UC-B |  | LVPS | LVPS |  |  |
| 137 | 2.1.4 | **Assembly** |  | 363.75d | 2002-07-24 A | 2004-01-06 |  | 32% | 247.1d | 2002-07-24 | 2003-11-19 | 333d | -26.75d | 0d |  | STEREO | IMPACT | PS | UC-B |  |  |  |  |  |
| 138 | 2.1.4.1 | **ETU** |  | 238.75d | 2002-07-24 A | 2003-07-07 |  | 83% | 41.41d | 2002-07-24 | 2003-04-21 | 186d | -20.25d | 0d |  | STEREO | IMPACT | PS | UC-B |  |  |  |  |  |
| 139 | 2.1.4.1.1 | Assemble IDPU ETU LVPS |  | 35.5d | 2002-10-15 A | 2003-01-21 A | 71, 96, 98, 99 | 100% |  | 2002-10-15 | 2003-01-21 | 35.5d |  |  | start no earlier than 2002-09-30 | STEREO | IMPACT | PS | UC-B | LVPS Card | IDPU | LVPS | IDPU ETU LVPS Assembled |  |
| 140 | 2.1.4.1.2 | Assemble SEP ETU LVPS |  | 10d | 2003-06-20 | 2003-07-07 | 104, 103, 101 |  |  | 2003-04-08 | 2003-04-21 | 10d | -31.75d | 0d | start no earlier than 2003-06-01 | STEREO | IMPACT | PS | UC-B | LVPS Card | SEP DPU | LVPS | SEP ETU LVPS Assembled | SEP Package |
| 141 | 2.1.4.1.3 | Assemble SWEA ETU LVPS |  | 9d | 2003-04-17 A | 2003-04-29 A | 106, 108, 109 | 100% |  | 2003-03-25 | 2003-04-04 | 9d |  |  |  | STEREO | IMPACT | PS | UC-B | LVPS Card | SWEA/STE-D | LVPS | SWEA/STE-D ETU LVPS Assembled | Boom Suite |
| 142 | 2.1.4.1.4 | Assemble PLASTIC ETU LVPS |  | 9d | 2003-05-15 A | 2003-06-06 | 114, 113 | 50% | 4.5d | 2003-03-26 | 2003-04-07 | 9d | -8.5d | 0d |  | STEREO | PLASTIC | PS | UC-B | LVPS Card |  | LVPS | PLASTIC ETU LVPS Assembled | PLASTIC |
| 143 | 2.1.4.1.5 | Assemble SIT ETU HVPS |  | 20.1d | 2002-07-24 A | 2002-09-05 A | 72, 116, 115 | 100% |  | 2002-07-24 | 2002-09-05 | 20.1d |  |  |  | STEREO | IMPACT | PS | UC-B | HVPS Card | SIT | HVPS |  | SEP Package |

| ID | WBS | Task | Duration | Start | Finish | Predecessors | Complete | Remaining | Baseline start | Baseline finish | Baseline duration | Total slack | Free slack | Constraint | Text11 | Text12 | Text14 | Text28 | Text13 | Text15 | Text16 | Text17 | Text20 | Text23 |
| --- | --- | --- | --- | --- | --- | --- | --- | --- | --- | --- | --- | --- | --- | --- | --- | --- | --- | --- | --- | --- | --- | --- | --- | --- |
| 144 | 2.1.4.2 | **FM 1** | 98.75d | 2003-05-19 A | 2003-10-08 |  | 5% | 94.1d | 2003-02-26 | 2003-08-25 | 127d | -25.75d | 0d |  | STEREO | IMPACT | PS | UC-B |  |  |  |  |  |  |
| 145 | 2.1.4.2.1 | Assemble IDPU FM 1 LVPS | 12d | 2003-06-23 | 2003-07-09 | 74, 119, 127, 164 |  |  | 2003-04-02 | 2003-04-17 | 12d | 7d | 0d |  | STEREO | IMPACT | PS | UC-B | IDPU | LVPS Card | IDPU | LVPS | Assy IDPU FM 1 LVPS | IDPU FM 1 LVPS Assembled |
| 146 | 2.1.4.2.2 | Assemble SEP FM 1 LVPS | 15d | 2003-09-16 | 2003-10-08 | 128, 74, 119, 165 |  |  | 2003-07-14 | 2003-08-01 | 15d | -31.75d | 0d |  | STEREO | IMPACT | PS | UC-B | SEP Package | LVPS Card | SEP DPU | LVPS |  | SEP FM 1 LVPS Assembled |
| 147 | 2.1.4.2.3 | Assemble SWEA FM 1 LVPS | 14d | 2003-08-19 | 2003-09-08 | 129, 74, 119, 166 |  |  | 2003-06-24 | 2003-07-14 | 14d | -6d | 0d |  | STEREO | IMPACT | PS | UC-B | Boom Suite | LVPS Card | SWEA/STE-D | LVPS |  | SWEA/STE-D FM 1 LVPS Assembled |
| 148 | 2.1.4.2.4 | Assemble PLASTIC FM 1 LVPS | 15d | 2003-08-05 | 2003-08-25 | 130, 74, 119, 167 |  |  | 2003-08-05 | 2003-08-25 | 15d | 4d | 0d |  | STEREO | PLASTIC | PS | UC-B |  | LVPS Card |  | LVPS |  | PLASTIC FM 1 LVPS Assembled |
| 149 | 2.1.4.2.5 | Assemble SIT FM 1 HVPS | 13d | 2003-05-19 A | 2003-06-13 | 126, 75, 168 | 25% | 9.75d | 2003-02-26 | 2003-03-14 | 13d | 19.25d | 0d |  | STEREO | IMPACT | PS | UC-B | SEP Package | HVPS Card | SIT | HVPS |  | SIT FM 1 HVPS Assembled |
| 150 | 2.1.4.3 | **FM 2** | 104.75d | 2003-08-05 | 2004-01-06 |  |  |  | 2003-06-23 | 2003-11-19 | 104d | -26.75d | 0d |  | STEREO | IMPACT | PS | UC-B |  |  |  |  |  |  |
| 151 | 2.1.4.3.1 | Assemble IDPU FM 2 LVPS | 15d | 2003-09-12 | 2003-10-02 | 178, 133 |  |  | 2003-06-23 | 2003-07-14 | 15d | 7d | 0d |  | STEREO | IMPACT | PS | UC-B | IDPU | LVPS Card | IDPU | LVPS |  | IDPU FM 2 LVPS Assembled |
| 152 | 2.1.4.3.2 | Assemble SEP FM 2 LVPS | 15d | 2003-12-12 | 2004-01-06 | 134, 179 |  |  | 2003-10-08 | 2003-10-28 | 15d | -31.75d | 0d |  | STEREO | IMPACT | PS | UC-B | SEP Package | LVPS Card | SEP DPU | LVPS |  | SEP FM 2 LVPS Assembled |
| 153 | 2.1.4.3.3 | Assemble SWEA FM 2 LVPS | 15d | 2003-11-13 | 2003-12-04 | 135, 180 |  |  | 2003-09-17 | 2003-10-08 | 15d | -6d | 0d |  | STEREO | IMPACT | PS | UC-B | Boom Suite | LVPS Card | SWEA/STE-D | LVPS |  | SWEA/STE-D FM 2 LVPS Assembled |
| 154 | 2.1.4.3.4 | Assemble PLASTIC FM 2 LVPS | 14d | 2003-10-30 | 2003-11-19 | 136, 181 |  |  | 2003-10-30 | 2003-11-19 | 14d | 4d | 0d |  | STEREO | PLASTIC | PS | UC-B | PLASTIC | LVPS Card |  | LVPS |  | PLASTIC FM 2 LVPS Assembled |
| 155 | 2.1.4.3.5 | Assemble SIT FM 2 HVPS | 14d | 2003-08-05 | 2003-08-22 | 132, 30 |  |  | 2003-06-30 | 2003-07-21 | 14d | 15d | 0d |  | STEREO | IMPACT | PS | UC-B | SEP Package | HVPS Card | SIT | HVPS |  | SIT FM 2 HVPS Assembled |
| 156 | 2.1.5 | **Test** | 366.75d | 2002-08-30 A | 2004-02-19 |  | 11% | 326.61d | 2002-08-30 | 2004-01-05 | 336d | -26.75d | 0d |  | STEREO | IMPACT | PS | UC-B |  |  |  |  |  |  |
| 157 | 2.1.5.1 | **ETU** | 221.75d | 2002-08-30 A | 2003-07-21 |  | 58% | 93.37d | 2002-08-30 | 2003-05-05 | 169d | -26.75d | 0d |  | STEREO | IMPACT | PS | UC-B |  |  |  |  |  |  |
| 158 | 2.1.5.1.1 | Test IDPU ETU LVPS | 12d | 2003-01-20 A | 2003-02-05 A | 139FS-5d | 100% |  | 2003-01-20 | 2003-02-03 | 10d |  |  | start no earlier than 2002-11-30 | STEREO | IMPACT | PS | UC-B | IDPU | LVPS Card | IDPU | LVPS |  | IDPU ETU LVPS Tested |
| 159 | 2.1.5.1.2 | Test SEP ETU LVPS | 10d | 2003-07-07 | 2003-07-21 | 140 |  |  | 2003-04-22 | 2003-05-05 | 10d | -31.75d | 0d |  | STEREO | IMPACT | PS | UC-B | SEP Package | LVPS Card | SEP DPU | LVPS |  | SEP ETU LVPS Tested |
| 160 | 2.1.5.1.3 | Test SWEA ETU LVPS | 10d | 2003-05-01 A | 2003-05-14 A | 141 | 100% |  | 2003-04-07 | 2003-04-18 | 10d |  |  |  | STEREO | IMPACT | PS | UC-B | Boom Suite | LVPS Card | SWEA/STE-D | LVPS |  | SWEA/STE-D ETU LVPS Tested |
| 161 | 2.1.5.1.4 | Test PLASTIC ETU LVPS | 10d | 2003-06-06 | 2003-06-20 | 142, 111FF |  |  | 2003-04-08 | 2003-04-21 | 10d | -8.5d | 0d | start no earlier than 2003-06-01 | STEREO | PLASTIC | PS | UC-B | PLASTIC | LVPS Card |  | LVPS |  | PLASTIC ETU LVPS Tested |
| 162 | 2.1.5.1.5 | Test SIT ETU HVPS | 5.5d | 2002-08-30 A | 2002-10-01 A | 143FF-4d | 100% |  | 2002-08-30 | 2002-10-01 | 5.5d |  |  |  | STEREO | IMPACT | PS | UC-B | SEP Package | HVPS Card | SIT | HVPS |  |  |
| 163 | 2.1.5.2 | **FM 1 & FM 2** | 107.75d | 2003-04-15 A | 2003-09-16 |  | 38% | 67.34d | 2003-02-19 | 2003-08-04 | 117d | -25.75d | 0d |  | STEREO | IMPACT |  |  |  |  |  |  |  |  |
| 164 | 2.1.5.2.1 | Coupon Test IDPU Flight Printed Wiring Board | 4d | 2003-05-27 A | 2003-05-30 A | 77 | 100% |  | 2003-03-26 | 2003-04-01 | 5d |  |  | start no earlier than 2003-05-31 | STEREO | IMPACT |  |  |  |  |  |  |  |  |
| 165 | 2.1.5.2.2 | Coupon Test SEP Flight Printed Wiring Board | 5d | 2003-09-09 | 2003-09-16 | 78 |  |  | 2003-07-07 | 2003-07-11 | 5d | -31.75d | 0d |  | STEREO | IMPACT |  |  |  |  |  |  |  |  |
| 166 | 2.1.5.2.3 | Coupon Test SWEA Flight Printed Wiring Board | 5d | 2003-08-12 | 2003-08-18 | 79 |  |  | 2003-06-17 | 2003-06-23 | 5d | -6d | 0d |  | STEREO | IMPACT |  |  |  |  |  |  |  |  |
| 167 | 2.1.5.2.4 | Coupon Test PLASTIC Flight Printed Wiring Board | 5d | 2003-07-29 | 2003-08-04 | 80 |  |  | 2003-07-29 | 2003-08-04 | 5d | 4d | 0d |  | STEREO | IMPACT |  |  |  |  |  |  |  |  |
| 168 | 2.1.5.2.5 | Coupon Test SIT HVPS Flight Printed Wiring Board | 5d | 2003-04-15 A | 2003-04-21 A | 76 | 100% |  | 2003-02-19 | 2003-02-25 | 5d |  |  | start no earlier than 2003-03-31 | STEREO | IMPACT |  |  |  |  |  |  |  |  |

| ID | WBS | Task | Duration | Start | Finish | Predecessors | Baseline start | Baseline finish | Baseline duration | Total slack | Free slack | Text11 | Text12 | Text14 | Text28 | Text13 | Text15 | Text16 | Text17 | Text23 |
| --- | --- | --- | --- | --- | --- | --- | --- | --- | --- | --- | --- | --- | --- | --- | --- | --- | --- | --- | --- | --- |
| 169 | 2.1.5.3 | **FM 1** | 110d | 2003-06-13 | 2003-11-20 |  | 2003-03-17 | 2003-10-08 | 144d | -25.75d | 0d | STEREO | IMPACT | PS | UC-B |  |  |  |  |  |
| 170 | 2.1.5.3.1 | Test IDPU FM 1 LVPS | 10d | 2003-07-10 | 2003-07-23 | 145 | 2003-04-18 | 2003-05-01 | 10d | 7d | 0d | STEREO | IMPACT | PS | UC-B | IDPU | LVPS Card | IDPU | LVPS | IDPU FM 1 LVPS Tested |
| 171 | 2.1.5.3.2 | Test SEP FM 1 LVPS | 10d | 2003-10-08 | 2003-10-22 | 146 | 2003-08-04 | 2003-08-15 | 10d | -31.75d | 0d | STEREO | IMPACT | PS | UC-B | SEP Package | LVPS Card | SEP DPU | LVPS | SEP FM 1 LVPS Tested |
| 172 | 2.1.5.3.3 | Test SWEA FM 1 LVPS | 10d | 2003-09-09 | 2003-09-22 | 147 | 2003-07-15 | 2003-07-28 | 10d | -6d | 0d | STEREO | IMPACT | PS | UC-B | Boom Suite | LVPS Card | SWEA/STE-D | LVPS | SWEA/STE-D FM 1 LVPS Tested |
| 173 | 2.1.5.3.4 | Test PLASTIC FM 1 LVPS | 10d | 2003-08-26 | 2003-09-09 | 148 | 2003-08-26 | 2003-09-09 | 10d | 4d | 0d | STEREO | PLASTIC | PS | UC-B | PLASTIC | LVPS Card |  | LVPS | PLASTIC FM 1 LVPS Tested |
| 174 | 2.1.5.3.5 | Coat & Stake IDPU LVPS FM 1 Boards | 5d | 2003-07-24 | 2003-07-30 | 170 | 2003-05-02 | 2003-05-08 | 5d | 7d | 0d | STEREO | IMPACT | PS | UC-B |  |  | LVPS | LVPS |  |
| 175 | 2.1.5.3.6 | Coat & Stake SEP LVPS FM 1 Boards | 5d | 2003-10-22 | 2003-10-29 | 171 | 2003-08-18 | 2003-08-22 | 5d | -31.75d | 0d | STEREO | IMPACT |  |  |  |  |  |  |  |
| 176 | 2.1.5.3.7 | Coat & Stake SWEA LVPS FM 1 Boards | 5d | 2003-09-23 | 2003-09-29 | 172 | 2003-07-29 | 2003-08-04 | 5d | -6d | 0d | STEREO | IMPACT |  |  |  |  |  |  |  |
| 177 | 2.1.5.3.8 | Coat & Stake PLASTIC LVPS FM 1 Boards | 5d | 2003-09-10 | 2003-09-16 | 173 | 2003-09-10 | 2003-09-16 | 5d | 4d | 0d | STEREO | IMPACT |  |  |  |  |  |  |  |
| 178 | 2.1.5.3.9 | Retest IDPU LVPS FM 1 Boards | 15d | 2003-07-31 | 2003-08-20 | 174 | 2003-05-09 | 2003-05-30 | 15d | 7d | 0d | STEREO | IMPACT | PS | UC-B |  |  | LVPS | LVPS |  |
| 179 | 2.1.5.3.10 | Retest SEP LVPS FM 1 Boards | 15d | 2003-10-29 | 2003-11-20 | 175 | 2003-08-25 | 2003-09-15 | 15d | -31.75d | 0d | STEREO | IMPACT |  |  |  |  |  |  |  |
| 180 | 2.1.5.3.11 | Retest SWEA LVPS FM 1 Boards | 15d | 2003-09-30 | 2003-10-21 | 176 | 2003-08-05 | 2003-08-25 | 15d | -6d | 0d | STEREO | IMPACT |  |  |  |  |  |  |  |
| 181 | 2.1.5.3.12 | Retest PLASTIC LVPS FM 1 Boards | 15d | 2003-09-17 | 2003-10-08 | 177 | 2003-09-17 | 2003-10-08 | 15d | 4d | 0d | STEREO | IMPACT |  |  |  |  |  |  |  |
| 182 | 2.1.5.3.13 | Test SIT FM 1 HVPS | 5d | 2003-06-13 | 2003-06-20 | 149 | 2003-03-17 | 2003-03-21 | 5d | 19.25d | 0d | STEREO | IMPACT | PS | UC-B | SEP Package | HVPS Card | SIT | HVPS | SIT FM 1 HVPS Tested |
| 183 | 2.1.5.3.14 | Coat & Stake SIT HVPS FM 1 Boards | 5d | 2003-06-20 | 2003-06-27 | 182 | 2003-03-24 | 2003-03-28 | 5d | 19.25d | 0d | STEREO | IMPACT | PS | UC-B | SEP Package |  | SIT | HVPS |  |
| 184 | 2.1.5.3.15 | Retest SIT HVPS FM 1 Boards | 1d | 2003-06-27 | 2003-06-30 | 183 | 2003-03-31 | 2003-03-31 | 1d | 19.25d | 0d | STEREO | IMPACT | PS | UC-B | SEP Package |  | SIT | HVPS |  |
| 185 | 2.1.5.4 | **FM 2** | 120.75d | 2003-08-25 | 2004-02-19 |  | 2003-07-15 | 2004-01-05 | 119d | -26.75d | 0d | STEREO | IMPACT | PS | UC-B |  |  |  |  |  |
| 186 | 2.1.5.4.1 | **IDPU** | 30d | 2003-10-03 | 2003-11-17 |  | 2003-07-15 | 2003-08-25 | 30d | 36d |  | STEREO | IMPACT |  |  |  |  |  |  |  |
| 187 | 2.1.5.4.1.1 | Test IDPU FM 2 LVPS | 10d | 2003-10-03 | 2003-10-17 | 151 | 2003-07-15 | 2003-07-28 | 10d | 7d | 0d | STEREO | IMPACT | PS | UC-B |  | LVPS Card | IDPU | LVPS | IDPU FM 2 LVPS Tested |
| 188 | 2.1.5.4.1.2 | Coat & Stake IDPU LVPS FM 2 Boards | 5d | 2003-10-20 | 2003-10-24 | 187 | 2003-07-29 | 2003-08-04 | 5d | 7d | 0d | STEREO | IMPACT | PS | UC-B |  |  | LVPS | LVPS |  |
| 189 | 2.1.5.4.1.3 | Retest IDPU LVPS FM 2 Boards | 15d | 2003-10-27 | 2003-11-17 | 188 | 2003-08-05 | 2003-08-25 | 15d | 7d | 0d | STEREO | IMPACT | PS | UC-B |  |  | LVPS | LVPS |  |
| 190 | 2.1.5.4.2 | **SEP** | 30d | 2004-01-06 | 2004-02-19 |  | 2003-10-29 | 2003-12-11 | 30d | -26.75d | 0d | STEREO | IMPACT |  |  |  |  |  |  |  |
| 191 | 2.1.5.4.2.1 | Test SEP FM 2 LVPS | 10d | 2004-01-06 | 2004-01-21 | 152 | 2003-10-29 | 2003-11-12 | 10d | -31.75d | 0d | STEREO | IMPACT | PS | UC-B | SEP Package | LVPS Card | SEP DPU | LVPS | SEP FM 2 LVPS Tested |
| 192 | 2.1.5.4.2.2 | Coat & Stake SEP LVPS FM 2 Boards | 5d | 2004-01-21 | 2004-01-28 | 191 | 2003-11-13 | 2003-11-19 | 5d | -31.75d | 0d | STEREO | IMPACT |  |  |  |  |  |  |  |
| 193 | 2.1.5.4.2.3 | Retest SEP LVPS FM 2 Boards | 15d | 2004-01-28 | 2004-02-19 | 192 | 2003-11-20 | 2003-12-11 | 15d | -31.75d | 0d | STEREO | IMPACT |  |  |  |  |  |  |  |

| ID | WBS | Task | Duration | Start | Finish | Predecessors | Baseline start | Baseline finish | Baseline duration | Total slack | Free slack | Text11 | Text12 | Text13 | Text14 | Text15 | Text16 | Text17 | Text23 | Text28 |
| --- | --- | --- | --- | --- | --- | --- | --- | --- | --- | --- | --- | --- | --- | --- | --- | --- | --- | --- | --- | --- |
| 194 | 2.1.5.4.3 | **SWEA** | 30d | 2003-12-05 | 2004-01-20 |  | 2003-10-09 | 2003-11-20 | 30d | -6d | 0d | STEREO | IMPACT |  |  |  |  |  |  |  |
| 195 | 2.1.5.4.3.1 | Test SWEA FM 2 LVPS | 10d | 2003-12-05 | 2003-12-18 | 153 | 2003-10-09 | 2003-10-22 | 10d | -6d | 0d | STEREO | IMPACT | Boom Suite | PS | LVPS Card | SWEA/STE-D | LVPS | SWEA/STE-D FM 2 LVPS Tested | UC-B |
| 196 | 2.1.5.4.3.2 | Coat & Stake SWEA LVPS FM 2 Boards | 5d | 2003-12-19 | 2003-12-26 | 195 | 2003-10-23 | 2003-10-29 | 5d | -6d | 0d | STEREO | IMPACT |  |  |  |  |  |  |  |
| 197 | 2.1.5.4.3.3 | Retest SWEA LVPS FM 2 Boards | 15d | 2003-12-29 | 2004-01-20 | 196 | 2003-10-30 | 2003-11-20 | 15d | -6d | 0d | STEREO | IMPACT |  |  |  |  |  |  |  |
| 198 | 2.1.5.4.4 | **PLASTIC** | 30d | 2003-11-20 | 2004-01-05 |  | 2003-11-20 | 2004-01-05 | 30d | 4d |  | STEREO | IMPACT |  |  |  |  |  |  |  |
| 199 | 2.1.5.4.4.1 | Test PLASTIC FM 2 LVPS | 10d | 2003-11-20 | 2003-12-04 | 154 | 2003-11-20 | 2003-12-04 | 10d | 4d | 0d | STEREO | PLASTIC | PLASTIC | PS | LVPS Card |  | LVPS | PLASTIC FM 2 LVPS Tested | UC-B |
| 200 | 2.1.5.4.4.2 | Coat & Stake PLASTIC LVPS FM 2 Boards | 5d | 2003-12-05 | 2003-12-11 | 199 | 2003-12-05 | 2003-12-11 | 5d | 4d | 0d | STEREO | IMPACT |  |  |  |  |  |  |  |
| 201 | 2.1.5.4.4.3 | Retest PLASTIC LVPS FM 2 Boards | 15d | 2003-12-12 | 2004-01-05 | 200 | 2003-12-12 | 2004-01-05 | 15d | 4d | 0d | STEREO | IMPACT |  |  |  |  |  |  |  |
| 202 | 2.1.5.4.5 | **SIT** | 11d | 2003-08-25 | 2003-09-09 |  | 2003-07-21 | 2003-08-05 | 11d | 15d |  | STEREO | IMPACT |  |  |  |  |  |  |  |
| 203 | 2.1.5.4.5.1 | Test SIT FM 2 HVPS | 5d | 2003-08-25 | 2003-08-29 | 155 | 2003-07-21 | 2003-07-28 | 5d | 15d | 0d | STEREO | IMPACT | SEP Package | PS | HVPS Card | SIT | HVPS | SIT FM 2 HVPS Tested | UC-B |
| 204 | 2.1.5.4.5.2 | Coat & Stake SIT FM 2 HVPS Boards | 5d | 2003-09-02 | 2003-09-08 | 203 | 2003-07-28 | 2003-08-04 | 5d | 15d | 0d | STEREO | IMPACT | SEP Package | PS |  | SIT | HVPS |  | UC-B |
| 205 | 2.1.5.4.5.3 | Retest SIT FM 2 HVPS Boards | 1d | 2003-09-09 | 2003-09-09 | 204 | 2003-08-04 | 2003-08-05 | 1d | 15d | 0d | STEREO | IMPACT | SEP Package | PS |  | SIT | HVPS |  | UC-B |
