# SEP I & T

Schedule from MS Project, 2001-03-01 to 2005-09-16, status date 2003-04-30, A marks actual dates.
SEP Package I & T
NASA GSFC
Status Date: 04/30/2003 / Baseline Date: 01/31/2003 R1

## Calendars

- Standard w/ 10 Gov't Holidays: Mon-Fri 08:00-12:00, 13:00-17:00; Sat-Sun off. Exceptions (off unless hours are given): 2001-05-28, 2001-07-04, 2001-09-03, 2001-10-08, 2001-11-12, 2001-11-22, 2001-12-25, 2002-01-01, 2002-01-14, 2002-02-18, 2002-05-27, 2002-07-04, 2002-09-02, 2002-10-07, 2002-11-11, 2002-11-28, 2002-12-25, 2003-01-01, 2003-01-13, 2003-02-17, 2003-05-26, 2003-07-04, 2003-09-01, 2003-10-06, 2003-11-10, 2003-11-27, 2003-12-25, 2004-01-01, 2004-01-12, 2004-02-16, 2004-05-31, 2004-07-05, 2004-09-06, 2004-10-11, 2004-11-08, 2004-11-25, 2004-12-24, 2004-12-31, 2005-01-17, 2005-02-21, 2005-05-30, 2005-07-04, 2005-09-05.

## Schedule

| ID | WBS | Task | Type | Duration | Start | Finish | Predecessors | Complete | Remaining | Baseline start | Baseline finish | Baseline duration | Total slack | Free slack | Constraint | Text11 | Text12 | Text13 | Text14 | Text28 | Text20 | Text22 | Text23 |
| --- | --- | --- | --- | --- | --- | --- | --- | --- | --- | --- | --- | --- | --- | --- | --- | --- | --- | --- | --- | --- | --- | --- | --- |
| 1 | 1 | **Management** |  | 328d | 2003-04-08 A | 2004-07-28 |  | 5% | 313.09d | 2003-02-01 | 2004-07-28 | 374d | 287d |  |  | STEREO | IMPACT | SEP Package | SEP Package | CIT |  |  |  |
| 2 | 1.1 | **Contingency** |  | 20d | 2003-09-11 | 2003-10-10 |  |  |  | 2003-09-05 | 2003-10-02 | 20d | 55.4d |  |  | STEREO | IMPACT | SEP Package | SEP Package |  |  |  |  |
| 3 | 1.1.1 | SEP Package EM Contingency |  | 20d | 2003-09-11 | 2003-10-10 | 122, 124, 123, 126 |  |  | 2003-09-05 | 2003-10-02 | 20d | 89.15d | 0d |  | STEREO | IMPACT | SEP Package | SEP Package |  |  |  |  |
| 4 | 1.2 | **Milestones** |  | 328d | 2003-04-08 A | 2004-07-28 |  | 50% | 164d | 2003-02-01 | 2004-07-28 | 374d | 287d |  |  | STEREO | IMPACT | SEP Package | SEP Package | CIT |  |  |  |
| 5 | 1.2.1 | SEP Package EM I & T Begins | milestone | 0d | 2003-05-08 A | 2003-05-08 A | 120SS | 100% |  | 2003-06-10 | 2003-06-10 | 0d |  |  |  | STEREO | IMPACT | SEP Package | SEP Package |  | Begin EM I & T |  |  |
| 6 | 1.2.2 | SEP Package EM I & T Complete | milestone | 0d | 2003-10-10 | 2003-10-10 | 3 |  |  | 2003-10-02 | 2003-10-02 | 0d | 89.15d | 42.4d |  | STEREO | IMPACT | SEP Package | SEP Package |  | Completed EM I & T | SEP Package - EM I & T Complete | EM I & T Complete |
| 7 | 1.2.3 | SEP Package FM 1 I & T Complete | milestone | 0d | 2004-04-21 | 2004-04-21 | 151 |  |  | 2004-04-08 | 2004-04-08 | 0d | 2d |  |  | STEREO | IMPACT | SEP Package | SEP Package |  | FM 1 I & T | SEP Package - FM 1 I & T Complete | FM 1 I & T Complete |
| 8 | 1.2.4 | SEP Package FM 1 Enviornmental Testing Complete | milestone | 0d | 2004-07-09 | 2004-07-09 | 174 |  |  | 2004-07-01 | 2004-07-01 | 0d | 0.25d | 0d |  | STEREO | IMPACT | SEP Package | SEP Package |  | FM 1 Envt | SEP Package - FM 1 Enviornmental Testing Complete | FM 1 Environ. Testing Complete |
| 9 | 1.2.5 | SEP Package FM 2 I & T Complete | milestone | 0d | 2004-04-20 | 2004-04-20 | 163, 166 |  |  | 2004-04-07 | 2004-04-07 | 0d | 18d | 3d | start no earlier than 2004-03-23 | STEREO | IMPACT | SEP Package | SEP Package |  | FM 2 I & T | SEP Package - FM 2 I & T Complete | FM 2 I & T Complete |
| 10 | 1.2.6 | **Receivables** |  | 287.75d | 2003-04-08 A | 2004-05-28 |  | 50% | 143.88d | 2003-02-01 | 2004-05-21 | 329d | 327.25d |  |  | STEREO | IMPACT | SEP Package | SEP Package | CIT |  |  |  |
| 11 | 1.1.67.5 | Deliver SEP Package FM 1 After EMC Testing | milestone | 0d | 2004-05-14 | 2004-05-14 |  |  |  |  |  |  | 0.25d | 0d |  | STEREO | IMPACT | SEP Package | SEP Package |  |  |  |  |
| 12 | 1.2.6.2 | Receive SEP Package FM 1 From IMPACT Suite EMC Testing | milestone | 0d | 2004-05-21 | 2004-05-21 | 11FS+5d |  |  | 2004-05-14 | 2004-05-14 | 0d | 0.25d | 0d |  | STEREO | IMPACT | SEP Package | SEP Package |  |  |  |  |
| 13 | 1.1.67.7 | Deliver SEP Package FM 2 After EMC Testing | milestone | 0d | 2004-05-21 | 2004-05-21 |  |  |  |  |  |  | 2.25d | 0d |  | STEREO | IMPACT | SEP Package | SEP Package |  |  |  |  |
| 14 | 1.2.6.4 | Receive SEP Package FM 2 From IMPACT Suite EMC Testing | milestone | 0d | 2004-05-28 | 2004-05-28 | 13FS+5d |  |  | 2004-05-21 | 2004-05-21 | 0d | 2.25d | 0d |  | STEREO | IMPACT | SEP Package | SEP Package |  |  |  |  |
| 15 | 1.2.6.5 | **SEP Central** |  | 227.75d | 2003-04-08 A | 2004-03-05 |  | 50% | 113.88d | 2003-05-15 | 2004-02-03 | 179d | 387.25d |  |  | STEREO | IMPACT | SEP Package | SEP Package |  |  |  |  |
| 16 | 1.2.6.5.1 | **EM** |  | 184d | 2003-04-08 A | 2003-12-31 |  | 50% | 92d | 2003-05-15 | 2004-02-03 | 179d | 431d |  |  | STEREO | IMPACT | SEP Package | SEP Package |  |  |  |  |
| 17 | 1.1.6.10 | Deliver SEP Central EM Logic Board (intial) for SEP EM/IDPU ETU I & T | milestone | 0d | 2003-05-31 | 2003-05-31 |  |  |  |  |  |  | 1023.5d |  | start no earlier than 2003-05-31 | STEREO | IMPACT | SEP Package | SEP Package |  |  |  |  |
| 18 | 1.2.6.5.1.2 | Receive SEP Central EM Logic Board for SEP EM /IDPU I & T |  | 1d | 2003-05-08 A | 2003-05-08 A | 17 | 100% |  | 2003-05-15 | 2003-05-15 | 0d |  |  |  | STEREO | IMPACT | SEP Package | SEP Package |  |  |  |  |
| 19 | 1.1.6.11 | Deliver SEP Central EM Logic Board (final) for SEP EM I & T | milestone | 0d | 2003-06-05 | 2003-06-05 |  |  |  |  |  |  | 111d | 0d | start no earlier than 2003-05-31 | STEREO | IMPACT | SEP Package | SEP Package |  |  |  |  |
| 20 | 1.2.6.5.1.4 | Receive SEP Central EM Logic Board for SEP EM I & T |  | 1d | 2003-06-05 | 2003-06-06 | 19 |  |  |  |  |  | 111d | 0d | start no earlier than 2003-05-31 | STEREO | IMPACT | SEP Package | SEP Package |  |  |  |  |
| 21 | 1.1.6.24 | Deliver Bench Tested SEP Cental EM Analog/Post-Reg Board for SEP EM I & T | milestone | 0d | 2003-05-29 A | 2003-05-29 A |  | 100% |  |  |  |  |  |  |  | STEREO | IMPACT | SEP Package | SEP Package |  |  |  |  |
| 22 | 1.2.6.5.1.6 | Receive SEP Central EM Analog/Post-Reg Board for SEP EM I & T | milestone | 0d | 2003-05-29 A | 2003-05-29 A | 21 | 100% |  | 2003-05-28 | 2003-05-28 | 0d |  |  |  | STEREO | IMPACT | SEP Package | SEP Package |  |  |  |  |
| 23 | 1.1.6.30 | Deliver Bench Tested SEP Cental EM SSD Bias Supply for SEP EM I & T | milestone | 0d | 2003-06-25 | 2003-06-25 |  |  |  |  |  |  | 137.75d | 0d |  | STEREO | IMPACT | SEP Package | SEP Package |  |  |  |  |
| 24 | 1.2.6.5.1.8 | Receive SEP Central EM SSD Bias Supply for SEP EM I & T | milestone | 0d | 2003-06-25 | 2003-06-25 | 23 |  |  | 2003-05-28 | 2003-05-28 | 0d | 137.75d | 28d |  | STEREO | IMPACT | SEP Package | SEP Package |  |  |  |  |
| 25 | 1.1.6.18 | Deliver Bench Tested SEP Cental ETU LVPS for SEP EM I & T | milestone | 0d | 2003-07-31 | 2003-07-31 |  |  |  |  |  |  | 113d | 0d |  | STEREO | IMPACT | SEP Package | SEP Package |  |  |  |  |
| 26 | 1.2.6.5.1.10 | Receive SEP Central EM Bench Tested LVPS for SEP EM I & T | milestone | 0d | 2003-07-31 | 2003-07-31 | 25 |  |  | 2003-05-27 | 2003-05-27 | 0d | 113d | 3.25d |  | STEREO | IMPACT | SEP Package | SEP Package |  |  |  |  |
| 27 | 1.1.6.35 | Deliver SEP Central Build 1 For SEP I & T | milestone | 0d | 2003-04-08 A | 2003-04-08 A |  | 100% |  |  |  |  |  |  |  | STEREO | IMPACT | SEP Package | SEP Package |  |  |  |  |
| 28 | 1.2.6.5.1.12 | Receive SEP Central S/W Build 1 for SEP I & T | milestone | 0d | 2003-04-08 A | 2003-04-08 A | 27 | 100% |  | 2003-05-30 | 2003-05-30 | 0d |  |  |  | STEREO | IMPACT | SEP Package | SEP Package |  |  |  |  |
| 29 | 1.1.6.37 | Deliver SEP Central Build 2 For SEP I & T | milestone | 0d | 2003-07-29 | 2003-07-29 |  |  |  |  |  |  | 109.75d | 0d |  | STEREO | IMPACT | SEP Package | SEP Package |  |  |  |  |
| 30 | 1.2.6.5.1.14 | Receive SEP Central S/W Build 2 for SEP I & T | milestone | 0d | 2003-07-29 | 2003-07-29 | 29 |  |  | 2003-08-27 | 2003-08-27 | 0d | 109.75d | 0d |  | STEREO | IMPACT | SEP Package | SEP Package |  |  |  |  |
| 31 | 1.1.6.39 | Deliver SEP Central Build 3 For SEP I & T | milestone | 0d | 2003-12-31 | 2003-12-31 |  |  |  |  |  |  | 431d | 0d |  | STEREO | IMPACT | SEP Package | SEP Package |  |  |  |  |
| 32 | 1.2.6.5.1.16 | Receive SEP Central S/W Build 3 for SEP I & T | milestone | 0d | 2003-12-31 | 2003-12-31 | 31 |  |  | 2004-02-03 | 2004-02-03 | 0d | 431d |  |  | STEREO | IMPACT | SEP Package | SEP Package |  |  |  |  |

| ID | WBS | Task | Type | Duration | Start | Finish | Predecessors | Baseline start | Baseline finish | Baseline duration | Total slack | Free slack | Constraint | Text11 | Text12 | Text13 | Text14 | Text16 | Text28 |
| --- | --- | --- | --- | --- | --- | --- | --- | --- | --- | --- | --- | --- | --- | --- | --- | --- | --- | --- | --- |
| 33 | 1.2.6.5.2 | **FM 1** |  | 78.5d | 2003-08-19 | 2003-12-11 |  | 2003-05-30 | 2003-11-28 | 125d | 13d |  |  | STEREO | IMPACT | SEP Package | SEP Package |  |  |
| 34 | 1.1.6.14 | Deliver SEP Central FM 1 Logic Board to SEP FM 1 I & T | milestone | 0d | 2003-10-30 | 2003-10-30 |  |  |  |  | 75.35d | 0d |  | STEREO | IMPACT | SEP Package | SEP Package |  |  |
| 35 | 1.2.6.5.2.2 | Receive SEP Central FM 1 Logic Board for SEP FM 1 I & T | milestone | 0d | 2003-10-30 | 2003-10-30 | 34 | 2003-10-15 | 2003-10-15 | 0d | 75.35d | 28.6d |  | STEREO | IMPACT | SEP Package | SEP Package |  |  |
| 36 | 1.1.6.26 | Deliver Bench Tested SEP Cental FM 1 Analog/Post-Reg Board for SEP FM 1 I & T | milestone | 0d | 2003-11-20 | 2003-11-20 |  |  |  |  | 60.75d | 1d | finish no earlier than 2003-11-20 | STEREO | IMPACT | SEP Package | SEP Package |  |  |
| 37 | 1.2.6.5.2.4 | Receive SEP Central FM 1Analog/Post-Reg Board for SEP FM 1 I & T | milestone | 0d | 2003-11-21 | 2003-11-21 | 36 | 2003-11-21 | 2003-11-21 | 0d | 26d | 13d | finish no earlier than 2003-11-21 | STEREO | IMPACT | SEP Package | SEP Package |  |  |
| 38 | 1.1.6.32 | Deliver Bench Tested SEP Cental FM 1 SSD Bias Supply for SEP FM 1 I & T | milestone | 0d | 2003-11-27 | 2003-11-27 |  |  |  |  | 56.75d | 1d | finish no earlier than 2003-11-27 | STEREO | IMPACT | SEP Package | SEP Package |  |  |
| 39 | 1.2.6.5.2.6 | Receive SEP Central FM 1 SSD Bias Supply Board for SEP FM 1 I & T | milestone | 0d | 2003-11-28 | 2003-11-28 | 38 | 2003-11-28 | 2003-11-28 | 0d | 22d | 9d | finish no earlier than 2003-11-28 | STEREO | IMPACT | SEP Package | SEP Package |  |  |
| 40 | 1.1.6.20 | Deliver Bench Tested SEP Central FM 1 LVPS to SEP FM 1 I & T | milestone | 0d | 2003-12-11 | 2003-12-11 |  |  |  |  | 46.75d | 0d |  | STEREO | IMPACT | SEP Package | SEP Package |  |  |
| 41 | 1.2.6.5.2.8 | Receive SEP Central FM 1 Bench Tested LVPS for SEP FM 1 I & T | milestone | 0d | 2003-12-11 | 2003-12-11 | 40 | 2003-10-28 | 2003-10-28 | 0d | 15d | 0d |  | STEREO | IMPACT | SEP Package | SEP Package |  |  |
| 42 | 1.1.6.1 | Deliver SEP FM 1 Common Electronics Enclosure to CIT | milestone | 0d | 2003-08-19 | 2003-08-19 |  |  |  |  | 125.25d | 0d |  | STEREO | IMPACT | SEP Package | SEP Package |  |  |
| 43 | 1.2.6.5.2.10 | Receive SEP FM 1 Common Electronics Enclosure from GSFC | milestone | 0d | 2003-08-19 | 2003-08-19 | 42 | 2003-05-30 | 2003-05-30 | 0d | 125.25d | 78.5d |  | STEREO | IMPACT | SEP Package | SEP Cen | SEP DPU | CIT |
| 44 | 1.2.6.5.3 | **FM 2** |  | 135.25d | 2003-08-19 | 2004-03-05 |  | 2003-05-30 | 2004-01-05 | 149d | -8.75d | 0d |  | STEREO | IMPACT | SEP Package | SEP Package |  |  |
| 45 | 1.1.6.16 | Deliver SEP Central FM 2 Logic Board to SEP FM 2 I & T | milestone | 0d | 2003-10-30 | 2003-10-30 |  |  |  |  | 75.35d | 0d |  | STEREO | IMPACT | SEP Package | SEP Package |  |  |
| 46 | 1.2.6.5.3.2 | Receive SEP Central FM 2 Logic Board for SEP FM 2 I & T | milestone | 0d | 2003-10-30 | 2003-10-30 | 45 | 2003-10-15 | 2003-10-15 | 0d | 75.35d |  |  | STEREO | IMPACT | SEP Package | SEP Package |  |  |
| 47 | 1.1.6.28 | Deliver Bench Tested SEP Cental FM 2 Analog/Post-Reg Board for SEP FM 2 I & T | milestone | 0d | 2003-11-20 | 2003-11-20 |  |  |  |  | 60.75d | 1d | finish no earlier than 2003-11-20 | STEREO | IMPACT | SEP Package | SEP Package |  |  |
| 48 | 1.2.6.5.3.4 | Receive SEP Central FM 2Analog/Post-Reg Board for SEP FM 2 I & T | milestone | 0d | 2003-11-21 | 2003-11-21 | 47 | 2003-11-21 | 2003-11-21 | 0d | 26d | 13d | finish no earlier than 2003-11-21 | STEREO | IMPACT | SEP Package | SEP Package |  |  |
| 49 | 1.1.6.34 | Deliver Bench Tested SEP Cental FM 2 SSD Bias Supply for SEP FM 2 I & T | milestone | 0d | 2003-11-27 | 2003-11-27 |  |  |  |  | 56.75d | 1d | finish no earlier than 2003-11-27 | STEREO | IMPACT | SEP Package | SEP Package |  |  |
| 50 | 1.2.6.5.3.6 | Receive SEP Central FM 2 SSD Bias Supply Board for SEP FM 2 I & T | milestone | 0d | 2003-11-28 | 2003-11-28 | 49 | 2003-11-28 | 2003-11-28 | 0d | 22d | 9d | finish no earlier than 2003-11-28 | STEREO | IMPACT | SEP Package | SEP Package |  |  |
| 51 | 1.1.6.22 | Deliver Bench Tested SEP Central FM 2 LVPS to SEP FM 2 I & T | milestone | 0d | 2004-03-05 | 2004-03-05 |  |  |  |  | -8.75d | 0d |  | STEREO | IMPACT | SEP Package | SEP Package |  |  |
| 52 | 1.2.6.5.3.8 | Receive SEP Central FM 2 Bench Tested LVPS for SEP FM 2 I & T | milestone | 0d | 2004-03-05 | 2004-03-05 | 51 | 2004-01-05 | 2004-01-05 | 0d | -8.75d | 0d |  | STEREO | IMPACT | SEP Package | SEP Package |  |  |
| 53 | 1.1.6.3 | Deliver SEP FM 2 Common Electronics Enclosure to CIT | milestone | 0d | 2003-08-19 | 2003-08-19 |  |  |  |  | 125.25d | 0d |  | STEREO | IMPACT | SEP Package | SEP Package |  |  |
| 54 | 1.2.6.5.3.10 | Receive SEP FM 2 Common Electronics Enclosure from GSFC | milestone | 0d | 2003-08-19 | 2003-08-19 | 53 | 2003-05-30 | 2003-05-30 | 0d | 125.25d |  |  | STEREO | IMPACT | SEP Package | SEP Cen | SEP DPU | CIT |
| 55 | 1.2.6.6 | **HET** |  | 148.25d | 2003-07-08 | 2004-02-10 |  | 2003-07-08 | 2004-01-29 | 141d | -1.25d | 0d |  | STEREO | IMPACT | SEP Package | SEP Package |  |  |
| 56 | 1.1.6.4 | Deliver HET EM to CIT | milestone | 0d | 2003-06-17 | 2003-06-17 |  |  |  |  | -12d | 0d | finish no later than 2003-05-30 | STEREO | IMPACT | SEP Package | SEP Package |  |  |
| 57 | 1.2.6.6.2 | Receive HET EM for SEP EM I & T | milestone | 0d | 2003-07-08 | 2003-07-08 | 56FS+5d | 2003-07-08 | 2003-07-08 | 0d | 130.75d | 0d | start no earlier than 2003-07-08 | STEREO | IMPACT | SEP Package | SEP Package |  |  |
| 58 | 1.1.6.8 | Deliver HET FM 1 for SEP I & T | milestone | 0d | 2004-01-08 | 2004-01-08 |  |  |  |  | -9.25d | 0d | finish no later than 2003-12-23 | STEREO | IMPACT | SEP Package | SEP Package |  |  |
| 59 | 1.2.6.6.4 | Receive HET FM 1 From GSFC For SEP FM 1 I & T | milestone | 0d | 2004-01-16 | 2004-01-16 | 58FS+5d | 2003-12-31 | 2003-12-31 | 0d | 48.5d | 0d |  | STEREO | IMPACT | SEP Package | SEP Package | HET | CIT |
| 60 | 1.1.6.10 | Deliver HET FM 2 for SEP I & T | milestone | 0d | 2004-02-03 | 2004-02-03 |  |  |  |  | -7.25d | 0d | finish no later than 2004-01-22 | STEREO | IMPACT | SEP Package | SEP Package |  |  |
| 61 | 1.2.6.6.6 | Receive HET FM 2 From GSFC For SEP FM 2 I & T | milestone | 0d | 2004-02-10 | 2004-02-10 | 60FS+5d | 2004-01-29 | 2004-01-29 | 0d | -2.25d | 0d |  | STEREO | IMPACT | SEP Package | SEP Package | HET | CIT |

| ID | WBS | Task | Type | Duration | Start | Finish | Predecessors | Baseline start | Baseline finish | Baseline duration | Total slack | Free slack | Constraint | Text11 | Text12 | Text13 | Text14 | Text16 | Text28 | Text20 |
| --- | --- | --- | --- | --- | --- | --- | --- | --- | --- | --- | --- | --- | --- | --- | --- | --- | --- | --- | --- | --- |
| 62 | 1.2.6.7 | **LET** |  | 128.65d | 2003-07-02 | 2004-01-08 |  | 2003-05-05 | 2004-01-06 | 168d | 144d |  |  | STEREO | IMPACT | SEP Package | SEP Package |  |  |  |
| 63 | 1.2.4.9 | Deliver LET S/W Build 2 | milestone | 0d | 2003-07-02 | 2003-07-02 |  |  |  |  | -2d | 0d |  | STEREO | IMPACT | SEP Package | SEP Package |  |  |  |
| 64 | 1.2.6.7.2 | Receive LET S/W Build 2 | milestone | 0d | 2003-07-02 | 2003-07-02 | 63 | 2003-05-05 | 2003-05-05 | 0d | 127.75d | 18d |  | STEREO | IMPACT | SEP Package | SEP Package | LET | CIT |  |
| 65 | 1.2.4.12 | Deliver LET S/W Build 3 | milestone | 0d | 2003-12-10 | 2003-12-10 |  |  |  |  | 67.75d | 0d |  | STEREO | IMPACT | SEP Package | SEP Package |  |  |  |
| 66 | 1.2.6.7.4 | Receive LET S/W Build 3 | milestone | 0d | 2003-12-10 | 2003-12-10 | 65 | 2003-10-09 | 2003-10-09 | 0d | 67.75d |  |  | STEREO | IMPACT | SEP Package | SEP Package | LET | CIT |  |
| 67 | 1.2.4.3 | Deliver LET EM to I & T | milestone | 0d | 2003-07-18 | 2003-07-18 |  |  |  |  | -12.5d | 0d | finish no later than 2003-06-30 | STEREO | IMPACT | SEP Package | SEP Package |  |  |  |
| 68 | 1.2.6.7.6 | Receive LET EM fo SEP EM I & T | milestone | 0d | 2003-07-25 | 2003-07-25 | 67FS+5d | 2003-07-15 | 2003-07-15 | 0d | 112.25d | 2.5d | start no earlier than 2003-07-15 | STEREO | IMPACT | SEP Package | SEP Package |  |  |  |
| 69 | 1.2.4.5 | Deliver LET FM 1 to CIT For SEP I & T | milestone | 0d | 2003-12-31 | 2003-12-31 |  |  |  |  | 0.35d | 0d | finish no later than 2003-12-31 | STEREO | IMPACT | SEP Package | SEP Package |  |  |  |
| 70 | 1.2.6.7.8 | Receive LET FM 1 For SEP FM 1 I & T | milestone | 0d | 2004-01-08 | 2004-01-08 | 69FS+5d | 2004-01-06 | 2004-01-06 | 0d | 49.1d |  |  | STEREO | IMPACT | SEP Package | SEP Package | LET | CIT | LET |
| 71 | 1.2.4.7 | Deliver LET FM 2 to CIT For SEP I & T | milestone | 0d | 2003-12-31 | 2003-12-31 |  |  |  |  | 0.35d | 0d | finish no later than 2003-12-31 | STEREO | IMPACT | SEP Package | SEP Package |  |  |  |
| 72 | 1.2.6.7.10 | Receive LET FM 2 For SEP FM 2 I & T | milestone | 0d | 2004-01-08 | 2004-01-08 | 71FS+5d | 2004-01-06 | 2004-01-06 | 0d | 49.1d |  |  | STEREO | IMPACT | SEP Package | SEP Package | LET | CIT | LET |
| 73 | 1.2.6.8 | **SIT** |  | 156.5d | 2003-06-19 | 2004-02-05 |  | 2003-06-19 | 2004-01-22 | 147d | 7.5d |  |  | STEREO | IMPACT | SEP Package | SEP Package |  |  |  |
| 74 | 1.1.3.21 | Deliver SIT EM to CIT | milestone | 0d | 2003-06-13 | 2003-06-13 |  |  |  |  | 0d |  | must start on 2003-06-13 | STEREO | IMPACT | SEP Package | SEP Package |  |  |  |
| 75 | 1.2.6.8.2 | Receive SIT EM From UMD For SEP EM I & T | milestone | 0d | 2003-06-19 | 2003-06-19 | 74FS+5d | 2003-06-19 | 2003-06-19 | 0d | 141.75d | 0d |  | STEREO | IMPACT | SEP Package | SEP Package |  |  |  |
| 76 | 1.1.3.23 | Deliver SIT FM 1 to CIT For SEP I & T | milestone | 0d | 2004-01-19 | 2004-01-19 |  |  |  |  | -7.5d | 0d | finish no later than 2004-01-06 | STEREO | IMPACT | SEP Package | SEP Package |  |  |  |
| 77 | 1.2.6.8.4 | Receive SIT FM 1 From UMD For SEP FM 1 I & T | milestone | 0d | 2004-01-26 | 2004-01-26 | 76FS+5d | 2004-01-14 | 2004-01-14 | 0d | 47.25d | 0d |  | STEREO | IMPACT | SEP Package | SEP Package | SIT | CIT |  |
| 78 | 1.1.3.25 | Deliver SIT FM 2 to CIT For SEP I & T | milestone | 0d | 2004-01-29 | 2004-01-29 |  |  |  |  | -9.5d | 0d | finish no later than 2004-01-15 | STEREO | IMPACT | SEP Package | SEP Package |  |  |  |
| 79 | 1.2.6.8.6 | Receive SIT FM 2 From UMD For SEP FM 2 I & T | milestone | 0d | 2004-02-05 | 2004-02-05 | 78FS+5d | 2004-01-22 | 2004-01-22 | 0d | 39.25d | 0d |  | STEREO | IMPACT | SEP Package | SEP Package | SIT | CIT |  |
| 80 | 1.2.6.9 | **SEPT** |  | 66.4d | 2003-08-27 | 2003-12-03 |  | 2003-06-24 | 2003-11-24 | 106d | 28d |  |  | STEREO | IMPACT | SEP Package | SEP Package |  |  |  |
| 81 | 1.3.5.2 | Deliver SEPT ETU to CIT | milestone | 0d | 2003-08-27 | 2003-08-27 |  |  |  |  | 35.4d | 0d |  | STEREO | IMPACT | SEP Package | SEP Package |  |  |  |
| 82 | 1.2.6.9.2 | Receive SEPT EM From Kiel For SEP EM I & T | milestone | 0d | 2003-08-27 | 2003-08-27 | 81 | 2003-06-24 | 2003-06-24 | 0d | 35.4d | 0d |  | STEREO | IMPACT | SEP Package | SEP Package |  |  |  |
| 83 | 1.3.5.12 | Deliver SEPT-NS FM 1 w/Brackets to CIT for SEP I & T | milestone | 0d | 2003-10-29 | 2003-10-29 |  |  |  |  | 3d | 0d | finish no later than 2003-11-03 | STEREO | IMPACT | SEP Package | SEP Package |  |  |  |
| 84 | 1.2.6.9.4 | Receive SEPT-NS w/Brackets FM 1 From Kiel For SEP FM 1 I & T | milestone | 0d | 2003-11-05 | 2003-11-05 | 83FS+5d | 2003-11-20 | 2003-11-20 | 0d | 79.75d | 8d |  | STEREO | IMPACT | SEP Package | SEP Package | SEPT | CIT |  |
| 85 | 1.3.5.14 | Deliver SEPT-E FM 1 to CIT for SEP I & T | milestone | 0d | 2003-11-11 | 2003-11-11 |  |  |  |  | -5d | 0d | finish no later than 2003-11-03 | STEREO | IMPACT | SEP Package | SEP Package |  |  |  |
| 86 | 1.2.6.9.6 | Receive SEPT-E FM 1 From Kiel For SEP FM 1 I & T | milestone | 0d | 2003-11-18 | 2003-11-18 | 85FS+5d | 2003-11-20 | 2003-11-20 | 0d | 71.75d | 0d |  | STEREO | IMPACT | SEP Package | SEP Package | SEPT | CIT |  |
| 87 | 1.3.5.16 | Deliver SEPT-NS FM 2 w/Brackets to CIT for SEP I & T | milestone | 0d | 2003-11-18 | 2003-11-18 |  |  |  |  | -1d | 0d | finish no later than 2003-11-17 | STEREO | IMPACT | SEP Package | SEP Package |  |  |  |
| 88 | 1.2.6.9.8 | Receive SEPT-NS w/Brackets FM 2 From Kiel For SEP FM 2 I & T | milestone | 0d | 2003-11-25 | 2003-11-25 | 87FS+5d | 2003-11-24 | 2003-11-24 | 0d | 66.75d | 5d |  | STEREO | IMPACT | SEP Package | SEP Package | SEPT | CIT |  |
| 89 | 1.3.5.18 | Deliver SEPT-E FM 2 to CIT for SEP I & T | milestone | 0d | 2003-11-25 | 2003-11-25 |  |  |  |  | -6d | 0d | finish no later than 2003-11-17 | STEREO | IMPACT | SEP Package | SEP Package |  |  |  |
| 90 | 1.2.6.9.10 | Receive SEPT-E FM 2 From Kiel For SEP FM 2 I & T | milestone | 0d | 2003-12-03 | 2003-12-03 | 89FS+5d | 2003-11-24 | 2003-11-24 | 0d | 61.75d | 0d |  | STEREO | IMPACT | SEP Package | SEP Package | SEPT | CIT |  |

| ID | WBS | Task | Type | Duration | Start | Finish | Predecessors | Complete | Remaining | Baseline start | Baseline finish | Baseline duration | Total slack | Free slack | Constraint | Text11 | Text12 | Text13 | Text14 | Text16 | Text28 | Text21 |
| --- | --- | --- | --- | --- | --- | --- | --- | --- | --- | --- | --- | --- | --- | --- | --- | --- | --- | --- | --- | --- | --- | --- |
| 91 | 1.2.6.10 | **IDPU** |  | 5d | 2003-04-30 A | 2003-05-08 |  |  | 5d | 2003-02-01 | 2003-05-23 | 78d | 594d |  |  | STEREO | IMPACT | SEP Package | SEP Package |  |  |  |
| 92 | 1.1.5.22 | Deliver ETU IDPU to CIT For SEP/IDPU I/F Test | milestone | 0d | 2003-05-08 A | 2003-05-08 A |  | 100% |  |  |  |  |  |  | finish no earlier than 2003-05-01 | STEREO | IMPACT | SEP Package | SEP Package |  |  |  |
| 93 | 1.2.6.10.2 | Receive ETU IDPU From UC-B For SEP ETU/IDPU ETU I/F Test | milestone | 0d | 2003-05-08 A | 2003-05-08 A | 92 | 100% |  | 2003-05-23 | 2003-05-23 | 0d |  |  | start no earlier than 2003-05-23 | STEREO | IMPACT | SEP Package | SEP Package | IDPU | CIT |  |
| 94 | 1.2.6.10.3 | Receive Flight IDPU From UC-B | milestone | 0d | 2003-04-30 | 2003-04-30 |  |  |  | 2003-02-01 | 2003-02-01 | 0d | 599d |  | start no earlier than 2003-04-30 | STEREO | IMPACT | SEP Package | SEP Package |  |  |  |
| 95 | 1.2.7 | **Deliverables** |  | 306d | 2003-05-09 A | 2004-07-28 |  |  | 306d | 2003-07-29 | 2004-07-28 | 250.4d | 0d |  |  | STEREO | IMPACT | SEP Package | SEP Package |  | CIT |  |
| 96 | 1.2.7.1 | Deliver SIT EM Back to UMD | milestone | 0d | 2003-06-26 | 2003-06-26 | 122 |  |  | 2003-08-05 | 2003-08-05 | 0d | 166.3d | 0d |  | STEREO | IMPACT | SEP Package | SEP Package |  |  |  |
| 97 | 1.1.2.25 | Receive SIT EM Back from CIT | milestone | 0d | 2003-07-03 | 2003-07-03 | 96FS+5d |  |  |  |  |  | 166.3d |  |  | STEREO | IMPACT | SEP Package | SEP Package |  |  |  |
| 98 | 1.2.7.3 | Deliver SEPT EM Back to Kiel | milestone | 0d | 2003-09-11 | 2003-09-11 | 123 |  |  | 2003-08-12 | 2003-08-12 | 0d | 35.4d | 0d |  | STEREO | IMPACT | SEP Package | SEP Package |  |  |  |
| 99 | 1.3.4.11 | Receive SEPT ETU Back From CIT | milestone | 0d | 2003-09-18 | 2003-09-18 | 98FS+5d |  |  |  |  |  | 35.4d |  |  | STEREO | IMPACT | SEP Package | SEP Package |  |  |  |
| 100 | 1.2.7.5 | Deliver SEP FM 1 to UC-B for EMC Testing | milestone | 0d | 2004-04-23 | 2004-04-23 | 169, 7 |  |  | 2004-04-16 | 2004-04-16 | 0d | 0d |  |  | STEREO | IMPACT | SEP Package | SEP Package |  | CIT | Ready for EMC Test |
| 101 | 1.1.66.6 | Receive SEP Package FM 1 For EMC Testing | milestone | 0d | 2004-04-30 | 2004-04-30 | 100FS+5d |  |  |  |  |  | 0d |  |  | STEREO | IMPACT | SEP Package | SEP Package |  |  |  |
| 102 | 1.2.7.7 | Deliver SEP FM 2 to UC-B for EMC Testing | milestone | 0d | 2004-04-23 | 2004-04-23 | 9, 169 |  |  | 2004-04-16 | 2004-04-16 | 0d | 15d | 0d |  | STEREO | IMPACT | SEP Package | SEP Package |  |  |  |
| 103 | 1.1.66.8 | Receive SEP Package FM 2 For EMC Testing | milestone | 0d | 2004-04-23 | 2004-04-23 | 102 |  |  |  |  |  | 15d |  |  | STEREO | IMPACT | SEP Package | SEP Package |  |  |  |
| 104 | 1.2.7.9 | Deliver IDPU ETU to UC-B W/ SEP ETU/IDPU ETU I/F Test Results | milestone | 0d | 2003-05-09 A | 2003-05-09 A | 120 | 100% |  | 2003-07-29 | 2003-07-29 | 0d |  |  |  | STEREO | IMPACT | SEP Package | SEP Package | IDPU | CIT |  |
| 105 | 1.1.4.14 | Receive ETU IDPU Back From CIT SEP/IDPU I/F Test | milestone | 0d | 2003-05-09 A | 2003-05-09 A | 104 | 100% |  |  |  |  |  |  |  | STEREO | IMPACT | SEP Package | SEP Package |  |  |  |
| 106 | 1.2.7.11 | Deliver IDPU FM 1 to UC-B From SEP FM 1/ IDPU FM 1 Testing | milestone | 0d | 2004-04-21 | 2004-04-21 | 151 |  |  | 2004-04-08 | 2004-04-08 | 0d | -8.75d | 0d |  | STEREO | IMPACT | SEP Package | SEP Package | IDPU | CIT |  |
| 107 | 1.1.4.32 | Receive IDPU FM 2 From SEP Package/IDPU I & T | milestone | 0d | 2004-04-21 | 2004-04-21 | 106 |  |  |  |  |  | -8.75d | 0d |  | STEREO | IMPACT | SEP Package | SEP Package |  |  |  |
| 108 | 1.2.7.13 | SEP Package FM 1 Complete | milestone | 0d | 2004-07-14 | 2004-07-14 | 177 |  |  | 2004-07-07 | 2004-07-07 | 0d | 0.25d | 0d |  | STEREO | IMPACT | SEP Package | SEP Package |  |  |  |
| 109 | 1.1.3.2 | SEP Package FM 1 Ready For Delivery | milestone | 0d | 2004-07-14 | 2004-07-14 | 108 |  |  |  |  |  | 0.25d |  |  | STEREO | IMPACT | SEP Package | SEP Package |  |  |  |
| 110 | 1.2.7.15 | SEP Package FM 2 Complete | milestone | 0d | 2004-07-28 | 2004-07-28 | 184 |  |  | 2004-07-28 | 2004-07-28 | 0d | 0d |  | as late as possible | STEREO | IMPACT | SEP Package | SEP Package |  |  |  |
| 111 | 1.1.3.4 | SEP Package FM 2 Ready For Delivery | milestone | 0d | 2004-07-28 | 2004-07-28 | 110 |  |  |  |  |  | 0d |  |  | STEREO | IMPACT | SEP Package | SEP Package |  |  |  |
| 112 | 2 | **Integration & Test** |  | 406d | 2003-05-01 A | 2004-12-10 |  |  | 405.58d | 2003-02-03 | 2005-01-04 | 483d | 193d |  |  | STEREO | IMPACT | SEP Package | SEP Package |  | CIT |  |
| 113 | 2.1 | **ETU** |  | 377d | 2003-05-01 A | 2004-10-28 |  |  | 376.39d | 2003-04-01 | 2004-09-27 | 377d | 222d |  |  | STEREO | IMPACT | SEP Package | SEP Package |  | CIT |  |
| 114 | 2.1.1 | LET telescope mock-up integration/doc |  | 5d | 2003-05-01 | 2003-05-07 |  |  |  | 2003-04-01 | 2003-04-07 | 5d | 156.75d | 0d | start no earlier than 2003-04-30 | STEREO | IMPACT | SEP Package | SEP Package |  | CIT |  |
| 115 | 2.1.2 | Maintain room 5 STEREO Doc. Lib. |  | 377d | 2003-05-01 | 2004-10-28 | 114SS |  |  | 2003-04-01 | 2004-09-27 | 377d | 222d |  | start no earlier than 2003-04-30 | STEREO | IMPACT | SEP Package | SEP Package |  | CIT |  |
| 116 | 2.1.3 | Respond to electronics test/cal inquiries |  | 377d | 2003-05-01 | 2004-10-28 | 114SS |  |  | 2003-04-01 | 2004-09-27 | 377d | 222d |  | start no earlier than 2003-04-30 | STEREO | IMPACT | SEP Package | SEP Package |  | CIT |  |
| 117 | 2.1.4 | Procure lab equip, tools, supplies |  | 377d | 2003-05-01 | 2004-10-28 | 114SS |  |  | 2003-04-01 | 2004-09-27 | 377d | 222d |  | start no earlier than 2003-04-30 | STEREO | IMPACT | SEP Package | SEP Package |  | CIT |  |
| 118 | 2.1.5 | Maintain lab equip |  | 377d | 2003-05-01 | 2004-10-28 | 114SS |  |  | 2003-04-01 | 2004-09-27 | 377d | 222d |  | start no earlier than 2003-04-30 | STEREO | IMPACT | SEP Package | SEP Package |  | CIT |  |
| 119 | 2.1.6 | LET tel EM integration/documentation |  | 10d | 2003-05-08 | 2003-05-21 | 114 |  |  | 2003-04-08 | 2003-04-21 | 10d | 156.75d | 0d | start no earlier than 2003-04-30 | STEREO | IMPACT | SEP Package | SEP Package |  | CIT |  |
| 120 | 2.1.7 | Integrate/Test SEP Central Logic Board EM With IDPU |  | 2.5d | 2003-05-08 A | 2003-05-12 A | 201, 202, 18, 22, 194, 200, 93 | 100% |  | 2003-07-22 | 2003-07-29 | 5d |  |  |  | STEREO | IMPACT | SEP Package | SEP Package |  |  |  |
| 121 | 2.1.8 | Complete Integrate/Test SEP Central EM |  | 2.5d | 2003-06-06 | 2003-06-10 | 120, 22, 20 |  |  | 2003-06-09 | 2003-06-11 | 2.5d | 111d | 7d | start no earlier than 2003-05-31 | STEREO | IMPACT | SEP Package | SEP Package |  |  |  |
| 122 | 2.1.9 | Integrate/Test SIT EM |  | 5d | 2003-06-20 | 2003-06-26 | 75, 121 |  |  | 2003-07-29 | 2003-08-05 | 5d | 141.75d | 0d |  | STEREO | IMPACT | SEP Package | SEP Package |  |  |  |
| 123 | 2.1.10 | Integrate/Test SEPT EM |  | 10d | 2003-08-27 | 2003-09-11 | 82, 121 |  |  | 2003-07-29 | 2003-08-12 | 10d | 35.4d | 0d |  | STEREO | IMPACT | SEP Package | SEP Package |  |  |  |
| 124 | 2.1.11 | Integrate/Test HET EM |  | 5d | 2003-07-08 | 2003-07-14 | 57, 121 |  |  | 2003-07-29 | 2003-08-05 | 5d | 130.75d | 21d |  | STEREO | IMPACT | SEP Package | SEP Package |  |  |  |
| 125 | 2.1.12 | Integrate/Test LET EM |  | 5d | 2003-07-30 | 2003-08-05 | 119, 64, 68, 30, 121 |  |  | 2003-08-28 | 2003-09-04 | 5d | 532d |  |  | STEREO | IMPACT | SEP Package | SEP Package |  |  |  |
| 126 | 2.1.13 | LVPS Compatibility Test |  | 5d | 2003-07-31 | 2003-08-07 | 26, 24 |  |  | 2003-08-06 | 2003-08-12 | 5d | 113d | 0d |  | STEREO | IMPACT | SEP Package | SEP Package |  |  |  |

Notes:
- 100: FNL 5/17/04
- 114: Per CDR slides changed dur from 10 days to 5 days, (pg 16) of LET Overview

| ID | WBS | Task | Duration | Start | Finish | Predecessors | Baseline start | Baseline finish | Baseline duration | Total slack | Free slack | Constraint | Text11 | Text12 | Text13 | Text14 | Text28 |
| --- | --- | --- | --- | --- | --- | --- | --- | --- | --- | --- | --- | --- | --- | --- | --- | --- | --- |
| 127 | 2.2 | **FM 1 & FM 2** | 270d | 2003-05-01 | 2004-05-26 |  | 2003-02-03 | 2004-06-17 | 347d | 138d |  |  | STEREO | IMPACT | SEP Package | SEP Package |  |
| 128 | 2.2.1 | Software Support For SEP Integration | 115d | 2003-12-12 | 2004-05-26 | 154SS, 140SS | 2004-01-06 | 2004-06-17 | 115d | 329d |  |  | STEREO | IMPACT | SEP Package | SEP Package | CIT |
| 129 | 2.2.2 | LET tel flight integration/documentation | 50d | 2003-05-22 | 2003-08-01 | 119 | 2003-04-22 | 2003-07-01 | 50d | 156.75d |  | start no earlier than 2003-04-30 | STEREO | IMPACT | SEP Package | SEP Package | CIT |
| 130 | 2.2.3 | Generate SEPT integration & test procedure | 5d | 2003-09-17 | 2003-09-23 |  | 2003-09-17 | 2003-09-23 | 5d | 110.75d | 64d | start no earlier than 2003-09-17 | STEREO | IMPACT | SEP Package | SEP Package | CIT |
| 131 | 2.2.4 | Generate LET integration & test procedure | 5d | 2004-01-06 | 2004-01-13 | 156FS-5d, 142FS-6d | 2004-01-28 | 2004-02-03 | 5d | 13d | 0d |  | STEREO | IMPACT | SEP Package | SEP Package | CIT |
| 132 | 2.2.5 | Generate HET integration & test procedure | 5d | 2004-01-14 | 2004-01-20 | 157FS-5d, 143FS-5d | 2004-02-04 | 2004-02-10 | 5d | 13d | 0d |  | STEREO | IMPACT | SEP Package | SEP Package | CIT |
| 133 | 2.2.6 | Generate SIT integration & test procedure | 4d | 2004-02-11 | 2004-02-18 | 159FS-5d, 145FS-5d | 2004-02-11 | 2004-02-17 | 4d | -1.25d | 0d |  | STEREO | IMPACT | SEP Package | SEP Package | CIT |
| 134 | 2.2.7 | Generate SEP system test procedure | 5d | 2004-02-19 | 2004-02-26 | 161FS-5d, 147FS-5d | 2004-02-19 | 2004-02-25 | 5d | -0.25d | 0d |  | STEREO | IMPACT | SEP Package | SEP Package | CIT |
| 135 | 2.2.8 | Soft Support For Acceptance Testing of SEP Instruments | 25d | 2004-03-09 | 2004-04-13 | 163SS, 148SS | 2004-02-26 | 2004-03-31 | 25d | 360.25d |  |  | STEREO | IMPACT | SEP Package | SEP Package | CIT |
| 136 | 2.2.9 | Generate SEP-IDPU integration procedure | 4d | 2004-03-29 | 2004-04-02 | 163 | 2004-03-17 | 2004-03-22 | 4d | -8.75d | 0d |  | STEREO | IMPACT | SEP Package | SEP Package | CIT |
| 137 | 2.2.10 | Generate SEP-IDPU test procedure | 4d | 2004-04-02 | 2004-04-08 | 164SS | 2004-03-23 | 2004-03-26 | 4d | 0d |  |  | STEREO | IMPACT | SEP Package | SEP Package | CIT |
| 138 | 2.2.11 | Software Support of SEP Accelerator Tests | 20d | 2003-05-01 | 2003-05-29 |  | 2003-02-03 | 2003-03-03 | 20d | 579d |  | start no earlier than 2003-04-30 | STEREO | IMPACT | SEP Package | SEP Package | CIT |
| 139 | 2.3 | **FM 1** | 267d | 2003-11-19 | 2004-12-10 |  | 2003-11-20 | 2004-11-29 | 257d | 29d |  |  | STEREO | IMPACT | SEP Package | SEP Package |  |
| 140 | 2.3.1 | Integrate/test SEP Central FM 1 | 10d | 2003-12-12 | 2003-12-26 | 35, 37, 39, 194, 43, 6, 41 | 2003-12-01 | 2003-12-12 | 10d | 46.75d | 0d |  | STEREO | IMPACT | SEP Package | SEP Package |  |
| 141 | 2.3.2 | Receive & inspect SEPT FM 1 | 1d | 2003-11-19 | 2003-11-19 | 84, 86 | 2003-11-20 | 2003-11-20 | 1d | 71.75d | 25d |  | STEREO | IMPACT | SEP Package | SEP Package |  |
| 142 | 2.3.3 | Integrate & test SEPT FM 1 | 10d | 2003-12-29 | 2004-01-13 | 130, 141, 140 | 2003-12-15 | 2003-12-29 | 10d | 46.75d | 0d |  | STEREO | IMPACT | SEP Package | SEP Package |  |
| 143 | 2.3.4 | Integrate & test LET FM 1 | 5d | 2004-01-14 | 2004-01-20 | 129, 131, 70, 142, 66 | 2004-02-04 | 2004-02-10 | 5d | 13d | 0d |  | STEREO | IMPACT | SEP Package | SEP Package |  |
| 144 | 2.3.5 | Receive & inspect HET FM 1 | 1d | 2004-01-16 | 2004-01-19 | 59 | 2004-01-02 | 2004-01-02 | 1d | 48.5d |  |  | STEREO | IMPACT | SEP Package | SEP Package |  |
| 145 | 2.3.6 | Integrate & test HET FM 1 | 5d | 2004-01-21 | 2004-01-27 | 132, 143, 144 | 2004-02-11 | 2004-02-18 | 5d | 14d | 0d |  | STEREO | IMPACT | SEP Package | SEP Package |  |
| 146 | 2.3.7 | Receive & inspect SIT FM 1 | 1d | 2004-01-26 | 2004-01-27 | 77 | 2004-01-15 | 2004-01-15 | 1d | 47.25d |  |  | STEREO | IMPACT | SEP Package | SEP Package |  |
| 147 | 2.3.8 | Integrate & test SIT FM 1 | 5d | 2004-02-18 | 2004-02-25 | 146, 145, 133 | 2004-02-19 | 2004-02-25 | 5d | 0.75d | 0d |  | STEREO | IMPACT | SEP Package | SEP Package |  |
| 148 | 2.3.9 | SEP system test FM 1 | 14d | 2004-02-26 | 2004-03-17 | 134, 147 | 2004-02-26 | 2004-03-16 | 14d | 3.75d |  |  | STEREO | IMPACT | SEP Package | SEP Package |  |
| 149 | 2.3.10 | Integrate SEP FM 1 -IDPU | 5d | 2004-04-02 | 2004-04-09 | 136, 148 | 2004-03-23 | 2004-03-29 | 5d | -8.75d | 0d |  | STEREO | IMPACT | SEP Package | SEP Package |  |
| 150 | 2.3.11 | Test SEP FM 1 -IDPU | 4d | 2004-04-09 | 2004-04-15 | 149 | 2004-03-30 | 2004-04-02 | 4d | -8.75d | 0d |  | STEREO | IMPACT | SEP Package | SEP Package |  |
| 151 | 2.3.12 | Rework SEP FM 1-IDPU issues and retest | 4d | 2004-04-15 | 2004-04-21 | 150 | 2004-04-05 | 2004-04-08 | 4d | -8.75d | 0d |  | STEREO | IMPACT | SEP Package | SEP Package |  |
| 152 | 2.3.13 | Maintain hard copy docs | 241d | 2003-12-29 | 2004-12-10 | 140 | 2003-12-15 | 2004-11-29 | 241d | 193d |  |  | STEREO | IMPACT | SEP Package | SEP Package |  |

| ID | WBS | Task | Duration | Start | Finish | Predecessors | Baseline start | Baseline finish | Baseline duration | Total slack | Free slack | Constraint | Text11 | Text12 | Text13 | Text14 | Text28 | Text21 |
| --- | --- | --- | --- | --- | --- | --- | --- | --- | --- | --- | --- | --- | --- | --- | --- | --- | --- | --- |
| 153 | 2.4 | **FM 2** | 257d | 2003-12-04 | 2004-12-10 |  | 2003-11-25 | 2005-01-04 | 278d | 19d |  |  | STEREO | IMPACT | SEP Package | SEP Package | CIT |  |
| 154 | 2.4.1 | Integrate/testSEP Central FM 2 | 10d | 2003-12-12 | 2003-12-26 | 194, 54, 46, 48, 50, 6, 41 | 2004-01-06 | 2004-01-20 | 10d | 13d | 0d |  | STEREO | IMPACT | SEP Package | SEP Package | CIT |  |
| 155 | 2.4.2 | Receive & inspect SEPT FM 2 | 1d | 2003-12-04 | 2003-12-04 | 88, 90 | 2003-11-25 | 2003-11-25 | 1d | 61.75d |  |  | STEREO | IMPACT | SEP Package | SEP Package | CIT |  |
| 156 | 2.4.3 | Integrate & test SEPT FM 2 | 10d | 2003-12-29 | 2004-01-13 | 154, 155, 130 | 2004-01-21 | 2004-02-03 | 10d | 13d | 0d |  | STEREO | IMPACT | SEP Package | SEP Package | CIT | Begin I & T |
| 157 | 2.4.4 | Integrate & test LET FM 2 | 5d | 2004-01-14 | 2004-01-20 | 72, 131, 129, 66, 156 | 2004-02-04 | 2004-02-10 | 5d | 13d | 0d |  | STEREO | IMPACT | SEP Package | SEP Package | CIT |  |
| 158 | 2.4.5 | Receive & inspect HET FM 2 | 1d | 2004-02-10 | 2004-02-11 | 61 | 2004-01-30 | 2004-01-30 | 1d | -2.25d | 0d |  | STEREO | IMPACT | SEP Package | SEP Package | CIT |  |
| 159 | 2.4.6 | Integrate & test HET FM 2 | 5d | 2004-02-11 | 2004-02-19 | 132, 157, 158 | 2004-02-11 | 2004-02-18 | 5d | -2.25d | 0d |  | STEREO | IMPACT | SEP Package | SEP Package | CIT |  |
| 160 | 2.4.7 | Receive & inspect SIT FM 2 | 1d | 2004-02-05 | 2004-02-06 | 79 | 2004-01-23 | 2004-01-23 | 1d | 39.25d |  |  | STEREO | IMPACT | SEP Package | SEP Package | CIT |  |
| 161 | 2.4.8 | Integrate & test SIT FM 2 | 5d | 2004-02-19 | 2004-02-26 | 133, 160, 159 | 2004-02-19 | 2004-02-25 | 5d | -2.25d | 0d |  | STEREO | IMPACT | SEP Package | SEP Package | CIT |  |
| 162 | 2.4.9 | Integrate FM 2 LVPS into SEP Central (if necessary) | 2d | 2004-03-05 | 2004-03-09 | 52, 161 |  |  |  | -8.75d | 0d |  | STEREO | IMPACT | SEP Package | SEP Package |  |  |
| 163 | 2.4.10 | SEP FM 2 system test | 14d | 2004-03-09 | 2004-03-29 | 134, 162 | 2004-02-26 | 2004-03-16 | 14d | -8.75d | 0d |  | STEREO | IMPACT | SEP Package | SEP Package | CIT | SEP System Test |
| 164 | 2.4.11 | Integrate SEP FM 2 -IDPU | 4d | 2004-04-02 | 2004-04-08 | 163, 136 | 2004-03-23 | 2004-03-26 | 4d | 0d |  |  | STEREO | IMPACT | SEP Package | SEP Package | CIT |  |
| 165 | 2.4.12 | Test SEP FM 2 -IDPU | 4d | 2004-04-08 | 2004-04-14 | 164, 137 | 2004-03-29 | 2004-04-01 | 4d | 18d | 0d |  | STEREO | IMPACT | SEP Package | SEP Package | CIT |  |
| 166 | 2.4.13 | Rework SEP FM 2 -IDPU issues and retest | 4d | 2004-04-14 | 2004-04-20 | 165 | 2004-04-02 | 2004-04-07 | 4d | 18d | 0d |  | STEREO | IMPACT | SEP Package | SEP Package | CIT |  |
| 167 | 2.4.14 | Maintain hard copy docs | 241d | 2003-12-29 | 2004-12-10 | 154 | 2004-01-21 | 2005-01-04 | 241d | 193d |  |  | STEREO | IMPACT | SEP Package | SEP Package | CIT |  |
| 168 | 3 | **Environmental Test** | 128.75d | 2004-02-09 | 2004-08-10 |  | 2004-02-09 | 2004-08-03 | 124d | 38.75d |  |  | STEREO | IMPACT | SEP Package | SEP Package | CIT |  |
| 169 | 3.1 | Generate Environmental Test Procedures | 15d | 2004-04-02 | 2004-04-23 | 137SS | 2004-03-29 | 2004-04-16 | 15d | 0d |  |  | STEREO | IMPACT | SEP Package | SEP Package | CIT |  |
| 170 | 3.2 | Manufacture test cables | 9d | 2004-02-09 | 2004-02-20 |  | 2004-02-09 | 2004-02-20 | 9d | 397d |  | start no earlier than 2004-02-09 | STEREO | IMPACT | SEP Package | SEP Package | CIT |  |
| 171 | 3.3 | **FM 1** | 50d | 2004-05-19 | 2004-07-30 |  | 2004-05-13 | 2004-07-23 | 50d | 0.25d |  |  | STEREO | IMPACT | SEP Package | SEP Package |  |  |
| 172 | 3.3.1 | FM 1 HET/LET Accelerator Test | 10d | 2004-05-19 | 2004-06-03 | 191, 203, 204, 12FS-2d | 2004-05-13 | 2004-05-26 | 10d | 0.25d | 0d |  | STEREO | IMPACT | SEP Package | SEP Package |  |  |
| 173 | 3.3.2 | FM 1 LET/HET/SEP Central Vibration/Acoustics Test | 10d | 2004-06-03 | 2004-06-17 | 172 | 2004-05-27 | 2004-06-10 | 10d | 0.25d | 0d |  | STEREO | IMPACT | SEP Package | SEP Package |  |  |
| 174 | 3.3.3 | FM 1 LET/HET/SIT/SEP Central T/V Test | 15d | 2004-06-17 | 2004-07-09 | 173 | 2004-06-11 | 2004-07-01 | 15d | 0.25d | 0d |  | STEREO | IMPACT | SEP Package | SEP Package |  |  |
| 175 | 3.3.4 | Evaluate SEP performance | 10d | 2004-07-09 | 2004-07-23 | 174 | 2004-07-02 | 2004-07-16 | 10d | 284.25d | 0d |  | STEREO | IMPACT | SEP Package | SEP Package |  |  |
| 176 | 3.3.5 | Generate test reports | 15d | 2004-07-09 | 2004-07-30 | 175SS | 2004-07-02 | 2004-07-23 | 15d | 284.25d |  |  | STEREO | IMPACT | SEP Package | SEP Package |  |  |
| 177 | 3.3.6 | Bakeout Clean SEP exterior & prepare for delivery | 3d | 2004-07-09 | 2004-07-14 | 174, 8 | 2004-07-02 | 2004-07-07 | 3d | 0.25d | 0d |  | STEREO | IMPACT | SEP Package | SEP Package |  |  |

Notes:
- 154: March 03 Status - Removed Predecessor of LVPS FM 2 to verify it is the driver of the suite.
- 169: 2003 May Status - Change the logic to have these procedures written in parallel with the I & T procedures of each instrument/component. The entire I & T areas of both the Boom Suite and SEP Package should be revisited.

| ID | WBS | Task | Type | Duration | Start | Finish | Predecessors | Complete | Remaining | Baseline start | Baseline finish | Baseline duration | Total slack | Free slack | Constraint | Text11 | Text12 | Text13 | Text14 | Text28 | Text20 |
| --- | --- | --- | --- | --- | --- | --- | --- | --- | --- | --- | --- | --- | --- | --- | --- | --- | --- | --- | --- | --- | --- |
| 178 | 3.4 | **FM 2** |  | 50d | 2004-05-28 | 2004-08-10 |  |  |  | 2004-05-24 | 2004-08-03 | 50d | 2.25d |  |  | STEREO | IMPACT | SEP Package | SEP Package |  |  |
| 179 | 3.4.1 | FM 2 HET/LET Accelerator Test |  | 10d | 2004-05-28 | 2004-06-14 | 191, 203, 204, 14 |  |  | 2004-05-24 | 2004-06-07 | 10d | 2.25d | 0d |  | STEREO | IMPACT | SEP Package | SEP Package |  |  |
| 180 | 3.4.2 | FM 2 LET/HET/SEP Central Vibration/Acoustics Test |  | 10d | 2004-06-14 | 2004-06-28 | 179 |  |  | 2004-06-08 | 2004-06-21 | 10d | 2.25d | 0d |  | STEREO | IMPACT | SEP Package | SEP Package |  |  |
| 181 | 3.4.3 | FM 2 LET/HET/SIT/SEP Central T/V Test |  | 15d | 2004-06-28 | 2004-07-20 | 180 |  |  | 2004-06-22 | 2004-07-13 | 15d | 2.25d | 0d |  | STEREO | IMPACT | SEP Package | SEP Package |  |  |
| 182 | 3.4.4 | Evaluate SEP performance |  | 10d | 2004-07-20 | 2004-08-03 | 181 |  |  | 2004-07-14 | 2004-07-27 | 10d | 277.25d | 0d |  | STEREO | IMPACT | SEP Package | SEP Package | CIT |  |
| 183 | 3.4.5 | Generate test reports |  | 15d | 2004-07-20 | 2004-08-10 | 182SS |  |  | 2004-07-14 | 2004-08-03 | 15d | 277.25d |  |  | STEREO | IMPACT | SEP Package | SEP Package | CIT |  |
| 184 | 3.4.6 | Bakeout Clean SEP exterior & prepare for delivery |  | 3d | 2004-07-20 | 2004-07-23 | 181 |  |  | 2004-07-14 | 2004-07-16 | 3d | 2.25d |  |  | STEREO | IMPACT | SEP Package | SEP Package | CIT | Begin SEP Final I & T |
| 185 | 4 | **Emulators/Simulators/GSE** |  | 1144d | 2001-03-01 A | 2005-09-16 |  | 42% | 662.8d | 2001-03-01 | 2005-09-16 | 1144d | 0d |  |  | STEREO | IMPACT | SEP Package | SEP Package | CIT |  |
| 186 | 4.1 | **GSE** |  | 1144d | 2001-03-01 A | 2005-09-16 |  | 42% | 662.8d | 2001-03-01 | 2005-09-16 | 1144d | 0d |  |  | STEREO | IMPACT | SEP Package | SEP Package | CIT |  |
| 187 | 4.1.1 | GSE Release 1 Ready | milestone | 0d | 2003-05-30 A | 2003-06-10 | 201, 194 | 90% | 0d | 2003-07-22 | 2003-07-22 | 0d | 571.2d |  |  | STEREO | IMPACT | SEP Package | GSE | CIT |  |
| 188 | 4.1.2 | **Design hardware** |  | 655d | 2001-08-01 A | 2004-03-12 |  | 5% | 620.07d | 2001-08-01 | 2004-03-12 | 655d | 48d |  |  | STEREO | IMPACT | SEP Package | GSE | CIT |  |
| 189 | 4.1.2.1 | Initial GSE H/W Design |  | 3d | 2001-08-01 A | 2001-08-03 A |  | 100% |  | 2001-08-01 | 2001-08-03 | 3d |  |  | start no earlier than 2001-08-01 | STEREO | IMPACT | SEP Package | GSE | CIT |  |
| 190 | 4.1.2.2 | Final GSE H/W Design |  | 1d | 2002-12-02 A | 2002-12-02 A | 189FS+123d | 100% |  | 2002-12-02 | 2002-12-02 | 1d |  |  | start no earlier than 2002-11-30 | STEREO | IMPACT | SEP Package | GSE | CIT |  |
| 191 | 4.1.2.3 | GSE H/W Calibration equipment |  | 71d | 2003-12-01 | 2004-03-12 |  |  |  | 2003-12-01 | 2004-03-12 | 71d | 48d | 47.75d | start no earlier than 2003-12-01 | STEREO | IMPACT | SEP Package | GSE | CIT |  |
| 192 | 4.1.3 | **Assemble & test** |  | 1d | 2002-12-02 A | 2002-12-02 A |  | 100% |  | 2002-12-02 | 2002-12-02 | 1d |  |  |  | STEREO | IMPACT | SEP Package | SEP Package | CIT |  |
| 193 | 4.1.3.1 | Initial GSE H/W Assembly |  | 1d | 2002-12-02 A | 2002-12-02 A | 190FS+19d | 100% |  | 2002-12-02 | 2002-12-02 | 1d |  |  |  | STEREO | IMPACT | SEP Package | GSE | CIT |  |
| 194 | 4.1.3.2 | GSE H/W Test |  | 1d | 2002-12-02 A | 2002-12-02 A | 193FS+24d | 100% |  | 2002-12-02 | 2002-12-02 | 1d |  |  |  | STEREO | IMPACT | SEP Package | GSE | CIT |  |
| 195 | 4.1.4 | **GSE software** |  | 1144d | 2001-03-01 A | 2005-09-16 |  | 45% | 634.51d | 2001-03-01 | 2005-09-16 | 1144d | 0d |  |  | STEREO | IMPACT | SEP Package | SEP Package | CIT |  |
| 196 | 4.1.4.1 | Preliminary design activities |  | 189d | 2001-03-01 A | 2001-11-28 A |  | 100% |  | 2001-03-01 | 2001-11-28 | 189d |  |  | start no earlier than 2001-03-01 | STEREO | IMPACT | SEP Package | GSE | CIT |  |
| 197 | 4.1.4.2 | Write software development plan |  | 61d | 2001-09-04 A | 2001-11-30 A | 196SS+130d | 100% |  | 2001-09-04 | 2001-11-30 | 61d |  |  |  | STEREO | IMPACT | SEP Package | GSE | CIT |  |
| 198 | 4.1.4.3 | Initial s/w des & implementation of generic pieces |  | 98d | 2002-10-01 A | 2003-02-24 A | 197SS+10d | 100% |  | 2001-10-01 | 2003-02-24 | 69.9d |  |  | finish no earlier than 2003-02-24 | STEREO | IMPACT | SEP Package | GSE | CIT |  |
| 199 | 4.1.4.4 | Preparation for informal s/w reqs & des rev |  | 5d | 2002-05-13 A | 2002-05-17 A |  | 100% |  | 2002-05-13 | 2002-05-17 | 5d |  |  |  | STEREO | IMPACT | SEP Package | GSE | CIT |  |
| 200 | 4.1.4.5 | Write & Test Instrument Simulator S/W |  | 61d | 2002-12-03 A | 2003-05-14 A | 194 | 100% |  | 2002-12-03 | 2003-03-03 | 61d |  |  |  | STEREO | IMPACT | SEP Package | SEP Package |  |  |
| 201 | 4.1.4.6 | Finalize des & complete GSE release 1 |  | 68d | 2003-02-25 A | 2003-06-10 | 198, 199 | 90% | 6.8d | 2003-02-25 | 2003-05-30 | 68d | 52.2d | 0d |  | STEREO | IMPACT | SEP Package | GSE | CIT |  |
| 202 | 4.1.4.7 | Write user's guide |  | 5d | 2003-06-10 | 2003-06-17 | 201 |  |  | 2003-07-15 | 2003-07-22 | 5d | 52.2d |  |  | STEREO | IMPACT | SEP Package | GSE | CIT |  |
| 203 | 4.1.4.8 | Build GSE software release 2 |  | 113d | 2003-09-02 | 2004-02-13 | 201, 202 |  |  | 2003-09-02 | 2004-02-13 | 113d | 0d |  | start no earlier than 2003-09-01 | STEREO | IMPACT | SEP Package | GSE | CIT |  |
| 204 | 4.1.4.9 | Write user's guide supplement |  | 10d | 2004-02-02 | 2004-02-13 | 202, 203FS-10d |  |  | 2004-02-02 | 2004-02-13 | 10d | 67d | 66.75d |  | STEREO | IMPACT | SEP Package | GSE | CIT |  |
| 205 | 4.1.4.10 | Build GSE software release 3 |  | 125d | 2003-11-24 | 2004-05-21 | 203FS-56d |  |  | 2003-11-24 | 2004-05-21 | 125d | 0d |  |  | STEREO | IMPACT | SEP Package | GSE | CIT |  |
| 206 | 4.1.4.11 | Post Delivery Support |  | 332d | 2004-05-24 | 2005-09-16 | 205 |  |  | 2004-05-24 | 2005-09-16 | 332d | 0d |  |  | STEREO | IMPACT | SEP Package | GSE | CIT |  |

Notes:
- 184: EMC is a pred to this activity right now.
- 190: Reduced lag by 23 days on successor
- 198: In July we broke up build1 into initial and then final. so that we got back on track. finish this off. / Receive an e-mail from Alan on 11/25 breaking out the GSE, this should activity should finish 12/02 so I modified this for worst case ending on 12/31/02. Will modify it's successor to end on 5/30/03 based on the 11/25 e-mail.
- 201: Receive an e-mail from Alan on 11/25 breaking out the GSE, this activity should finish 5/30/03. Will modify it's predessor to end on 12/31/02 based on the 11/25 e-mail.
