# SEPT - Solar Electron and Proton Telescope

Schedule from MS Project, 2001-01-02 to 2003-12-03, status date 2003-05-31, A marks actual dates.
SEPT Instrument Development Schedule
NASA GSFC
Status Date: 05/31/2003 / Baseline Date: 01/31/2003 R1

## Calendars

- Standard w/ 10 Gov't Holidays: Mon-Fri 08:00-12:00, 13:00-17:00; Sat-Sun off. Exceptions (off unless hours are given): 2001-01-15, 2001-02-19, 2001-05-28, 2001-07-04, 2001-09-03, 2001-10-08, 2001-11-12, 2001-11-22, 2001-12-25, 2002-01-01, 2002-01-14, 2002-02-18, 2002-05-27, 2002-07-04, 2002-09-02, 2002-10-07, 2002-11-11, 2002-11-28, 2002-12-25, 2003-01-01, 2003-01-13, 2003-02-17, 2003-05-26, 2003-07-04, 2003-09-01, 2003-10-06, 2003-11-10, 2003-11-27.
- Standard w/ Dutch Holidays: Mon-Fri 08:00-12:00, 13:00-17:00; Sat-Sun off.
- Standard w/ German Holidays: Mon-Fri 08:00-12:00, 13:00-17:00; Sat-Sun off. Exceptions (off unless hours are given): 2002-01-01, 2002-03-29, 2002-04-01, 2002-05-01, 2002-05-09, 2002-05-20, 2002-10-03, 2002-12-24 to 2002-12-26, 2002-12-31 to 2003-01-01, 2003-04-18, 2003-04-21, 2003-05-01, 2003-05-29, 2003-06-09, 2003-10-03.

## Resources

| Resource |
| --- |
| Sandi |
| PF |
| TOS-ESM |
| DK |
| JH |
| LD |
| BJ |
| ESTEC |
| IMEC |
| Smit |
| TBD |
| KTH |
| Kiel |

## Schedule

| ID | WBS | Task | Type | Duration | Start | Finish | Predecessors | Complete | Remaining | Baseline start | Baseline finish | Baseline duration | Total slack | Free slack | Constraint | Calendar | Text11 | Text12 | Text13 | Text14 | Text16 | Text28 | Text20 | Text22 | Text23 | Text19 | Text21 |
| --- | --- | --- | --- | --- | --- | --- | --- | --- | --- | --- | --- | --- | --- | --- | --- | --- | --- | --- | --- | --- | --- | --- | --- | --- | --- | --- | --- |
| 1 | 1 | **Management** |  | 427d | 2002-03-18 A | 2003-11-25 |  | 99% | 0d | 2002-03-18 | 2003-11-17 | 421d | 0d |  |  |  | STEREO | IMPACT | SEP Package | SEPT | SEPT |  |  |  |  |  |  |
| 2 | 1.1 | Workshop STEREO |  | 3d | 2002-03-18 A | 2002-03-20 A |  | 100% |  | 2002-03-18 | 2002-03-20 | 3d |  |  | start no earlier than 2002-03-18 |  | STEREO | IMPACT | SEP Package | SEPT | SEPT |  |  |  |  |  |  |
| 3 | 1.2 | Start Phase C/D |  | 1d | 2002-04-01 A | 2002-04-01 A |  | 100% |  | 2002-04-01 | 2002-04-01 | 1d |  |  | start no earlier than 2002-04-01 |  | STEREO | IMPACT | SEP Package | SEPT | SEPT |  |  |  |  |  |  |
| 4 | 1.3 | **Milestones** |  | 374d | 2002-05-31 A | 2003-11-25 |  | 99% | 0d | 2002-05-31 | 2003-11-17 | 368d | 0d |  |  |  | STEREO | IMPACT | SEP Package | SEPT | SEPT |  |  |  |  |  |  |
| 5 | 1.3.1 | Design Review |  | 1d | 2002-05-31 A | 2002-05-31 A | 133, 90 | 100% |  | 2002-05-31 | 2002-05-31 | 1d |  |  | start no earlier than 2002-05-31 |  | STEREO | IMPACT | SEP Package | SEPT | SEPT |  |  |  |  |  |  |
| 6 | 1.3.2 | SEPT Doors and Contamination Review |  | 1d | 2002-09-23 A | 2002-09-23 A |  | 100% |  | 2002-09-23 | 2002-09-23 | 1d |  |  | start no earlier than 2002-09-30 | Standard w/ German Holidays | STEREO | IMPACT | SEP Package | SEPT | SEPT | KIEL |  |  |  |  |  |
| 7 | 1.3.3 | **Contingency** |  | 18d | 2003-10-29 | 2003-11-25 |  |  |  | 2003-10-28 | 2003-11-17 | 14d | -6d | 0d |  |  | STEREO | IMPACT | SEP Package | SEPT | SEPT |  |  |  |  |  |  |
| 8 | 1.3.3.1 | Deliver SEPT-NS FM 1 Contingency | milestone | 0d | 2003-10-29 | 2003-10-29 | 201 |  |  | 2003-10-28 | 2003-11-03 | 5d | 3d | 0d |  | Standard w/ German Holidays | STEREO | IMPACT | SEP Package | SEPT | SEPT | KIEL |  |  |  |  |  |
| 9 | 1.3.3.2 | Deliver SEPT-E FM 1 Contingency | milestone | 0d | 2003-11-11 | 2003-11-11 | 206 |  |  | 2003-10-28 | 2003-11-03 | 5d | -6d | 0d |  | Standard w/ German Holidays | STEREO | IMPACT | SEP Package | SEPT | SEPT | KIEL |  |  |  |  |  |
| 10 | 1.3.3.3 | Deliver SEPT-NS FM 2 Contingency | milestone | 0d | 2003-11-18 | 2003-11-18 | 212 |  |  | 2003-11-13 | 2003-11-17 | 3d | -1d | 0d |  | Standard w/ German Holidays | STEREO | IMPACT | SEP Package | SEPT | SEPT | KIEL |  |  |  |  |  |
| 11 | 1.3.3.4 | Deliver SEPT-E FM 2 Contingency | milestone | 0d | 2003-11-25 | 2003-11-25 | 217 |  |  | 2003-11-13 | 2003-11-17 | 3d | -6d | 0d |  | Standard w/ German Holidays | STEREO | IMPACT | SEP Package | SEPT | SEPT | KIEL |  |  |  |  |  |
| 12 | 1.3.4 | **Receivables** |  | 118d | 2003-04-25 A | 2003-10-14 |  |  | 118d | 2003-04-25 | 2003-09-11 | 96d | 29d |  |  |  | STEREO | IMPACT | SEP Package | SEPT | SEPT |  |  |  |  |  |  |
| 13 | 1.3.4.1 | Receive SEPT ETU Electronics From ESTEC | milestone | 0d | 2003-04-25 A | 2003-04-25 A | 25FS+1d | 100% |  | 2003-04-25 | 2003-04-25 | 0d |  |  |  | Standard w/ German Holidays | STEREO | IMPACT | SEP Package | SEPT | SEPT | KIEL |  |  |  |  |  |
| 14 | 1.3.4.2 | Receive SEPT-NS FM 1 Electronics From ESTEC | milestone | 0d | 2003-08-14 | 2003-08-14 | 28 |  |  | 2003-08-14 | 2003-08-14 | 0d | 15d |  |  | Standard w/ German Holidays | STEREO | IMPACT | SEP Package | SEPT | SEPT | KIEL |  |  |  |  |  |
| 15 | 1.3.4.3 | Receive SEPT-E FM 1 Electronics From ESTEC | milestone | 0d | 2003-09-15 | 2003-09-15 | 29 |  |  | 2003-08-14 | 2003-08-14 | 0d | -7d | 0d |  | Standard w/ German Holidays | STEREO | IMPACT | SEP Package | SEPT | SEPT | KIEL |  |  |  |  |  |
| 16 | 1.3.4.4 | Receive SEPT-NS FM 2 Electronics From ESTEC | milestone | 0d | 2003-09-15 | 2003-09-15 | 30 |  |  | 2003-08-14 | 2003-08-14 | 0d | 12d |  |  | Standard w/ German Holidays | STEREO | IMPACT | SEP Package | SEPT | SEPT | KIEL |  |  |  |  |  |
| 17 | 1.3.4.5 | Receive SEPT-E FM 2 Electronics From ESTEC | milestone | 0d | 2003-09-15 | 2003-09-15 | 31 |  |  | 2003-08-14 | 2003-08-14 | 0d | 12d |  |  | Standard w/ German Holidays | STEREO | IMPACT | SEP Package | SEPT | SEPT | KIEL |  |  |  |  |  |
| 18 | 1.3.4.6 | Receive SEPT FS1 Electronics From ESTEC | milestone | 0d | 2003-10-14 | 2003-10-14 | 32 |  |  | 2003-09-11 | 2003-09-11 | 0d | 30d |  |  | Standard w/ German Holidays | STEREO | IMPACT | SEP Package | SEPT | SEPT | KIEL |  |  |  |  |  |
| 19 | 1.3.4.7 | Receive SEPT FS 2 Electronics From ESTEC | milestone | 0d | 2003-10-14 | 2003-10-14 | 33 |  |  | 2003-09-11 | 2003-09-11 | 0d | 30d |  |  | Standard w/ German Holidays | STEREO | IMPACT | SEP Package | SEPT | SEPT | KIEL |  |  |  |  |  |
| 20 | 1.3.4.8 | Receive SEPT-NS FM 1 Brackets from GSFC | milestone | 0d | 2003-08-29 | 2003-08-29 | 34 |  |  | 2003-08-29 | 2003-08-29 | 0d | 83d |  | start no earlier than 2003-08-29 |  | STEREO | IMPACT | SEP Package | SEPT | SEPT |  |  |  |  |  |  |
| 21 | 1.3.4.9 | Receive SEPT-NS FM 2 Brackets from GSFC | milestone | 0d | 2003-08-29 | 2003-08-29 | 35 |  |  | 2003-08-29 | 2003-08-29 | 0d | 83d |  | start no earlier than 2003-08-29 |  | STEREO | IMPACT | SEP Package | SEPT | SEPT |  |  |  |  |  |  |
| 22 | 1.2.7.3 | Deliver SEPT EM Back to Kiel | milestone | 0d | 2003-06-25 | 2003-06-25 |  |  |  | 2003-08-12 | 2003-08-12 | 0d | 89d | 0d |  |  | STEREO | IMPACT | SEP Package | SEPT | SEPT |  |  |  |  |  |  |
| 23 | 1.3.4.11 | Receive SEPT ETU Back From CIT | milestone | 0d | 2003-07-02 | 2003-07-02 | 22FS+5d |  |  | 2003-08-19 | 2003-08-19 | 0d | 89d | 0d |  |  | STEREO | IMPACT | SEP Package | SEPT | SEPT |  |  |  |  |  |  |
| 24 | 1.3.5 | **Deliverables** |  | 148d | 2003-04-24 A | 2003-11-25 |  |  | 148d | 2003-04-18 | 2003-11-17 | 146d | 0d |  |  |  | STEREO | IMPACT | SEP Package | SEPT | SEPT |  |  |  |  |  |  |
| 25 | 1.3.5.1 | Deliver SEPT ETU Electronics to Kiel | milestone | 0d | 2003-04-24 A | 2003-04-24 A | 168 | 100% |  | 2003-04-24 | 2003-04-24 | 0d |  |  |  | Standard w/ Dutch Holidays | STEREO | IMPACT | SEP Package | SEPT | SEPT | ESTEC |  |  |  |  |  |
| 26 | 1.3.5.2 | Deliver SEPT ETUElectronics to CIT | milestone | 0d | 2003-06-11 | 2003-06-11 | 13 |  |  | 2003-06-11 | 2003-06-11 | 0d | 89d | 0d | finish no earlier than 2003-06-11 |  | STEREO | IMPACT | SEP Package | SEPT | SEPT |  | SEPT ETU | SEPT - Deliver ETU to CIT | ETU Delivered |  |  |
| 27 | 1.2.6.9.2 | Receive SEPT EM From Kiel For SEP EM I & T | milestone | 0d | 2003-06-11 | 2003-06-11 | 26 |  |  | 2003-06-24 | 2003-06-24 | 0d | 89d |  |  |  | STEREO | IMPACT | SEP Package | SEPT | SEPT |  |  |  |  |  |  |
| 28 | 1.3.5.4 | Deliver SEPT-NS FM 1 Electronics to Kiel | milestone | 0d | 2003-08-14 | 2003-08-14 | 174 |  |  | 2003-08-14 | 2003-08-14 | 0d | 15d | 0d |  | Standard w/ Dutch Holidays | STEREO | IMPACT | SEP Package | SEPT | SEPT | ESTEC |  |  |  |  |  |
| 29 | 1.3.5.5 | Deliver SEPT-E FM 1 Electronics to Kiel | milestone | 0d | 2003-09-15 | 2003-09-15 | 175 |  |  | 2003-08-14 | 2003-08-14 | 0d | -7d | 0d |  | Standard w/ Dutch Holidays | STEREO | IMPACT | SEP Package | SEPT | SEPT | ESTEC |  |  |  |  |  |
| 30 | 1.3.5.6 | Deliver SEPT-NS FM 2 Electronics to Kiel | milestone | 0d | 2003-09-15 | 2003-09-15 | 181 |  |  | 2003-08-14 | 2003-08-14 | 0d | 12d | 0d |  | Standard w/ Dutch Holidays | STEREO | IMPACT | SEP Package | SEPT | SEPT | ESTEC |  |  |  |  |  |
| 31 | 1.3.5.7 | Deliver SEPT-E FM 2 Electronics to Kiel | milestone | 0d | 2003-09-15 | 2003-09-15 | 182 |  |  | 2003-08-14 | 2003-08-14 | 0d | 12d | 0d |  | Standard w/ Dutch Holidays | STEREO | IMPACT | SEP Package | SEPT | SEPT | ESTEC |  |  |  |  |  |
| 32 | 1.3.5.8 | Deliver SEPT FS 1 Electronics to Kiel | milestone | 0d | 2003-10-14 | 2003-10-14 | 188 |  |  | 2003-09-11 | 2003-09-11 | 0d | 30d | 0d |  | Standard w/ Dutch Holidays | STEREO | IMPACT | SEP Package | SEPT | SEPT | ESTEC |  |  |  |  |  |
| 33 | 1.3.5.9 | Deliver SEPT FS 2 Electronics to Kiel | milestone | 0d | 2003-10-14 | 2003-10-14 | 189 |  |  | 2003-09-11 | 2003-09-11 | 0d | 30d | 0d |  | Standard w/ Dutch Holidays | STEREO | IMPACT | SEP Package | SEPT | SEPT | ESTEC |  |  |  |  |  |
| 34 | 1.3.5.10 | Deliver SEPT-NS FM 1 Brackets to Kiel | milestone | 0d | 2003-08-15 | 2003-08-15 | 125 |  |  | 2003-04-18 | 2003-04-18 | 0d | 92d | 9d |  |  | STEREO | IMPACT | SEP Package | SEPT | SEPT |  |  |  |  |  |  |
| 35 | 1.3.5.11 | Deliver SEPT-NS FM 2 Brackets to Kiel | milestone | 0d | 2003-08-15 | 2003-08-15 | 127 |  |  | 2003-04-18 | 2003-04-18 | 0d | 92d | 9d |  |  | STEREO | IMPACT | SEP Package | SEPT | SEPT |  |  |  |  |  |  |
| 36 | 1.3.5.12 | Deliver SEPT-NS FM 1 w/Brackets to CIT for SEP I & T | milestone | 0d | 2003-10-29 | 2003-10-29 | 8 |  |  | 2003-11-03 | 2003-11-03 | 0d | 3d |  | finish no later than 2003-11-03 |  | STEREO | IMPACT | SEP Package | SEPT | SEPT | GSFC | SEPT FM 1 (Use Latest Date) | SEPT - NS FM 1 Delivery to CIT for SEP I & T | FM 1 NS Delivered | Sandy Shuman | SEPT FM 1 & 2 to CIT |
| 37 | 1.2.6.9.4 | Receive SEPT-NS w/Brackets FM 1 From Kiel For SEP FM 1 I & T | milestone | 0d | 2003-11-05 | 2003-11-05 | 36FS+5d |  |  | 2003-11-20 | 2003-11-20 | 0d | 79.75d |  |  |  | STEREO | IMPACT | SEP Package | SEPT | SEPT |  |  |  |  |  |  |
| 38 | 1.3.5.14 | Deliver SEPT-E FM 1 to CIT for SEP I & T | milestone | 0d | 2003-11-11 | 2003-11-11 | 9 |  |  | 2003-11-03 | 2003-11-03 | 0d | -5d | 0d | finish no later than 2003-11-03 |  | STEREO | IMPACT | SEP Package | SEPT | SEPT | GSFC | SEPT FM 1 (Use Latest Date) | SEPT - E FM 1 Delivery to CIT for SEP I & T | FM 1 E Delivered |  | SEPT FM 1 & 2 to CIT |
| 39 | 1.2.6.9.6 | Receive SEPT-E FM 1 From Kiel For SEP FM 1 I & T | milestone | 0d | 2003-11-18 | 2003-11-18 | 38FS+5d |  |  | 2003-11-20 | 2003-11-20 | 0d | 71.75d |  |  |  | STEREO | IMPACT | SEP Package | SEPT | SEPT |  |  |  |  |  |  |
| 40 | 1.3.5.16 | Deliver SEPT-NS FM 2 w/Brackets to CIT for SEP I & T | milestone | 0d | 2003-11-18 | 2003-11-18 | 10 |  |  | 2003-11-17 | 2003-11-17 | 0d | -1d | 0d | finish no later than 2003-11-17 |  | STEREO | IMPACT | SEP Package | SEPT | SEPT | GSFC | SEPT FM 2 (Use Latest Date) | SEPT - NS FM 2 Delivery to CIT for SEP I & T | FM 2 NS Delivered | Sandy Shuman | SEPT FM 1 & 2 to CIT |
| 41 | 1.2.6.9.8 | Receive SEPT-NS w/Brackets FM 2 From Kiel For SEP FM 2 I & T | milestone | 0d | 2003-11-25 | 2003-11-25 | 40FS+5d |  |  | 2003-11-24 | 2003-11-24 | 0d | 66.75d |  |  |  | STEREO | IMPACT | SEP Package | SEPT | SEPT |  |  |  |  |  |  |
| 42 | 1.3.5.18 | Deliver SEPT-E FM 2 to CIT for SEP I & T | milestone | 0d | 2003-11-25 | 2003-11-25 | 11 |  |  | 2003-11-17 | 2003-11-17 | 0d | -6d | 0d | finish no later than 2003-11-17 |  | STEREO | IMPACT | SEP Package | SEPT | SEPT | GSFC | SEPT FM 2 (Use Latest Date) | SEPT - E FM 2 Delivery to CIT for SEP I & T | FM 2 E Delivered |  | SEPT FM 1 & 2 to CIT |
| 43 | 1.2.6.9.10 | Receive SEPT-E FM 2 From Kiel For SEP FM 2 I & T | milestone | 0d | 2003-12-03 | 2003-12-03 | 42FS+5d |  |  | 2003-11-24 | 2003-11-24 | 0d | 61.75d |  |  |  | STEREO | IMPACT | SEP Package | SEPT | SEPT |  |  |  |  |  |  |

Notes:
- 8: Removed 2 days of duration 1/9/03
- 9: Removed 2 days of duration 1/9/03
- 36: FNL of 10/9/03 removed 1/9/03
- 38: FNL of 10/9/03 removed 1/9/03
- 40: FNL of 10/9/03 removed 1/9/03
- 42: FNL of 10/9/03 removed 1/9/03

| ID | WBS | Task | Type | Duration | Start | Finish | Predecessors | Complete | Baseline start | Baseline finish | Baseline duration | Constraint | Calendar | Resources | Work | Actual work | Text11 | Text12 | Text13 | Text14 | Text16 | Text1 | Text28 |
| --- | --- | --- | --- | --- | --- | --- | --- | --- | --- | --- | --- | --- | --- | --- | --- | --- | --- | --- | --- | --- | --- | --- | --- |
| 44 | 2 | **Systems Engineering** |  | 366d | 2001-08-13 A | 2003-01-29 A |  | 100% | 2001-08-13 | 2003-01-29 | 366d |  |  |  | 1680h | 1680h | STEREO | IMPACT | SEP Package | SEPT | SEPT |  |  |
| 45 | 2.1 | **Documentation** |  | 60d | 2001-08-13 A | 2001-11-06 A |  | 100% | 2001-08-13 | 2001-11-06 | 60d |  |  |  |  |  | STEREO | IMPACT | SEP Package | SEPT | SEPT |  |  |
| 46 | 2.1.1 | SEPT ICD Drawings |  | 60d | 2001-08-13 A | 2001-11-06 A |  | 100% | 2001-08-13 | 2001-11-06 | 60d | start no earlier than 2001-08-13 |  |  |  |  | STEREO | IMPACT | SEP Package | SEPT | SEPT |  |  |
| 47 | 2.2 | **Modeling** |  | 209d | 2002-04-01 A | 2003-01-29 A |  | 100% | 2002-04-01 | 2003-01-29 | 209d |  |  |  |  |  | STEREO | IMPACT | SEP Package | SEPT | SEPT |  |  |
| 48 | 2.2.1 | Mechanical |  | 209d | 2002-04-01 A | 2003-01-29 A | 5FS-40d | 100% | 2002-04-01 | 2003-01-29 | 209d |  |  |  |  |  | STEREO | IMPACT | SEP Package | SEPT | SEPT |  |  |
| 49 | 2.2.2 | Thermal |  | 40d | 2002-04-01 A | 2002-05-24 A | 5FS-40d | 100% | 2002-04-01 | 2002-05-24 | 40d |  |  |  |  |  | STEREO | IMPACT | SEP Package | SEPT | SEPT |  |  |
| 50 | 2.3 | **Bread Board** |  | 168d | 2002-01-02 A | 2002-08-29 A |  | 100% | 2002-01-02 | 2002-08-29 | 168d |  |  |  | 1680h | 1680h | STEREO | IMPACT | SEP Package | SEPT | SEPT | Bread Board |  |
| 51 | 2.3.1 | KTH Kick-off | milestone | 0d | 2002-01-10 A | 2002-01-10 A |  | 100% | 2002-01-10 | 2002-01-10 | 0d | start no earlier than 2002-01-10 | Standard w/ Dutch Holidays | KTH |  |  | STEREO | IMPACT | SEP Package | SEPT | SEPT |  | ESTEC |
| 52 | 2.3.2 | KTH testing contract Phase 1 |  | 90d | 2002-01-10 A | 2002-05-15 A | 51 | 100% | 2002-01-10 | 2002-05-15 | 90d | finish no earlier than 2002-05-15 | Standard w/ Dutch Holidays | KTH | 720h | 720h | STEREO | IMPACT | SEP Package | SEPT | SEPT |  | ESTEC |
| 53 | 2.3.3 | EGSE development, Rev. 0 |  | 108d | 2002-01-02 A | 2002-05-31 A |  | 100% | 2002-01-02 | 2002-05-31 | 108d | start no earlier than 2002-01-02 | Standard w/ Dutch Holidays | Smit | 864h | 864h | STEREO | IMPACT | SEP Package | SEPT | SEPT |  | ESTEC |
| 54 | 2.3.4 | SSD detector test |  | 4d | 2002-08-26 A | 2002-08-29 A |  | 100% | 2002-08-26 | 2002-08-29 | 4d | start no earlier than 2002-08-26 | Standard w/ Dutch Holidays | ESTEC; Kiel; KTH | 96h | 96h | STEREO | IMPACT | SEP Package | SEPT | SEPT |  | ESTEC |
| 55 | 3 | **FPGA development** |  | 281d | 2002-04-08 A | 2003-05-05 A |  | 100% | 2002-04-08 | 2003-05-05 | 281d |  | Standard w/ Dutch Holidays |  | 1744h | 1744h | STEREO | IMPACT | SEP Package | SEPT | SEPT | FPGA | ESTEC |
| 56 | 3.1 | FPGA Kick-off |  | 1d | 2002-04-08 A | 2002-04-08 A |  | 100% | 2002-04-08 | 2002-04-08 | 1d | start no earlier than 2002-04-08 | Standard w/ Dutch Holidays | Sandi; PF | 16h | 16h | STEREO | IMPACT | SEP Package | SEPT | SEPT |  | ESTEC |
| 57 | 3.2 | **ETU** |  | 41d | 2002-04-09 A | 2002-06-04 A |  | 100% | 2002-04-09 | 2002-06-04 | 41d |  | Standard w/ Dutch Holidays |  | 328h | 328h | STEREO | IMPACT | SEP Package | SEPT | SEPT |  | ESTEC |
| 58 | 3.2.1 | FPGA prototype Rev. 1 |  | 39d | 2002-04-09 A | 2002-05-31 A | 56, 122 | 100% | 2002-04-09 | 2002-05-31 | 39d | start no earlier than 2002-04-09 | Standard w/ Dutch Holidays | Sandi | 312h | 312h | STEREO | IMPACT | SEP Package | SEPT | SEPT |  | ESTEC |
| 59 | 3.2.2 | FPGA programming Rev. 1 |  | 2d | 2002-06-03 A | 2002-06-04 A | 58 | 100% | 2002-06-03 | 2002-06-04 | 2d | start no earlier than 2002-06-03 | Standard w/ Dutch Holidays | TOS-ESM | 16h | 16h | STEREO | IMPACT | SEP Package | SEPT | SEPT |  | ESTEC |
| 60 | 3.3 | **FM 1 & FM 2** |  | 232d | 2002-06-03 A | 2003-05-05 A |  | 100% | 2002-06-03 | 2003-05-05 | 232d |  |  |  | 1400h | 1400h | STEREO | IMPACT | SEP Package | SEPT | SEPT |  | ESTEC |
| 61 | 3.3.1 | FPGA development Rev. FM |  | 173d | 2002-06-03 A | 2003-05-01 A | 59 | 100% | 2002-06-03 | 2003-05-01 | 173d | start no earlier than 2002-06-03 | Standard w/ Dutch Holidays | Sandi | 1384h | 1384h | STEREO | IMPACT | SEP Package | SEPT | SEPT |  | ESTEC |
| 62 | 3.3.2 | FPGA programming Rev. FM |  | 2d | 2003-05-02 A | 2003-05-05 A | 61 | 100% | 2003-05-02 | 2003-05-05 | 2d | start no earlier than 2002-09-30 | Standard w/ Dutch Holidays | TOS-ESM | 16h | 16h | STEREO | IMPACT | SEP Package | SEPT | SEPT |  | ESTEC |
| 63 | 4 | **Radiation Testing COTS** |  | 260d | 2002-04-08 A | 2003-04-18 A |  | 100% | 2002-04-08 | 2003-02-20 | 219d |  |  |  | 2448h | 2448h | STEREO | IMPACT | SEP Package | SEPT | SEPT | Radiation | ESTEC |
| 64 | 4.1 | Parts final selection for testing |  | 55d | 2002-04-08 A | 2002-06-21 A |  | 100% | 2002-04-08 | 2002-06-21 | 55d | start no earlier than 2002-04-08 | Standard w/ Dutch Holidays | PF | 440h | 440h | STEREO | IMPACT | SEP Package | SEPT | SEPT |  | ESTEC |
| 65 | 4.2 | Design Radiation Test Board(s) |  | 36d | 2002-07-15 A | 2002-09-02 A | 64 | 100% | 2002-07-15 | 2002-09-02 | 36d | finish no earlier than 2002-09-20 | Standard w/ Dutch Holidays | DK; JH | 576h | 576h | STEREO | IMPACT | SEP Package | SEPT | SEPT |  | ESTEC |
| 66 | 4.3 | COTS Radiation Test Co-60 |  | 3d | 2002-11-21 A | 2002-11-25 A | 65 | 100% | 2002-11-21 | 2002-11-25 | 3d | start no earlier than 2002-11-30 | Standard w/ Dutch Holidays | DK; LD | 48h | 48h | STEREO | IMPACT | SEP Package | SEPT | SEPT |  | ESTEC |
| 67 | 4.4 | Proton test preperation |  | 50d | 2002-11-26 A | 2003-04-01 A | 66 | 100% | 2002-11-26 | 2003-02-03 | 50d |  | Standard w/ Dutch Holidays | DK; BJ; LD | 1200h | 1200h | STEREO | IMPACT | SEP Package | SEPT | SEPT |  | ESTEC |
| 68 | 4.5 | COTS Heavy Ion test Californium |  | 3d | 2003-04-02 A | 2003-04-04 A | 67 | 100% | 2003-02-04 | 2003-02-06 | 3d | start no earlier than 2003-03-31 | Standard w/ Dutch Holidays | ESTEC | 24h | 24h | STEREO | IMPACT | SEP Package | SEPT | SEPT |  | ESTEC |
| 69 | 4.6 | Heavy Ion testing Lauven LA Neuf (Be) |  | 10d | 2003-04-07 A | 2003-04-18 A | 68 | 100% | 2003-02-07 | 2003-02-20 | 10d | start no earlier than 2003-03-31 | Standard w/ Dutch Holidays | DK; LD | 160h | 160h | STEREO | IMPACT | SEP Package | SEPT | SEPT |  | ESTEC |

| ID | WBS | Task | Type | Duration | Start | Finish | Predecessors | Complete | Remaining | Baseline start | Baseline finish | Baseline duration | Total slack | Free slack | Constraint | Calendar | Resources | Work | Actual work | Text1 | Text11 | Text12 | Text13 | Text14 | Text16 | Text28 | Text23 | Text19 |
| --- | --- | --- | --- | --- | --- | --- | --- | --- | --- | --- | --- | --- | --- | --- | --- | --- | --- | --- | --- | --- | --- | --- | --- | --- | --- | --- | --- | --- |
| 70 | 5 | **PDFE ASIC development** |  | 189d | 2002-11-01 A | 2003-07-23 |  | 67% | 61.76d | 2002-11-01 | 2003-06-23 | 167d | -7d | 0d |  | Standard w/ Dutch Holidays |  | 1464h | 1064h | PDFE | STEREO | IMPACT | SEP Package | SEPT | SEPT | ESTEC |  |  |
| 71 | 5.1 | new contract with IMEC |  | 18d | 2003-01-07 A | 2003-01-30 A |  | 100% |  | 2003-01-07 | 2003-02-04 | 20d |  |  | start no earlier than 2002-11-30 | Standard w/ Dutch Holidays | BJ | 144h | 144h |  | STEREO | IMPACT | SEP Package | SEPT | SEPT | ESTEC |  |  |
| 72 | 5.2 | PDFE ASIC Specification & Change Definition |  | 15d | 2002-11-01 A | 2002-11-21 A |  | 100% |  | 2002-11-01 | 2002-11-21 | 15d |  |  | start no earlier than 2002-11-30 | Standard w/ Dutch Holidays | BJ; PF; LD | 360h | 360h |  | STEREO | IMPACT | SEP Package | SEPT | SEPT | ESTEC |  |  |
| 73 | 5.3 | Redesign of PDFE ASIC |  | 20d | 2002-11-22 A | 2002-12-19 A | 72 | 100% |  | 2002-11-22 | 2002-12-19 | 20d |  |  | start no earlier than 2002-11-30 | Standard w/ Dutch Holidays | IMEC | 160h | 160h |  | STEREO | IMPACT | SEP Package | SEPT | SEPT | ESTEC |  |  |
| 74 | 5.4 | PDFE ASIC Manufacturing |  | 50d | 2003-02-04 A | 2003-05-14 A | 73 | 100% |  | 2003-02-04 | 2003-04-14 | 50d |  |  | start no earlier than 2003-02-01 | Standard w/ Dutch Holidays | IMEC | 400h | 400h |  | STEREO | IMPACT | SEP Package | SEPT | SEPT | ESTEC | PDFE ASIC Manufacturing |  |
| 75 | 5.5 | PDFE ASIC Packaging |  | 35d | 2003-05-15 | 2003-07-02 | 74 |  |  | 2003-04-15 | 2003-06-02 | 35d | -7d | 0d | start no earlier than 2003-04-30 | Standard w/ Dutch Holidays | IMEC | 280h |  |  | STEREO | IMPACT | SEP Package | SEPT | SEPT | ESTEC | PDFE ASIC Packaging |  |
| 76 | 5.6 | PDFE ASIC Testing, Screening |  | 15d | 2003-07-03 | 2003-07-23 | 75 |  |  | 2003-06-03 | 2003-06-23 | 15d | -7d | 0d |  | Standard w/ Dutch Holidays | ESTEC | 120h |  |  | STEREO | IMPACT | SEP Package | SEPT | SEPT | ESTEC | PDFE ASIC Testing, Screening |  |
| 77 | 6 | **Power supply GSE development** |  | 60d | 2003-03-03 A | 2003-05-23 |  | 93% | 4.2d | 2003-02-03 | 2003-04-25 | 60d | 132d |  |  | Standard w/ Dutch Holidays |  | 737.6h | 658.08h |  | STEREO | IMPACT | SEP Package | SEPT | SEPT | ESTEC |  |  |
| 78 | 6.1 | Power supply GSE hardware/software definition |  | 10d | 2003-03-03 A | 2003-03-14 A |  | 100% |  | 2003-02-03 | 2003-02-14 | 10d |  |  | start no earlier than 2003-03-31 | Standard w/ Dutch Holidays | DK; LD; Smit | 240h | 240h |  | STEREO | IMPACT | SEP Package | SEPT | SEPT | ESTEC |  |  |
| 79 | 6.2 | Power supply software control development |  | 11d | 2003-03-17 A | 2003-03-31 A | 78 | 100% |  | 2003-02-17 | 2003-04-11 | 40d |  |  | start no earlier than 2003-03-31 | Standard w/ Dutch Holidays | Smit [20%] | 17.6h | 17.6h |  | STEREO | IMPACT | SEP Package | SEPT | SEPT | ESTEC |  |  |
| 80 | 6.3 | Power supply hardware manufacture |  | 40d | 2003-03-17 A | 2003-05-09 A | 78 | 100% |  | 2003-02-17 | 2003-04-11 | 40d |  |  |  | Standard w/ Dutch Holidays | TBD | 320h | 320h |  | STEREO | IMPACT | SEP Package | SEPT | SEPT | ESTEC |  |  |
| 81 | 6.4 | Power supply hardware delivery to ESTEC | milestone | 0d | 2003-05-09 A | 2003-05-09 A | 80 | 100% |  | 2003-04-11 | 2003-04-11 | 0d |  |  |  | Standard w/ Dutch Holidays |  |  |  |  | STEREO | IMPACT | SEP Package | SEPT | SEPT | ESTEC |  |  |
| 82 | 6.5 | Power supply testing |  | 10d | 2003-05-12 A | 2003-05-23 | 81 | 50% | 4.97d | 2003-04-14 | 2003-04-25 | 10d | 132d |  | finish no earlier than 2002-12-20 | Standard w/ Dutch Holidays | DK; Smit | 160h | 80.48h |  | STEREO | IMPACT | SEP Package | SEPT | SEPT | ESTEC | Power supply testing |  |
| 83 | 7 | **Mechanical** |  | 693d | 2001-01-02 A | 2003-10-02 |  | 68% | 218.66d | 2001-01-02 | 2003-10-09 | 697d | 36d |  |  |  |  |  |  |  | STEREO | IMPACT | SEP Package | SEPT | SEPT |  |  |  |
| 84 | 7.1 | **Design, Manufacture, Assembly and Test** |  | 693d | 2001-01-02 A | 2003-10-02 |  | 68% | 218.66d | 2001-01-02 | 2003-10-09 | 697d | 36d |  |  |  |  |  |  |  | STEREO | IMPACT | SEP Package | SEPT | SEPT |  |  |  |
| 85 | 7.1.1 | **Procurements** |  | 557d | 2001-03-01 A | 2003-05-16 |  | 97% | 15.95d | 2001-03-01 | 2003-03-27 | 521d | 132d |  |  |  |  |  |  |  | STEREO | IMPACT | SEP Package | SEPT | SEPT |  |  |  |
| 86 | 7.1.1.1 | SEPT Mechanical Long Lead Procurements |  | 418d | 2001-03-01 A | 2003-05-16 |  | 97% | 12d | 2001-03-01 | 2003-03-27 | 418d | 132d |  |  |  |  |  |  |  | STEREO | IMPACT | SEP Package | SEPT | SEPT | KIEL | SEPT Mechanical Long Lead Procurements |  |
| 87 | 7.1.1.2 | Procure SEPT Solid State Detectors |  | 1d | 2003-03-03 A | 2003-03-03 A |  | 100% |  | 2003-02-28 | 2003-02-28 | 1d |  |  | start no earlier than 2003-02-28 | Standard w/ Dutch Holidays |  |  |  |  | STEREO | IMPACT | SEP Package | SEPT | SEPT | ESTEC | Procure SEPT Solid State Detectors |  |
| 88 | 7.1.2 | **Design** |  | 627d | 2001-01-02 A | 2003-06-30 |  | 96% | 25.57d | 2001-01-02 | 2003-03-04 | 544d | 69d |  |  |  |  |  |  |  | STEREO | IMPACT | SEP Package | SEPT | SEPT |  |  |  |
| 89 | 7.1.2.1 | Design SEPT N-S Brackets |  | 21d | 2003-06-02 | 2003-06-30 | 46FS+205d |  |  | 2003-02-03 | 2003-03-04 | 21d | 70d | 0d | start no earlier than 2003-05-31 |  |  |  |  |  | STEREO | IMPACT | SEP Package | SEPT | SEPT | GSFC |  | Sandy Shuman |
| 90 | 7.1.2.2 | SEPT Sensor and E-Box Housing Design |  | 494d | 2001-01-02 A | 2002-12-03 A |  | 100% |  | 2001-01-02 | 2002-12-03 | 494d |  |  | start no earlier than 2001-01-01 | Standard w/ German Holidays |  |  |  |  | STEREO | IMPACT | SEP Package | SEPT | SEPT | KIEL |  |  |
| 91 | 7.1.3 | **Fabrication** |  | 258d | 2002-08-26 A | 2003-09-04 |  | 38% | 160.94d | 2002-08-26 | 2003-09-10 | 262d | 54d |  |  |  |  |  |  |  | STEREO | IMPACT | SEP Package | SEPT | SEPT |  |  |  |
| 92 | 7.1.3.1 | **ETU** |  | 106d | 2002-08-26 A | 2003-01-29 A |  | 100% |  | 2002-08-26 | 2003-02-12 | 116d |  |  |  |  |  |  |  |  | STEREO | IMPACT | SEP Package | SEPT | SEPT |  |  |  |
| 93 | 7.1.3.1.1 | Fabricate SEPT ETU Sensor and E-Box Housing |  | 42d | 2002-08-26 A | 2003-01-29 A | 48, 49, 122 | 100% |  | 2002-08-26 | 2003-02-12 | 50d |  |  |  | Standard w/ German Holidays |  |  |  |  | STEREO | IMPACT | SEP Package | SEPT | SEPT | KIEL |  |  |

| ID | WBS | Task | Type | Duration | Start | Finish | Predecessors | Complete | Remaining | Baseline start | Baseline finish | Baseline duration | Total slack | Free slack | Constraint | Calendar | Text11 | Text12 | Text13 | Text14 | Text16 | Text17 | Text19 | Text23 | Text28 |
| --- | --- | --- | --- | --- | --- | --- | --- | --- | --- | --- | --- | --- | --- | --- | --- | --- | --- | --- | --- | --- | --- | --- | --- | --- | --- |
| 94 | 7.1.3.2 | **FM 1 & FM 2** |  | 131d | 2003-03-03 A | 2003-09-04 |  | 33% | 87.9d | 2003-02-24 | 2003-09-10 | 140d | 54d |  |  |  | STEREO | IMPACT | SEP Package | SEPT | SEPT |  |  |  |  |
| 95 | 7.1.3.2.1 | **FM 1** |  | 116d | 2003-03-03 A | 2003-08-13 |  | 51% | 56.84d | 2003-02-24 | 2003-08-01 | 113d | 69d |  |  |  | STEREO | IMPACT | SEP Package | SEPT | SEPT |  |  |  |  |
| 96 | 1.1.13 | Instrument CDR | milestone | 3d | 2002-11-20 A | 2002-11-22 A |  | 100% |  | 2002-11-20 | 2002-11-22 | 3d |  |  | finish no earlier than 2002-11-22 |  | STEREO | IMPACT | SEP Package | SEPT | SEPT | SEPT |  |  |  |
| 97 | 7.1.3.2.1.2 | Fabricate SEPT-NS FM 1 N-S Brackets |  | 31d | 2003-07-01 | 2003-08-13 | 89, 96 |  |  | 2003-03-05 | 2003-04-16 | 31d | 70d | 0d | start no earlier than 2003-04-30 |  | STEREO | IMPACT | SEP Package | SEPT | SEPT |  | Sandy Shuman | Fabricate SEPT-NS FM 1 N-S Brackets | GSFC |
| 98 | 7.1.3.2.1.3 | Fabricate SEPT-NS FM 1 Sensor and E-Box Housing |  | 110d | 2003-03-03 A | 2003-08-05 |  | 58% | 46d |  |  |  | 2d | 0d | start no earlier than 2003-03-03 |  | STEREO | IMPACT | SEP Package | SEPT | SEPT |  |  |  |  |
| 99 | 7.1.3.2.1.4 | Fabricate SEPT-E FM 1 Sensor and E-Box Housing |  | 110d | 2003-03-03 A | 2003-08-05 |  | 58% | 46d |  |  |  | 2d | 0d | start no earlier than 2003-03-03 |  | STEREO | IMPACT | SEP Package | SEPT | SEPT |  |  |  |  |
| 100 | 7.1.3.2.2 | **FM 2** |  | 131d | 2003-03-03 A | 2003-09-04 |  | 18% | 108.04d | 2003-02-24 | 2003-08-01 | 113d | 54d |  |  |  | STEREO | IMPACT | SEP Package | SEPT | SEPT |  |  |  |  |
| 101 | 7.1.3.2.2.1 | Fabricate SEPT-NS FM 2 N-S Brackets |  | 31d | 2003-07-01 | 2003-08-13 | 89, 96 |  |  | 2003-03-05 | 2003-04-16 | 31d | 69d | 0d | start no earlier than 2003-04-30 |  | STEREO | IMPACT | SEP Package | SEPT | SEPT |  | Sandy Shuman | Fabricate SEPT-NS FM 2 N-S Brackets | GSFC |
| 102 | 7.1.3.2.2.2 | Fabricate SEPT-NS FM 2 Sensor and E-Box Housing |  | 110d | 2003-03-03 A | 2003-09-04 |  | 20% | 88d | 2003-02-24 | 2003-08-01 | 110d | -1d | 0d | start no earlier than 2003-03-01 | Standard w/ German Holidays | STEREO | IMPACT | SEP Package | SEPT | SEPT |  |  | Fabricate SEPT-NS FM 2 Sensor and E-Box Housing | KIEL |
| 103 | 7.1.3.2.2.3 | Fabricate SEPT-E FM 2 Sensor and E-Box Housing |  | 110d | 2003-03-03 A | 2003-09-04 |  | 20% | 88d | 2003-02-24 | 2003-08-01 | 110d | -1d | 0d | start no earlier than 2003-03-01 | Standard w/ German Holidays | STEREO | IMPACT | SEP Package | SEPT | SEPT |  |  | Fabricate SEPT-E FM 2 Sensor and E-Box Housing | KIEL |
| 104 | 7.1.3.2.3 | **Spare** |  | 53d | 2003-05-15 A | 2003-07-30 |  | 20% | 42.4d | 2003-06-30 | 2003-09-10 | 51d | 62d |  |  |  | STEREO | IMPACT | SEP Package | SEPT | SEPT |  |  |  |  |
| 105 | 7.1.3.2.3.1 | Fabricate SEPT Spare Sensor and E-Box Housing |  | 53d | 2003-05-15 A | 2003-07-30 |  | 20% | 42.4d | 2003-06-30 | 2003-09-10 | 53d | 63d | 0d |  | Standard w/ German Holidays | STEREO | IMPACT | SEP Package | SEPT | SEPT |  |  |  | KIEL |
| 106 | 7.1.4 | **Assembly** |  | 150d | 2003-03-04 A | 2003-10-02 |  | 26% | 110.8d | 2003-03-03 | 2003-10-09 | 155d | 36d |  |  |  | STEREO | IMPACT | SEP Package | SEPT | SEPT |  |  |  |  |
| 107 | 7.1.4.1 | **ETU** |  | 120.6d | 2003-03-04 A | 2003-08-21 |  | 61% | 47.61d | 2003-03-03 | 2003-04-17 | 34d | 61.4d |  |  |  | STEREO | IMPACT | SEP Package | SEPT | SEPT |  |  |  |  |
| 108 | 7.1.4.1.1 | Receive & Inspection of SEPT Solid State Detectors |  | 18d | 2003-05-01 | 2003-08-21 | 87 |  |  | 2003-03-03 | 2003-03-20 | 14d | 59.4d | 0d | start no earlier than 2003-04-30 | Standard w/ Dutch Holidays | STEREO | IMPACT | SEP Package | SEPT | SEPT |  |  |  | ESTEC |
| 109 | 7.1.4.1.2 | Receive & Inspection of SEPT Solid State Detectors |  | 18d | 2003-03-04 A | 2003-05-06 | 87 | 78% | 4d |  |  |  | 136d | 0d |  |  | STEREO | IMPACT | SEP Package | SEPT | SEPT |  |  |  |  |
| 110 | 7.1.4.1.3 | Assemble SEPT ETU Sensor and E-Box Housing |  | 20d | 2003-03-21 A | 2003-08-19 | 93, 108FF-2d, 109FF-2d | 80% | 4d | 2003-03-21 | 2003-04-17 | 20d | 63.4d | 0d |  | Standard w/ German Holidays | STEREO | IMPACT | SEP Package | SEPT | SEPT |  |  | Assemble SEPT ETU Sensor and E-Box Housing | KIEL |
| 111 | 7.1.4.1.4 | Assemble SEPT ETU Sensor and E-Box Housing |  | 20d | 2003-03-21 A | 2003-08-08 | 93, 108FF-9d, 109FF-9d | 80% | 4d |  |  |  | 68.4d | 0d |  |  | STEREO | IMPACT | SEP Package | SEPT | SEPT |  |  |  |  |
| 112 | 7.1.4.2 | **FM 1** |  | 19d | 2003-08-06 | 2003-09-02 |  |  |  | 2003-08-04 | 2003-08-29 | 20d | 2d |  |  |  | STEREO | IMPACT | SEP Package | SEPT | SEPT |  |  |  |  |
| 113 | 7.1.4.2.1 | Assemble SEPT-NS FM 1 Sensor and E-Box Housing |  | 20d | 2003-08-06 | 2003-09-02 | 98 |  |  | 2003-08-04 | 2003-08-29 | 20d | 2d | 0d |  | Standard w/ German Holidays | STEREO | IMPACT | SEP Package | SEPT | SEPT |  |  | Assemble SEPT-NS FM 1 Sensor and E-Box Housing | KIEL |
| 114 | 7.1.4.2.2 | Assemble SEPT-E FM 1 Sensor and E-Box Housing |  | 20d | 2003-08-06 | 2003-09-02 | 99 |  |  | 2003-08-04 | 2003-08-29 | 20d | 2d |  |  | Standard w/ German Holidays | STEREO | IMPACT | SEP Package | SEPT | SEPT |  |  | Assemble SEPT-E FM 1 Sensor and E-Box Housing | KIEL |
| 115 | 7.1.4.3 | **FM 2** |  | 20d | 2003-09-05 | 2003-10-02 |  |  |  | 2003-08-04 | 2003-08-29 | 20d | -1d | 0d |  |  | STEREO | IMPACT | SEP Package | SEPT | SEPT |  |  |  |  |
| 116 | 7.1.4.3.1 | Assemble SEPT-NS FM 2 Sensor and E-Box Housing |  | 20d | 2003-09-05 | 2003-10-02 | 102 |  |  | 2003-08-04 | 2003-08-29 | 20d | -1d | 0d |  | Standard w/ German Holidays | STEREO | IMPACT | SEP Package | SEPT | SEPT |  |  | Assemble SEPT-NS FM 2 Sensor and E-Box Housing | KIEL |
| 117 | 7.1.4.3.2 | Assemble SEPT-E FM 2 Sensor and E-Box Housing |  | 20d | 2003-09-05 | 2003-10-02 | 103 |  |  | 2003-08-04 | 2003-08-29 | 20d | -1d | 0d |  | Standard w/ German Holidays | STEREO | IMPACT | SEP Package | SEPT | SEPT |  |  | Assemble SEPT-E FM 2 Sensor and E-Box Housing | KIEL |

| ID | WBS | Task | Duration | Start | Finish | Predecessors | Complete | Remaining | Baseline start | Baseline finish | Baseline duration | Total slack | Free slack | Constraint | Calendar | Text11 | Text12 | Text13 | Text14 | Text16 | Text28 | Text23 |
| --- | --- | --- | --- | --- | --- | --- | --- | --- | --- | --- | --- | --- | --- | --- | --- | --- | --- | --- | --- | --- | --- | --- |
| 118 | 7.1.4.4 | **Spare** | 20d | 2003-07-31 | 2003-08-27 |  |  |  | 2003-09-11 | 2003-10-09 | 20d | 61d |  |  |  | STEREO | IMPACT | SEP Package | SEPT | SEPT |  |  |
| 119 | 7.1.4.4.1 | Assemble SEPT Spare Sensor and E-Box Housing | 20d | 2003-07-31 | 2003-08-27 | 105 |  |  | 2003-09-11 | 2003-10-09 | 20d | 63d |  | start no earlier than 2002-08-31 | Standard w/ German Holidays | STEREO | IMPACT | SEP Package | SEPT | SEPT | KIEL |  |
| 120 | 7.1.5 | **Test** | 342.6d | 2002-04-15 A | 2003-08-22 |  | 42% | 199.85d | 2002-04-15 | 2003-04-24 | 259d | 64.4d |  |  |  | STEREO | IMPACT | SEP Package | SEPT | SEPT |  |  |
| 121 | 7.1.5.1 | **ETU** | 342.6d | 2002-04-15 A | 2003-08-22 |  | 63% | 128.47d | 2002-04-15 | 2003-04-24 | 259d | 64.4d |  |  |  | STEREO | IMPACT | SEP Package | SEPT | SEPT |  |  |
| 122 | 7.1.5.1.1 | Magnetic Stray Field Test, only Magnet | 5d | 2002-04-15 A | 2002-04-19 A |  | 100% |  | 2002-04-15 | 2002-04-19 | 5d |  |  | start no earlier than 2002-04-15 |  | STEREO | IMPACT | SEP Package | SEPT | SEPT |  |  |
| 123 | 7.1.5.1.2 | Acoustics Test, only Sensor | 3d | 2003-08-19 | 2003-08-22 | 110, 111 |  |  | 2003-04-22 | 2003-04-24 | 3d | 66.4d |  | start no earlier than 2003-04-30 | Standard w/ German Holidays | STEREO | IMPACT | SEP Package | SEPT | SEPT | KIEL | ETU Tested |
| 124 | 7.1.5.2 | **FM 1** | 2d | 2003-08-14 | 2003-08-15 |  |  |  | 2003-04-17 | 2003-04-18 | 2d | 69d |  |  |  | STEREO | IMPACT | SEP Package | SEPT | SEPT |  |  |
| 125 | 7.1.5.2.1 | Vibrate FM 1 N-S Bracket | 2d | 2003-08-14 | 2003-08-15 | 97 |  |  | 2003-04-17 | 2003-04-18 | 2d | 69d | 0d |  |  | STEREO | IMPACT | SEP Package | SEPT | SEPT | GSFC |  |
| 126 | 7.1.5.3 | **FM 2** | 2d | 2003-08-14 | 2003-08-15 |  |  |  | 2003-04-17 | 2003-04-18 | 2d | 69d |  |  |  | STEREO | IMPACT | SEP Package | SEPT | SEPT |  |  |
| 127 | 7.1.5.3.1 | Vibrate FM 2 N-S Bracket | 2d | 2003-08-14 | 2003-08-15 | 101 |  |  | 2003-04-17 | 2003-04-18 | 2d | 69d | 0d |  |  | STEREO | IMPACT | SEP Package | SEPT | SEPT | GSFC |  |
| 128 | 8 | **Electronics** | 700d | 2001-01-02 A | 2003-10-14 |  | 75% | 177.43d | 2001-01-02 | 2003-09-11 | 678d | 29d |  |  |  | STEREO | IMPACT | SEP Package | SEPT | SEPT |  |  |
| 129 | 8.1 | **Design, Manufacture, Assembly and Test** | 700d | 2001-01-02 A | 2003-10-14 |  | 75% | 177.43d | 2001-01-02 | 2003-09-11 | 678d | 29d |  |  |  | STEREO | IMPACT | SEP Package | SEPT | SEPT |  |  |
| 130 | 8.1.1 | **Procurements** | 549d | 2001-03-01 A | 2003-05-06 |  | 99% | 6.99d | 2001-03-01 | 2003-02-06 | 487d | 140d |  |  |  | STEREO | IMPACT | SEP Package | SEPT | SEPT |  |  |
| 131 | 8.1.1.1 | Electronic Long Lead Procurements | 314d | 2001-03-01 A | 2003-05-06 |  | 99% | 4d | 2001-03-01 | 2003-02-06 | 314d | 145d |  | start no earlier than 2001-03-01 | Standard w/ Dutch Holidays | STEREO | IMPACT | SEP Package | SEPT | SEPT | ESTEC | Electronic Long Lead Procurements |
| 132 | 8.1.2 | **Design** | 560d | 2001-01-02 A | 2003-03-26 A |  | 100% |  | 2001-01-02 | 2003-03-26 | 560d |  |  |  |  | STEREO | IMPACT | SEP Package | SEPT | SEPT |  |  |
| 133 | 8.1.2.1 | SEPT Electronics Design | 364d | 2001-01-02 A | 2002-05-24 A |  | 100% |  | 2001-01-02 | 2002-05-24 | 364d |  |  | start no earlier than 2001-01-01 | Standard w/ Dutch Holidays | STEREO | IMPACT | SEP Package | SEPT | SEPT | ESTEC |  |
| 134 | 8.1.2.2 | **ETU** | 81d | 2002-08-21 A | 2002-12-17 A |  | 100% |  | 2002-08-21 | 2002-12-17 | 81d |  |  |  |  | STEREO | IMPACT | SEP Package | SEPT | SEPT |  |  |
| 135 | 8.1.2.2.1 | SEPT ETU Schematics Update | 8d | 2002-08-21 A | 2002-08-30 A |  | 100% |  | 2002-08-21 | 2002-08-30 | 8d |  |  | start no earlier than 2002-08-21 | Standard w/ Dutch Holidays | STEREO | IMPACT | SEP Package | SEPT | SEPT | ESTEC |  |
| 136 | 8.1.2.2.2 | SEPT ETU Layout Update DB,AB,EMCB | 16d | 2002-11-26 A | 2002-12-17 A | 135FS+4d | 100% |  | 2002-11-26 | 2002-12-17 | 16d |  |  | start no earlier than 2003-02-01 | Standard w/ Dutch Holidays | STEREO | IMPACT | SEP Package | SEPT | SEPT | ESTEC |  |
| 137 | 8.1.2.3 | **FM 1 & FM 2** | 56d | 2003-01-06 A | 2003-03-26 A |  | 100% |  | 2003-01-06 | 2003-03-26 | 56d |  |  |  |  | STEREO | IMPACT | SEP Package | SEPT | SEPT |  |  |
| 138 | 8.1.2.3.1 | SEPT Flight Schematics Update | 29d | 2003-01-06 A | 2003-02-13 A |  | 100% |  | 2003-01-06 | 2003-02-13 | 29d |  |  |  | Standard w/ Dutch Holidays | STEREO | IMPACT | SEP Package | SEPT | SEPT | ESTEC |  |
| 139 | 8.1.2.3.2 | SEPT Flight Layout Update DB,AB,EMCB | 29d | 2003-02-14 A | 2003-03-26 A | 138 | 100% |  | 2003-02-14 | 2003-03-26 | 29d |  |  |  | Standard w/ Dutch Holidays | STEREO | IMPACT | SEP Package | SEPT | SEPT | ESTEC |  |
| 140 | 8.1.3 | **Fabrication** | 76.5d | 2003-01-30 A | 2003-05-19 A |  | 100% |  | 2003-01-30 | 2003-05-02 | 66d |  |  |  |  | STEREO | IMPACT | SEP Package | SEPT | SEPT |  |  |
| 141 | 8.1.3.1 | **ETU** | 30d | 2003-01-30 A | 2003-03-13 A |  | 100% |  | 2003-01-30 | 2003-03-13 | 30d |  |  |  |  | STEREO | IMPACT | SEP Package | SEPT | SEPT |  |  |
| 142 | 8.1.3.1.1 | Fabricate SEPT ETU Electronics Board | 31d | 2003-01-30 A | 2003-03-13 A | 48, 49, 136 | 100% |  | 2003-01-30 | 2003-03-13 | 31d |  |  |  | Standard w/ Dutch Holidays | STEREO | IMPACT | SEP Package | SEPT | SEPT | ESTEC | Fabricate SEPT ETU Electronics Board |

Notes:
- 123: This activity was deleted in the schedule received from Europe on 9/9/02

| ID | WBS | Task | Duration | Start | Finish | Predecessors | Complete | Remaining | Baseline start | Baseline finish | Baseline duration | Total slack | Free slack | Constraint | Calendar | Text11 | Text12 | Text13 | Text14 | Text16 | Text23 | Text28 |
| --- | --- | --- | --- | --- | --- | --- | --- | --- | --- | --- | --- | --- | --- | --- | --- | --- | --- | --- | --- | --- | --- | --- |
| 143 | 8.1.3.2 | **FM 1 & FM 2** | 34.5d | 2003-04-01 A | 2003-05-19 A |  | 100% |  | 2003-03-31 | 2003-05-02 | 25d |  |  |  |  | STEREO | IMPACT | SEP Package | SEPT | SEPT |  |  |
| 144 | 8.1.3.2.1 | **FM 1** | 34.5d | 2003-04-01 A | 2003-05-19 A |  | 100% |  | 2003-03-31 | 2003-05-02 | 25d |  |  |  |  | STEREO | IMPACT | SEP Package | SEPT | SEPT |  |  |
| 145 | 8.1.3.2.1.1 | Fabricate SEPT-NS FM 1 Electronics Board | 25d | 2003-04-01 A | 2003-05-19 A | 139 | 100% |  | 2003-03-31 | 2003-05-02 | 25d |  |  | start no earlier than 2003-03-31 | Standard w/ Dutch Holidays | STEREO | IMPACT | SEP Package | SEPT | SEPT | Fabricate SEPT-NS FM 1 Electronics Board | ESTEC |
| 146 | 8.1.3.2.1.2 | Fabricate SEPT-E FM 1 Electronics Board | 25d | 2003-04-01 A | 2003-05-19 A | 139 | 100% |  | 2003-03-31 | 2003-05-02 | 25d |  |  | start no earlier than 2003-03-31 | Standard w/ Dutch Holidays | STEREO | IMPACT | SEP Package | SEPT | SEPT | Fabricate SEPT-E FM 1 Electronics Board | ESTEC |
| 147 | 8.1.3.2.2 | **FM 2** | 34.5d | 2003-04-01 A | 2003-05-19 A |  | 100% |  | 2003-03-31 | 2003-05-02 | 25d |  |  |  |  | STEREO | IMPACT | SEP Package | SEPT | SEPT |  |  |
| 148 | 8.1.3.2.2.1 | Fabricate SEPT-NS FM 2 Electronics Board | 25d | 2003-04-01 A | 2003-05-19 A | 139 | 100% |  | 2003-03-31 | 2003-05-02 | 25d |  |  | start no earlier than 2003-03-31 | Standard w/ Dutch Holidays | STEREO | IMPACT | SEP Package | SEPT | SEPT | Fabricate SEPT-NS FM 2 Electronics Board | ESTEC |
| 149 | 8.1.3.2.2.2 | Fabricate SEPT-E FM 2 Electronics Board | 25d | 2003-04-01 A | 2003-05-19 A | 139 | 100% |  | 2003-03-31 | 2003-05-02 | 25d |  |  | start no earlier than 2003-03-31 | Standard w/ Dutch Holidays | STEREO | IMPACT | SEP Package | SEPT | SEPT | Fabricate SEPT-E FM 2 Electronics Board | ESTEC |
| 150 | 8.1.3.2.3 | **Spare** | 34.5d | 2003-04-01 A | 2003-05-19 A |  | 100% |  | 2003-03-31 | 2003-05-02 | 25d |  |  |  |  | STEREO | IMPACT | SEP Package | SEPT | SEPT |  |  |
| 151 | 8.1.3.2.3.1 | Fabricate SEPT-NS FS Electronics Board | 25d | 2003-04-01 A | 2003-05-19 A | 139 | 100% |  | 2003-03-31 | 2003-05-02 | 25d |  |  | start no earlier than 2003-03-31 | Standard w/ Dutch Holidays | STEREO | IMPACT | SEP Package | SEPT | SEPT |  | ESTEC |
| 152 | 8.1.3.2.3.2 | Fabricate SEPT-E FS Electronics Board | 25d | 2003-04-01 A | 2003-05-19 A | 139 | 100% |  | 2003-03-31 | 2003-05-02 | 25d |  |  | start no earlier than 2003-03-31 | Standard w/ Dutch Holidays | STEREO | IMPACT | SEP Package | SEPT | SEPT |  | ESTEC |
| 153 | 8.1.4 | **Assmebly** | 115d | 2003-03-17 A | 2003-08-26 |  | 7% | 106.98d | 2003-03-17 | 2003-07-25 | 93d | 29d |  |  |  | STEREO | IMPACT | SEP Package | SEPT | SEPT |  |  |
| 154 | 8.1.4.1 | **ETU** | 9d | 2003-03-17 A | 2003-03-27 A |  | 100% |  | 2003-03-17 | 2003-03-27 | 9d |  |  |  |  | STEREO | IMPACT | SEP Package | SEPT | SEPT |  |  |
| 155 | 8.1.4.1.1 | Assemble SEPT ETU Electronics Board | 9d | 2003-03-17 A | 2003-03-27 A | 142FS+1d | 100% |  | 2003-03-17 | 2003-03-27 | 9d |  |  |  | Standard w/ Dutch Holidays | STEREO | IMPACT | SEP Package | SEPT | SEPT | Assemble SEPT ETU Electronics Board | ESTEC |
| 156 | 8.1.4.2 | **FM 1** | 41d | 2003-06-02 | 2003-07-29 |  |  |  | 2003-06-02 | 2003-06-27 | 20d | -7d | 0d |  |  | STEREO | IMPACT | SEP Package | SEPT | SEPT |  |  |
| 157 | 8.1.4.2.1 | Assemble SEPT-NS FM 1 Electronics | 20d | 2003-06-02 | 2003-06-27 | 145, 78FF+4d, 62 |  |  | 2003-06-02 | 2003-06-27 | 20d | 15d | 0d | start no earlier than 2003-06-02 | Standard w/ Dutch Holidays | STEREO | IMPACT | SEP Package | SEPT | SEPT | Assemble SEPT-NS FM 1 Electronics | ESTEC |
| 158 | 8.1.4.2.2 | Assemble SEPT-E FM 1 Electronics | 20d | 2003-07-02 | 2003-07-29 | 146, 76FF+4d |  |  | 2003-06-02 | 2003-06-27 | 20d | -7d | 0d | start no earlier than 2003-06-02 | Standard w/ Dutch Holidays | STEREO | IMPACT | SEP Package | SEPT | SEPT | Assemble SEPT-E FM 1 Electronics | ESTEC |
| 159 | 8.1.4.3 | **FM 2** | 19d | 2003-07-02 | 2003-07-29 |  |  |  | 2003-06-02 | 2003-06-27 | 20d | 11d |  |  |  | STEREO | IMPACT | SEP Package | SEPT | SEPT |  |  |
| 160 | 8.1.4.3.1 | Assemble SEPT-NS FM 2 Electronics | 20d | 2003-07-02 | 2003-07-29 | 148, 76FF+4d |  |  | 2003-06-02 | 2003-06-27 | 20d | 12d | 0d | start no earlier than 2003-06-02 | Standard w/ Dutch Holidays | STEREO | IMPACT | SEP Package | SEPT | SEPT | Assemble SEPT-NS FM 2 Electronics | ESTEC |
| 161 | 8.1.4.3.2 | Assemble SEPT-E FM 2 Electronics | 20d | 2003-07-02 | 2003-07-29 | 149, 76FF+4d |  |  | 2003-06-02 | 2003-06-27 | 20d | 12d | 0d |  | Standard w/ Dutch Holidays | STEREO | IMPACT | SEP Package | SEPT | SEPT | Assemble SEPT-E FM 2 Electronics | ESTEC |
| 162 | 8.1.4.4 | **SPARE** | 20d | 2003-07-30 | 2003-08-26 |  |  |  | 2003-06-30 | 2003-07-25 | 19d | 29d |  |  |  | STEREO | IMPACT | SEP Package | SEPT | SEPT |  |  |
| 163 | 8.1.4.4.1 | **SPARE** | 20d | 2003-07-30 | 2003-08-26 |  |  |  | 2003-06-30 | 2003-07-25 | 19d | 29d |  |  |  | STEREO | IMPACT | SEP Package | SEPT | SEPT |  |  |
| 164 | 8.1.4.4.1.1 | Assemble SEPT-NS FS Electronics | 20d | 2003-07-30 | 2003-08-26 | 151, 160 |  |  | 2003-06-30 | 2003-07-25 | 20d | 31d | 0d | start no earlier than 2003-06-30 | Standard w/ Dutch Holidays | STEREO | IMPACT | SEP Package | SEPT | SEPT |  | ESTEC |
| 165 | 8.1.4.4.1.2 | Assemble SEPT-E FS Electronics | 20d | 2003-07-30 | 2003-08-26 | 152, 161 |  |  | 2003-06-30 | 2003-07-25 | 20d | 31d | 0d | start no earlier than 2003-06-30 | Standard w/ Dutch Holidays | STEREO | IMPACT | SEP Package | SEPT | SEPT |  | ESTEC |
| 166 | 8.1.5 | **Test** | 140d | 2003-03-27 A | 2003-10-14 |  | 9% | 127.5d | 2003-03-28 | 2003-09-11 | 117d | 29d |  |  |  | STEREO | IMPACT | SEP Package | SEPT | SEPT |  |  |
| 167 | 8.1.5.1 | **ETU** | 21d | 2003-03-27 A | 2003-04-24 A |  | 100% |  | 2003-03-28 | 2003-04-24 | 20d |  |  |  |  | STEREO | IMPACT | SEP Package | SEPT | SEPT |  |  |
| 168 | 8.1.5.1.1 | SEPT ETU Electronics Test | 20d | 2003-03-27 A | 2003-04-24 A | 155 | 100% |  | 2003-03-28 | 2003-04-24 | 20d |  |  |  | Standard w/ Dutch Holidays | STEREO | IMPACT | SEP Package | SEPT | SEPT | SEPT ETU Electronics Test | ESTEC |

| ID | WBS | Task | Type | Duration | Start | Finish | Predecessors | Complete | Remaining | Baseline start | Baseline finish | Baseline duration | Total slack | Free slack | Calendar | Text11 | Text12 | Text13 | Text14 | Text16 | Text23 | Text28 |
| --- | --- | --- | --- | --- | --- | --- | --- | --- | --- | --- | --- | --- | --- | --- | --- | --- | --- | --- | --- | --- | --- | --- |
| 169 | 8.1.5.2 | **FM 1** |  | 54d | 2003-06-30 | 2003-09-15 |  |  |  | 2003-06-30 | 2003-08-14 | 33d | -7d | 0d |  | STEREO | IMPACT | SEP Package | SEPT | SEPT |  |  |
| 170 | 8.1.5.2.1 | SEPT-NS FM 1 Electronics Test |  | 20d | 2003-06-30 | 2003-07-25 | 157 |  |  | 2003-06-30 | 2003-07-25 | 20d | 15d | 0d | Standard w/ Dutch Holidays | STEREO | IMPACT | SEP Package | SEPT | SEPT | SEPT-NS FM 1 Electronics Test | ESTEC |
| 171 | 8.1.5.2.2 | SEPT-E FM 1 Electronics Test |  | 20d | 2003-07-30 | 2003-08-26 | 158 |  |  | 2003-06-30 | 2003-07-25 | 20d | -7d | 0d | Standard w/ Dutch Holidays | STEREO | IMPACT | SEP Package | SEPT | SEPT | SEPT-E FM 1 Electronics Test | ESTEC |
| 172 | 8.1.5.2.3 | Coat SEPT-NS FM 1 Electronics Board |  | 4d | 2003-07-28 | 2003-07-31 | 170 |  |  | 2003-07-28 | 2003-07-31 | 4d | 15d | 0d | Standard w/ Dutch Holidays | STEREO | IMPACT | SEP Package | SEPT | SEPT |  | ESTEC |
| 173 | 8.1.5.2.4 | Coat SEPT-E FM 1 Electronics Board |  | 4d | 2003-08-27 | 2003-09-01 | 171 |  |  | 2003-07-28 | 2003-07-31 | 4d | -7d | 0d | Standard w/ Dutch Holidays | STEREO | IMPACT | SEP Package | SEPT | SEPT |  | ESTEC |
| 174 | 8.1.5.2.5 | SEPT-NS FM 1 Mechanical Integration |  | 10d | 2003-08-01 | 2003-08-14 | 172 |  |  | 2003-08-01 | 2003-08-14 | 10d | 15d | 0d | Standard w/ German Holidays | STEREO | IMPACT | SEP Package | SEPT | SEPT | SEPT-NS FM 1 Mechanical Integration | KIEL |
| 175 | 8.1.5.2.6 | SEPT-E FM 1 Mechanical Integration |  | 10d | 2003-09-02 | 2003-09-15 | 173 |  |  | 2003-08-01 | 2003-08-14 | 10d | -7d | 0d | Standard w/ German Holidays | STEREO | IMPACT | SEP Package | SEPT | SEPT | SEPT-E FM 1 Mechanical Integration | KIEL |
| 176 | 8.1.5.3 | **FM 2** |  | 33d | 2003-07-30 | 2003-09-15 |  |  |  | 2003-06-30 | 2003-08-14 | 33d | 12d |  |  | STEREO | IMPACT | SEP Package | SEPT | SEPT |  |  |
| 177 | 8.1.5.3.1 | SEPT-NS FM 2 Electronics Test |  | 19d | 2003-07-30 | 2003-08-25 | 160 |  |  | 2003-06-30 | 2003-07-24 | 19d | 12d | 0d | Standard w/ Dutch Holidays | STEREO | IMPACT | SEP Package | SEPT | SEPT | SEPT-NS FM 2 Electronics Test | ESTEC |
| 178 | 8.1.5.3.2 | SEPT-E FM 2 Electronics Test |  | 19d | 2003-07-30 | 2003-08-25 | 161 |  |  | 2003-06-30 | 2003-07-24 | 19d | 12d | 0d | Standard w/ Dutch Holidays | STEREO | IMPACT | SEP Package | SEPT | SEPT | SEPT-E FM 2 Electronics Test | ESTEC |
| 179 | 8.1.5.3.3 | Coat SEPT-NS FM 2 Electronics Board |  | 5d | 2003-08-26 | 2003-09-01 | 177 |  |  | 2003-07-25 | 2003-07-31 | 5d | 12d | 0d | Standard w/ Dutch Holidays | STEREO | IMPACT | SEP Package | SEPT | SEPT |  | ESTEC |
| 180 | 8.1.5.3.4 | Coat SEPT-E FM 2 Electronics Board |  | 5d | 2003-08-26 | 2003-09-01 | 178 |  |  | 2003-07-25 | 2003-07-31 | 5d | 12d | 0d | Standard w/ Dutch Holidays | STEREO | IMPACT | SEP Package | SEPT | SEPT |  | ESTEC |
| 181 | 8.1.5.3.5 | SEPT-NS FM 2 Mechanical Integration |  | 10d | 2003-09-02 | 2003-09-15 | 179 |  |  | 2003-08-01 | 2003-08-14 | 10d | 12d | 0d | Standard w/ German Holidays | STEREO | IMPACT | SEP Package | SEPT | SEPT | SEPT-NS FM 2 Mechanical Integration | KIEL |
| 182 | 8.1.5.3.6 | SEPT-E FM 2 Mechanical Integration |  | 10d | 2003-09-02 | 2003-09-15 | 180 |  |  | 2003-08-01 | 2003-08-14 | 10d | 12d | 0d | Standard w/ German Holidays | STEREO | IMPACT | SEP Package | SEPT | SEPT | SEPT-E FM 2 Mechanical Integration | KIEL |
| 183 | 8.1.5.4 | **Spare** |  | 33d | 2003-08-27 | 2003-10-14 |  |  |  | 2003-07-28 | 2003-09-11 | 33d | 29d |  |  | STEREO | IMPACT | SEP Package | SEPT | SEPT |  |  |
| 184 | 8.1.5.4.1 | SEPT-NS Flight Spare Electronics Test |  | 20d | 2003-08-27 | 2003-09-23 | 164 |  |  | 2003-07-28 | 2003-08-22 | 20d | 31d | 0d | Standard w/ Dutch Holidays | STEREO | IMPACT | SEP Package | SEPT | SEPT |  | ESTEC |
| 185 | 8.1.5.4.2 | SEPT-E Flight Spare Electronics Test |  | 20d | 2003-08-27 | 2003-09-23 | 165 |  |  | 2003-07-28 | 2003-08-22 | 20d | 31d | 0d | Standard w/ Dutch Holidays | STEREO | IMPACT | SEP Package | SEPT | SEPT |  | ESTEC |
| 186 | 8.1.5.4.3 | Coat SEPT-NS FS Electronics Board |  | 5d | 2003-09-24 | 2003-09-30 | 184 |  |  | 2003-08-25 | 2003-08-29 | 5d | 31d | 0d | Standard w/ Dutch Holidays | STEREO | IMPACT | SEP Package | SEPT | SEPT |  | ESTEC |
| 187 | 8.1.5.4.4 | Coat SEPT-E FS Electronics Board |  | 5d | 2003-09-24 | 2003-09-30 | 185 |  |  | 2003-08-25 | 2003-08-29 | 5d | 31d | 0d | Standard w/ Dutch Holidays | STEREO | IMPACT | SEP Package | SEPT | SEPT |  | ESTEC |
| 188 | 8.1.5.4.5 | SEPT-NS FS Mechanical Integration |  | 9d | 2003-10-01 | 2003-10-14 | 186 |  |  | 2003-09-01 | 2003-09-11 | 9d | 30d | 0d | Standard w/ German Holidays | STEREO | IMPACT | SEP Package | SEPT | SEPT |  | KIEL |
| 189 | 8.1.5.4.6 | SEPT-E FS Mechanical Integration |  | 9d | 2003-10-01 | 2003-10-14 | 187 |  |  | 2003-09-01 | 2003-09-11 | 9d | 30d | 0d | Standard w/ German Holidays | STEREO | IMPACT | SEP Package | SEPT | SEPT |  | KIEL |
| 190 | 9 | **Integration & Test** |  | 133.4d | 2003-05-15 A | 2003-11-25 |  | 6% | 124.87d | 2003-04-28 | 2003-11-12 | 138d | 0d |  |  | STEREO | IMPACT | SEP Package | SEPT | SEPT |  |  |
| 191 | 9.1 | **ETU** |  | 72d | 2003-05-15 A | 2003-08-27 |  | 39% | 43.71d | 2003-04-28 | 2003-09-03 | 89.6d | 61.4d |  |  | STEREO | IMPACT | SEP Package | SEPT | SEPT |  |  |
| 192 | 9.1.1 | SEPT ETU Integration & Test | milestone | 17d | 2003-05-15 A | 2003-08-27 | 110, 13, 111 | 65% | 6d | 2003-04-28 | 2003-06-11 | 30d | 63.4d |  | Standard w/ German Holidays | STEREO | IMPACT | SEP Package | SEPT | SEPT | ETU I & T Complete | KIEL |
| 193 | 9.1.2 | Muon and Radioactive Source Test |  | 3d | 2003-07-03 | 2003-07-07 | 23 |  |  | 2003-08-19 | 2003-08-22 | 3d | 92d | 0d | Standard w/ German Holidays | STEREO | IMPACT | SEP Package | SEPT | SEPT |  | KIEL |
| 194 | 9.1.3 | Mechanical Function |  | 3d | 2003-07-08 | 2003-07-10 | 193 |  |  | 2003-08-22 | 2003-08-27 | 3d | 92d | 0d | Standard w/ German Holidays | STEREO | IMPACT | SEP Package | SEPT | SEPT |  | KIEL |
| 195 | 9.1.4 | Magnetic Deflection Test |  | 5d | 2003-07-11 | 2003-07-17 | 194 |  |  | 2003-08-27 | 2003-09-03 | 5d | 92d |  | Standard w/ German Holidays | STEREO | IMPACT | SEP Package | SEPT | SEPT | ETU Environmentally Tested | KIEL |

| ID | WBS | Task | Duration | Start | Finish | Predecessors | Baseline start | Baseline finish | Baseline duration | Total slack | Free slack | Calendar | Text11 | Text12 | Text13 | Text14 | Text16 | Text23 | Text28 |
| --- | --- | --- | --- | --- | --- | --- | --- | --- | --- | --- | --- | --- | --- | --- | --- | --- | --- | --- | --- |
| 196 | 9.2 | **FM 1** | 48d | 2003-09-03 | 2003-11-11 |  | 2003-09-01 | 2003-10-27 | 39d | -5d | 0d |  | STEREO | IMPACT | SEP Package | SEPT | SEPT |  |  |
| 197 | 9.2.1 | **SEPT-NS** | 40d | 2003-09-03 | 2003-10-29 |  | 2003-09-01 | 2003-10-27 | 39d | 2d |  |  | STEREO | IMPACT | SEP Package | SEPT | SEPT |  |  |
| 198 | 9.2.1.1 | SEPT-NS FM 1 Integration & Test | 20d | 2003-09-03 | 2003-09-30 | 113, 14 | 2003-09-01 | 2003-09-26 | 20d | 2d | 0d | Standard w/ German Holidays | STEREO | IMPACT | SEP Package | SEPT | SEPT | FM 1 NS I & T Complete | KIEL |
| 199 | 9.2.1.2 | Muon and Radioactive Source Test | 5d | 2003-10-01 | 2003-10-08 | 198 | 2003-09-29 | 2003-10-06 | 5d | 3d | 0d | Standard w/ German Holidays | STEREO | IMPACT | SEP Package | SEPT | SEPT |  | KIEL |
| 200 | 9.2.1.3 | SEPT-NS FM 1 Vibration | 5d | 2003-10-09 | 2003-10-15 | 199 | 2003-10-07 | 2003-10-13 | 5d | 3d | 0d | Standard w/ German Holidays | STEREO | IMPACT | SEP Package | SEPT | SEPT |  | KIEL |
| 201 | 9.2.1.4 | SEPT-NS FM 1 TV/TB | 10d | 2003-10-16 | 2003-10-29 | 200 | 2003-10-14 | 2003-10-27 | 10d | 3d | 0d | Standard w/ German Holidays | STEREO | IMPACT | SEP Package | SEPT | SEPT | FM 1 NS Environmentally Tested | KIEL |
| 202 | 9.2.2 | **SEPT-E** | 39d | 2003-09-16 | 2003-11-11 |  | 2003-09-01 | 2003-10-27 | 39d | -7d | 0d |  | STEREO | IMPACT | SEP Package | SEPT | SEPT |  |  |
| 203 | 9.2.2.1 | SEPT-E FM 1 Integration & Test | 20d | 2003-09-16 | 2003-10-14 | 114, 15 | 2003-09-01 | 2003-09-26 | 20d | -7d | 0d | Standard w/ German Holidays | STEREO | IMPACT | SEP Package | SEPT | SEPT | FM 1 E I & T Complete | KIEL |
| 204 | 9.2.2.2 | Muon and Radioactive Source Test | 5d | 2003-10-15 | 2003-10-21 | 203 | 2003-09-29 | 2003-10-06 | 5d | -6d | 0d | Standard w/ German Holidays | STEREO | IMPACT | SEP Package | SEPT | SEPT |  | KIEL |
| 205 | 9.2.2.3 | SEPT-E FM 1 Vibration | 5d | 2003-10-22 | 2003-10-28 | 204 | 2003-10-07 | 2003-10-13 | 5d | -6d | 0d | Standard w/ German Holidays | STEREO | IMPACT | SEP Package | SEPT | SEPT |  | KIEL |
| 206 | 9.2.2.4 | SEPT-E FM 1 TV/TB | 10d | 2003-10-29 | 2003-11-11 | 205 | 2003-10-14 | 2003-10-27 | 10d | -6d | 0d | Standard w/ German Holidays | STEREO | IMPACT | SEP Package | SEPT | SEPT | FM 1 E Environmentally Tested | KIEL |
| 207 | 9.3 | **FM 2** | 35d | 2003-10-06 | 2003-11-25 |  | 2003-09-29 | 2003-11-12 | 31d | -6d | 0d |  | STEREO | IMPACT | SEP Package | SEPT | SEPT |  |  |
| 208 | 9.3.1 | **SEPT-NS** | 30d | 2003-10-06 | 2003-11-18 |  | 2003-09-29 | 2003-11-12 | 31d | -2d | 0d |  | STEREO | IMPACT | SEP Package | SEPT | SEPT |  |  |
| 209 | 9.3.1.1 | SEPT-NS FM 2 Integration & Test | 12d | 2003-10-06 | 2003-10-21 | 116, 16, 198FS-2d | 2003-09-29 | 2003-10-15 | 12d | -1d | 0d | Standard w/ German Holidays | STEREO | IMPACT | SEP Package | SEPT | SEPT | FM 2 NS I & T Complete | KIEL |
| 210 | 9.3.1.2 | Muon and Radioactive Source Test | 5d | 2003-10-22 | 2003-10-28 | 209 | 2003-10-16 | 2003-10-22 | 5d | -1d | 0d | Standard w/ German Holidays | STEREO | IMPACT | SEP Package | SEPT | SEPT |  | KIEL |
| 211 | 9.3.1.3 | SEPT-NS FM 2 Vibration | 5d | 2003-10-29 | 2003-11-04 | 210 | 2003-10-23 | 2003-10-29 | 5d | -1d | 0d | Standard w/ German Holidays | STEREO | IMPACT | SEP Package | SEPT | SEPT |  | KIEL |
| 212 | 9.3.1.4 | SEPT-NS FM 2 TV/TB | 10d | 2003-11-05 | 2003-11-18 | 211 | 2003-10-30 | 2003-11-12 | 10d | -1d | 0d | Standard w/ German Holidays | STEREO | IMPACT | SEP Package | SEPT | SEPT | FM 2 NS Environmentally Tested | KIEL |
| 213 | 9.3.2 | **SEPT-E** | 31d | 2003-10-13 | 2003-11-25 |  | 2003-09-29 | 2003-11-12 | 31d | -6d | 0d |  | STEREO | IMPACT | SEP Package | SEPT | SEPT |  |  |
| 214 | 9.3.2.1 | SEPT-E FM 2 Integration & Test | 12d | 2003-10-13 | 2003-10-28 | 117, 17, 203FS-2d | 2003-09-29 | 2003-10-15 | 12d | -6d | 0d | Standard w/ German Holidays | STEREO | IMPACT | SEP Package | SEPT | SEPT | FM 2 E I & T Complete | KIEL |
| 215 | 9.3.2.2 | Muon and Radioactive Source Test | 5d | 2003-10-29 | 2003-11-04 | 214 | 2003-10-16 | 2003-10-22 | 5d | -6d | 0d | Standard w/ German Holidays | STEREO | IMPACT | SEP Package | SEPT | SEPT |  | KIEL |
| 216 | 9.3.2.3 | SEPT-E FM 2 Vibration | 5d | 2003-11-05 | 2003-11-11 | 215 | 2003-10-23 | 2003-10-29 | 5d | -6d | 0d | Standard w/ German Holidays | STEREO | IMPACT | SEP Package | SEPT | SEPT |  | KIEL |
| 217 | 9.3.2.4 | SEPT-E FM 2 TV/TB | 10d | 2003-11-12 | 2003-11-25 | 216 | 2003-10-30 | 2003-11-12 | 10d | -6d | 0d | Standard w/ German Holidays | STEREO | IMPACT | SEP Package | SEPT | SEPT | FM 2 E Environmentally Tested | KIEL |
