# STE - Suprathermal Electron Telescope

Schedule from MS Project, 2000-05-24 to 2004-04-19, status date 2003-05-31, A marks actual dates.
STE Development Schedule
NASA GSFC
Status Date: 05/31/2003 / Baseline Date: 01/31/2003 R1

## Calendars

- Standard w/ 10 Gov't Holidays: Mon-Fri 08:00-12:00, 13:00-17:00; Sat-Sun off. Exceptions (off unless hours are given): 2000-05-29, 2000-07-04, 2000-09-04, 2000-10-09, 2000-11-13, 2000-11-23, 2000-12-25, 2001-01-01, 2001-01-15, 2001-02-19, 2001-05-28, 2001-07-04, 2001-09-03, 2001-10-08, 2001-11-12, 2001-11-22, 2001-12-25, 2002-01-01, 2002-01-14, 2002-02-18, 2002-05-27, 2002-07-04, 2002-09-02, 2002-10-07, 2002-11-11, 2002-11-28, 2002-12-25, 2003-01-01, 2003-01-13, 2003-02-17, 2003-05-26, 2003-07-04, 2003-09-01, 2003-10-06, 2003-11-10, 2003-11-27, 2003-12-25, 2004-01-01, 2004-01-12, 2004-02-16.

## Schedule

| ID | WBS | Task | Type | Duration | Start | Finish | Predecessors | Complete | Remaining | Baseline start | Baseline finish | Baseline duration | Total slack | Free slack | Constraint | Text11 | Text12 | Text13 | Text14 | Text16 | Text17 | Text28 | Text20 | Text21 | Text22 | Text23 |
| --- | --- | --- | --- | --- | --- | --- | --- | --- | --- | --- | --- | --- | --- | --- | --- | --- | --- | --- | --- | --- | --- | --- | --- | --- | --- | --- |
| 1 | 1 | **Management** |  | 919d | 2000-08-18 A | 2004-04-19 |  | 83% | 152.87d | 2000-08-18 | 2004-04-19 | 919d | 0d |  |  | STEREO | IMPACT | Boom Suite | STE | SWEA/STE-D and STE-U | STE | UC-B |  |  |  |  |
| 2 | 1.1 | **Milestones** |  | 919d | 2000-08-18 A | 2004-04-19 |  | 83% | 152.87d | 2000-08-18 | 2004-04-19 | 919d | 0d |  |  | STEREO | IMPACT | Boom Suite | STE | SWEA/STE-D and STE-U | STE | UC-B |  |  |  |  |
| 3 | 1.1.1 | STE Box Design Contingency |  | 302d | 2000-08-18 A | 2001-10-31 A | 24 | 100% |  | 2000-08-18 | 2001-10-31 | 302d |  |  |  | STEREO | IMPACT | Boom Suite | STE | SWEA/STE-D and STE-U | STE | UC-B |  |  |  |  |
| 4 | 1.1.2 | STE ETU Detector Printed Wiring Board Layout Contingency |  | 134d | 2001-10-12 A | 2002-04-25 A | 67 | 100% |  | 2001-10-12 | 2002-04-25 | 134d |  |  |  | STEREO | IMPACT | Boom Suite | STE | SWEA/STE-D and STE-U | STE | UC-B |  |  |  |  |
| 5 | 1.1.3 | STE ETU Delivery Contingency | milestone | 0d | 2003-06-12 | 2003-06-12 | 78 |  |  | 2003-04-24 | 2003-04-24 | 0d | 17d | 0d |  | STEREO | IMPACT | Boom Suite | STE | SWEA/STE-D and STE-U | STE | UC-B |  |  |  |  |
| 6 | 1.1.4 | STE-U FM 1 Delivery Contingency |  | 15d | 2003-12-17 | 2004-01-08 | 83 |  |  | 2003-12-09 | 2004-01-07 | 20d | 0d |  |  | STEREO | IMPACT | Boom Suite | STE | SWEA/STE-D and STE-U | STE | UC-B |  |  |  |  |
| 7 | 1.1.5 | STE-U FM 2 Delivery Contingency |  | 72d | 2004-01-07 | 2004-04-19 | 88 |  |  | 2004-03-24 | 2004-04-19 | 19d | 0d |  |  | STEREO | IMPACT | Boom Suite | STE | SWEA/STE-D and STE-U | STE | UC-B |  |  |  |  |
| 8 | 1.1.6 | STE-D FM 1 Delivery Contingency | milestone | 0d | 2003-12-16 | 2003-12-16 | 83 |  |  | 2003-12-09 | 2003-12-19 | 9d | 3d | 0d |  | STEREO | IMPACT | Boom Suite | STE | SWEA/STE-D and STE-U | STE | UC-B |  |  |  |  |
| 9 | 1.1.7 | STE-D FM 2 Delivery Contingency | milestone | 0d | 2004-01-06 | 2004-01-06 | 88 |  |  | 2004-03-23 | 2004-03-23 | 0d | 36d | 0d |  | STEREO | IMPACT | Boom Suite | STE | SWEA/STE-D and STE-U | STE | UC-B |  |  |  |  |
| 10 | 1.1.8 | **Deliverables** |  | 213d | 2003-06-12 | 2004-04-19 |  |  |  | 2003-04-24 | 2004-04-19 | 247d | 0d |  |  | STEREO | IMPACT | Boom Suite | STE | SWEA/STE-D and STE-U | STE | UC-B |  |  |  |  |
| 11 | 1.1.8.1 | Deliver STE-U/D ETU For Interface Testing | milestone | 0d | 2003-06-12 | 2003-06-12 | 5 |  |  | 2003-04-24 | 2003-04-24 | 0d | 17d | 0d |  | STEREO | IMPACT | Boom Suite | STE | SWEA/STE-D and STE-U | STE | UC-B | STE ETU | ETU Cmplt | STE -ETU Complete | STE ETU Complete |
| 12 | 1.1.2.18 | Receive STE-U/D ETU w/Detectors | milestone | 0d | 2003-06-12 | 2003-06-12 | 11 |  |  | 2003-04-24 | 2003-04-24 | 0d | 17d |  |  | STEREO | IMPACT | Boom Suite | STE | SWEA/STE-D and STE-U | STE | UC-B |  |  |  |  |
| 13 | 1.1.8.3 | Deliver STE-U FM 1 For STE-U BOOM Suite I & T | milestone | 0d | 2004-01-08 | 2004-01-08 | 6 |  |  | 2004-01-07 | 2004-01-07 | 0d | 0d |  | finish no later than 2004-01-08 | STEREO | IMPACT | Boom Suite | STE | SWEA/STE-D and STE-U | STE | UC-B | STE-U FM 1 |  | STE-U - FM 1 Complete | Deliver STE-U FM 1 |
| 14 | 1.2.5.2.6 | Receive STE-U FM 1 For BOOM Suite I & T | milestone | 0d | 2004-01-16 | 2004-01-16 | 13FF+5d |  |  | 2004-01-15 | 2004-01-15 | 0d | 39d |  |  | STEREO | IMPACT | Boom Suite | STE | SWEA/STE-D and STE-U | STE | UC-B |  |  |  |  |
| 15 | 1.1.8.5 | Deliver STE-U FM 2 For STE-U BOOM Suite I & T | milestone | 0d | 2004-04-19 | 2004-04-19 | 7 |  |  | 2004-04-19 | 2004-04-19 | 0d | 0d |  | finish no later than 2004-04-19 | STEREO | IMPACT | Boom Suite | STE | SWEA/STE-D and STE-U | STE | UC-B | STE-U FM 2 |  | STE-U - FM 2 Complete | Deliver STE-U FM 2 |
| 16 | 1.2.5.3.4 | Receive STE-U FM 2 For BOOM Suite I & T | milestone | 0d | 2004-04-19 | 2004-04-19 | 15FF |  |  | 2004-04-19 | 2004-04-19 | 0d | 1.75d |  |  | STEREO | IMPACT | Boom Suite | STE | SWEA/STE-D and STE-U | STE | UC-B |  |  |  |  |
| 17 | 1.1.8.7 | Deliver STE-D FM 1 For SWEA/STE-D I & T | milestone | 0d | 2003-12-16 | 2003-12-16 | 8 |  |  | 2003-12-19 | 2003-12-19 | 0d | 3d |  | finish no later than 2003-12-19 | STEREO | IMPACT | Boom Suite | STE | SWEA/STE-D and STE-U | STE | UC-B | STE-D FM 1 |  | Deliver STE-D FM 1 For SWEA/STE-D I & T | Deliver STE-D FM 1 For SWEA/STE I & T |
| 18 | 1.1.2.20 | Receive STE-D FM 1 w/Detectors | milestone | 0d | 2003-12-16 | 2003-12-16 | 17 |  |  | 2003-12-19 | 2003-12-19 | 0d | 19d |  |  | STEREO | IMPACT | Boom Suite | STE | SWEA/STE-D and STE-U | STE | UC-B |  |  |  |  |
| 19 | 1.1.8.9 | Deliver STE-D FM 2 For SWEA/STE-D I & T | milestone | 0d | 2004-01-06 | 2004-01-06 | 9 |  |  | 2004-03-23 | 2004-03-23 | 0d | 36d | 19d | finish no later than 2004-03-24 | STEREO | IMPACT | Boom Suite | STE | SWEA/STE-D and STE-U | STE | UC-B | STE-D FM 2 |  | Deliver STE-D FM 2 For SWEA/STE-D I & T | Deliver STE-D FM 2 For SWEA/STE I & T |
| 20 | 1.1.2.22 | Receive STE-D FM 2 w/Detectors | milestone | 0d | 2004-01-06 | 2004-01-06 | 19 |  |  | 2004-03-23 | 2004-03-23 | 0d | 27d |  |  | STEREO | IMPACT | Boom Suite | STE | SWEA/STE-D and STE-U | STE | UC-B |  |  |  |  |
| 21 | 2 | **STE-U/D Housing** |  | 906d | 2000-05-26 A | 2004-01-07 |  | 64% | 321.84d | 2000-05-26 | 2004-01-16 | 912d | 62d |  |  | STEREO | IMPACT | Boom Suite | STE | SWEA/STE-D and STE-U | STE | UC-B |  |  |  |  |
| 22 | 2.1 | **Design, Manufacture, Assembly and Test** |  | 906d | 2000-05-26 A | 2004-01-07 |  | 64% | 321.84d | 2000-05-26 | 2004-01-16 | 912d | 62d |  |  | STEREO | IMPACT | Boom Suite | STE | SWEA/STE-D and STE-U | STE | UC-B |  |  |  |  |
| 23 | 2.1.1 | **Design** |  | 397d | 2000-05-26 A | 2001-12-26 A |  | 100% |  | 2000-05-26 | 2001-12-26 | 397d |  |  |  | STEREO | IMPACT | Boom Suite | STE | SWEA/STE-D and STE-U | STE | UC-B |  |  |  |  |
| 24 | 2.1.1.1 | STE Aperture Design |  | 58d | 2000-05-26 A | 2000-08-17 A | 38FS+2d | 100% |  | 2000-05-26 | 2000-08-17 | 58d |  |  |  | STEREO | IMPACT | Boom Suite | STE | SWEA/STE-D and STE-U | STE | UC-B |  |  |  |  |
| 25 | 2.1.1.2 | STE Box Design |  | 37d | 2001-11-01 A | 2001-12-26 A | 3 | 100% |  | 2001-11-01 | 2001-12-26 | 37d |  |  |  | STEREO | IMPACT | Boom Suite | STE | SWEA/STE-D and STE-U | STE | UC-B |  |  |  |  |

Notes:
- 6: March 03 Status Removed 5 days of contingency
- 7: March 03 Status removed 13 days of contingency
- 8: March 03 Status removed 6 days of contingency.

| ID | WBS | Task | Type | Duration | Start | Finish | Predecessors | Complete | Remaining | Baseline start | Baseline finish | Baseline duration | Total slack | Free slack | Constraint | Text11 | Text12 | Text13 | Text14 | Text16 | Text17 | Text28 | Text23 |
| --- | --- | --- | --- | --- | --- | --- | --- | --- | --- | --- | --- | --- | --- | --- | --- | --- | --- | --- | --- | --- | --- | --- | --- |
| 26 | 2.1.2 | **Fabrication** |  | 509d | 2001-12-27 A | 2004-01-07 |  | 34% | 336.26d | 2001-12-27 | 2004-01-16 | 515d | 62d |  |  | STEREO | IMPACT | Boom Suite | STE | SWEA/STE-D and STE-U | STE | UC-B |  |
| 27 | 2.1.2.1 | **ETU** |  | 233d | 2001-12-27 A | 2002-11-29 A |  | 100% |  | 2001-12-27 | 2002-11-29 | 233d |  |  |  | STEREO | IMPACT | Boom Suite | STE | SWEA/STE-D and STE-U | STE | UC-B |  |
| 28 | 2.1.2.1.1 | Fabricate STE ETU Box |  | 37.5d | 2001-12-27 A | 2002-11-29 A | 25 | 100% |  | 2001-12-27 | 2002-11-29 | 37.5d |  |  |  | STEREO | IMPACT | Boom Suite | STE | SWEA/STE-D and STE-U | STE | UC-B |  |
| 29 | 2.1.2.2 | **FM 1 & FM 2** |  | 142d | 2003-06-13 | 2004-01-07 |  |  |  | 2003-02-03 | 2004-01-16 | 240d | 30d |  |  | STEREO | IMPACT | Boom Suite | STE | SWEA/STE-D and STE-U | STE | UC-B |  |
| 30 | 2.1.2.2.1 | **FM 1** |  | 35d | 2003-06-13 | 2003-08-01 |  |  |  | 2003-02-03 | 2003-03-24 | 35d | 30d |  |  | STEREO | IMPACT | Boom Suite | STE | SWEA/STE-D and STE-U | STE | UC-B |  |
| 31 | 2.1.2.2.1.1 | Fabricate STE FM 1 Box |  | 35d | 2003-06-13 | 2003-08-01 | 53, 78 |  |  | 2003-02-03 | 2003-03-24 | 35d | 46d |  | start no earlier than 2003-04-30 | STEREO | IMPACT | Boom Suite | STE | SWEA/STE-D and STE-U | STE | UC-B |  |
| 32 | 2.1.2.2.2 | **FM 2** |  | 38d | 2003-11-12 | 2004-01-07 |  |  |  | 2003-11-20 | 2004-01-16 | 38d | 62d |  |  | STEREO | IMPACT | Boom Suite | STE | SWEA/STE-D and STE-U | STE | UC-B |  |
| 33 | 2.1.2.2.2.1 | Fabricate STE FM 2 Box |  | 38d | 2003-11-12 | 2004-01-07 | 53, 81, 78 |  |  | 2003-11-20 | 2004-01-16 | 38d | 62d | 0d |  | STEREO | IMPACT | Boom Suite | STE | SWEA/STE-D and STE-U | STE | UC-B |  |
| 34 | 3 | **STE-U/D Detector Boards** |  | 854d | 2000-05-26 A | 2003-10-21 |  | 82% | 154.39d | 2000-05-26 | 2004-01-06 | 905d | 123d |  |  | STEREO | IMPACT | Boom Suite | STE | SWEA/STE-D and STE-U | STE | UC-B |  |
| 35 | 3.1 | **Design, Manufacture, Assembly and Test** |  | 854d | 2000-05-26 A | 2003-10-21 |  | 82% | 154.39d | 2000-05-26 | 2004-01-06 | 905d | 123d |  |  | STEREO | IMPACT | Boom Suite | STE | SWEA/STE-D and STE-U | STE | UC-B |  |
| 36 | 3.1.1 | **Procurements** |  | 830d | 2000-05-26 A | 2003-09-16 |  | 85% | 124.37d | 2000-05-26 | 2003-08-11 | 805d | 129d |  |  | STEREO | IMPACT | Boom Suite | STE | SWEA/STE-D and STE-U | STE | UC-B |  |
| 37 | 3.1.1.1 | **ETU** |  | 318d | 2000-05-26 A | 2001-08-30 A |  | 100% |  | 2000-05-26 | 2001-08-30 | 318d |  |  |  | STEREO | IMPACT | Boom Suite | STE | SWEA/STE-D and STE-U | STE | UC-B |  |
| 38 | 1.1.1 | Instrument SRR | milestone | 0d | 2000-05-24 A | 2000-05-24 A |  | 100% |  | 2000-05-24 | 2000-05-24 | 0d |  |  | start no earlier than 2000-05-24 | STEREO | IMPACT | Boom Suite | STE | SWEA/STE-D and STE-U | STE | UC-B |  |
| 39 | 3.1.1.1.2 | Procure STE ETU Detector |  | 318d | 2000-05-26 A | 2001-08-30 A | 38FS+2d | 100% |  | 2000-05-26 | 2001-08-30 | 318d |  |  |  | STEREO | IMPACT | Boom Suite | STE | SWEA/STE-D and STE-U | STE | UC-B |  |
| 40 | 3.1.1.2 | **FM 1 & FM 2** |  | 506d | 2001-09-11 A | 2003-09-16 |  | 70% | 152.12d | 2001-09-11 | 2003-08-11 | 481d | 129d |  |  | STEREO | IMPACT | Boom Suite | STE | SWEA/STE-D and STE-U | STE | UC-B |  |
| 41 | 1.1.5 | Instrument PDR | milestone | 1d | 2001-09-11 A | 2001-09-11 A |  | 100% |  | 2001-09-11 | 2001-09-11 | 1d |  |  | start no earlier than 2001-09-11 | STEREO | IMPACT | Boom Suite | STE | SWEA/STE-D and STE-U | STE | UC-B |  |
| 42 | 3.1.1.2.2 | Procure STE Long Lead Parts |  | 241d | 2001-09-11 A | 2003-06-27 | 45, 41 | 92% | 20d | 2001-09-11 | 2003-03-31 | 241d | 30d |  |  | STEREO | IMPACT | Boom Suite | STE | SWEA/STE-D and STE-U | STE | UC-B | Long Lead Parts Procured and Screened |
| 43 | 3.1.1.2.3 | (OBSOLETE) Procure STE FM 1 & FM 2 Detectors |  | 75d | 2003-06-02 | 2003-09-16 | 41 |  |  | 2003-04-25 | 2003-08-11 | 75d | 129d | 0d | start no earlier than 2003-05-31 | STEREO | IMPACT | Boom Suite | STE | SWEA/STE-D and STE-U | STE | UC-B | Flight Detectors Received |
| 44 | 3.1.2 | **Design** |  | 552d | 2000-05-26 A | 2002-08-07 A |  | 100% |  | 2000-05-26 | 2002-08-07 | 552d |  |  |  | STEREO | IMPACT | Boom Suite | STE | SWEA/STE-D and STE-U | STE | UC-B |  |
| 45 | 3.1.2.1 | STE Charge Sensitive Amplifier Design |  | 318d | 2000-05-26 A | 2001-08-30 A | 38FS+2d | 100% |  | 2000-05-26 | 2001-08-30 | 318d |  |  |  | STEREO | IMPACT | Boom Suite | STE | SWEA/STE-D and STE-U | STE | UC-B |  |
| 46 | 3.1.2.2 | Layout STE ETU Detector Printed Wiring Board |  | 5d | 2002-08-01 A | 2002-08-07 A | 4 | 100% |  | 2002-08-01 | 2002-08-07 | 5d |  |  | start no earlier than 2002-07-31 | STEREO | IMPACT | Boom Suite | STE | SWEA/STE-D and STE-U | STE | UC-B |  |
| 47 | 3.1.3 | **Fabrication** |  | 238d | 2002-08-08 A | 2003-07-21 |  | 25% | 178.5d | 2002-08-08 | 2003-02-12 | 128d | 187d |  |  | STEREO | IMPACT | Boom Suite | STE | SWEA/STE-D and STE-U | STE | UC-B |  |
| 48 | 3.1.3.1 | **ETU** |  | 10d | 2002-08-08 A | 2002-08-21 A |  | 100% |  | 2002-08-08 | 2002-08-21 | 10d |  |  |  | STEREO | IMPACT | Boom Suite | STE | SWEA/STE-D and STE-U | STE | UC-B |  |
| 49 | 3.1.3.1.1 | Fabrication STE ETU Detector Printed Wiring Board |  | 10d | 2002-08-08 A | 2002-08-21 A | 46 | 100% |  | 2002-08-08 | 2002-08-21 | 10d |  |  |  | STEREO | IMPACT | Boom Suite | STE | SWEA/STE-D and STE-U | STE | UC-B |  |

Notes:
- 43: 2003-05-31 status: On 6/10 it was determined that there was no need to respin the detectors this activity is now obsolete.

| ID | WBS | Task | Type | Duration | Start | Finish | Predecessors | Complete | Remaining | Baseline start | Baseline finish | Baseline duration | Total slack | Free slack | Constraint | Text11 | Text12 | Text13 | Text14 | Text16 | Text17 | Text28 | Text21 | Text23 |
| --- | --- | --- | --- | --- | --- | --- | --- | --- | --- | --- | --- | --- | --- | --- | --- | --- | --- | --- | --- | --- | --- | --- | --- | --- |
| 50 | 3.1.3.2 | **FM 1 & FM 2** |  | 15d | 2003-06-30 | 2003-07-21 |  |  |  | 2003-02-03 | 2003-02-12 | 8d | 0d |  |  | STEREO | IMPACT | Boom Suite | STE | SWEA/STE-D and STE-U | STE | UC-B |  |  |
| 51 | 3.1.3.2.1 | Begin Fabrication STE FM 1and FM 2 | milestone | 0d | 2003-06-30 | 2003-06-30 | 54SS |  |  | 2003-02-03 | 2003-02-03 | 0d | 202d |  | start no earlier than 2003-06-30 | STEREO | IMPACT | Boom Suite | STE | SWEA/STE-D and STE-U | STE | UC-B | FM1/2 Fab |  |
| 52 | 3.1.3.2.2 | **FM 1** |  | 15d | 2003-06-30 | 2003-07-21 |  |  |  | 2003-02-03 | 2003-02-12 | 8d | 0d |  |  | STEREO | IMPACT | Boom Suite | STE | SWEA/STE-D and STE-U | STE | UC-B |  |  |
| 53 | 1.1.13 | Instrument CDR | milestone | 3d | 2002-11-20 A | 2002-11-22 A |  | 100% |  | 2002-11-20 | 2002-11-22 | 3d |  |  | finish no earlier than 2002-11-22 | STEREO | IMPACT | Boom Suite | STE | SWEA/STE-D and STE-U | STE | UC-B |  |  |
| 54 | 3.1.3.2.2.2 | Fabrication STE FM 1 Detector Printed Wiring Board |  | 15d | 2003-06-30 | 2003-07-21 | 53, 78 |  |  | 2003-02-03 | 2003-02-12 | 8d | 0d |  | start no earlier than 2003-06-30 | STEREO | IMPACT | Boom Suite | STE | SWEA/STE-D and STE-U | STE | UC-B |  | FM 1 Detector PWB Fabricated |
| 55 | 3.1.3.2.3 | **FM 2** |  | 15d | 2003-06-30 | 2003-07-21 |  |  |  | 2003-02-03 | 2003-02-12 | 8d | 0d |  |  | STEREO | IMPACT | Boom Suite | STE | SWEA/STE-D and STE-U | STE | UC-B |  |  |
| 56 | 3.1.3.2.3.1 | Fabricate STE FM 2 Detector Printed Wiring Board |  | 15d | 2003-06-30 | 2003-07-21 | 53, 78 |  |  | 2003-02-03 | 2003-02-12 | 8d | 0d |  | start no earlier than 2003-06-30 | STEREO | IMPACT | Boom Suite | STE | SWEA/STE-D and STE-U | STE | UC-B |  | FM 2 Detector PWB Fabricated |
| 57 | 3.1.4 | **Assembly** |  | 153d | 2003-03-03 A | 2003-10-07 |  | 23% | 117.69d | 2003-02-03 | 2003-12-19 | 223d | 123d |  |  | STEREO | IMPACT | Boom Suite | STE | SWEA/STE-D and STE-U | STE | UC-B |  |  |
| 58 | 3.1.4.1 | **ETU** |  | 25d | 2003-03-03 A | 2003-04-04 A |  | 100% |  | 2003-02-03 | 2003-02-13 | 9d |  |  |  | STEREO | IMPACT | Boom Suite | STE | SWEA/STE-D and STE-U | STE | UC-B |  |  |
| 59 | 3.1.4.1.1 | Load STE ETU Detector Printed Wiring Board |  | 9d | 2003-03-03 A | 2003-04-04 A | 49 | 100% |  | 2003-02-03 | 2003-02-13 | 9d |  |  | start no earlier than 2003-03-01 | STEREO | IMPACT | Boom Suite | STE | SWEA/STE-D and STE-U | STE | UC-B |  | ETU Detector Board Loaded |
| 60 | 3.1.4.2 | **FM 1** |  | 15d | 2003-08-12 | 2003-09-02 |  |  |  | 2003-04-01 | 2003-04-10 | 8d | 0d |  |  | STEREO | IMPACT | Boom Suite | STE | SWEA/STE-D and STE-U | STE | UC-B |  |  |
| 61 | 3.1.4.2.1 | Load STE FM 1 Detector Printed Wiring Board |  | 15d | 2003-08-12 | 2003-09-02 | 42, 71 |  |  | 2003-04-01 | 2003-04-10 | 8d | 0d |  |  | STEREO | IMPACT | Boom Suite | STE | SWEA/STE-D and STE-U | STE | UC-B |  | FM 1 Detector Board Loaded |
| 62 | 3.1.4.3 | **FM 2** |  | 15d | 2003-09-16 | 2003-10-07 |  |  |  | 2003-12-09 | 2003-12-19 | 9d | 123d |  |  | STEREO | IMPACT | Boom Suite | STE | SWEA/STE-D and STE-U | STE | UC-B |  |  |
| 63 | 3.1.4.3.1 | Load STE FM 2 Detector Printed Wiring Board |  | 15d | 2003-09-16 | 2003-10-07 | 71, 42, 73 |  |  | 2003-12-09 | 2003-12-19 | 9d | 123d | 0d |  | STEREO | IMPACT | Boom Suite | STE | SWEA/STE-D and STE-U | STE | UC-B |  | FM 2 Detector Board Loaded |
| 64 | 3.1.5 | **Test** |  | 536d | 2001-08-31 A | 2003-10-21 |  | 52% | 255.71d | 2001-08-31 | 2004-01-06 | 587d | 123d |  |  | STEREO | IMPACT | Boom Suite | STE | SWEA/STE-D and STE-U | STE | UC-B |  |  |
| 65 | 3.1.5.1 | **ETU** |  | 408d | 2001-08-31 A | 2003-04-18 A |  | 100% |  | 2001-08-31 | 2003-02-28 | 373d |  |  |  | STEREO | IMPACT | Boom Suite | STE | SWEA/STE-D and STE-U | STE | UC-B |  |  |
| 66 | 3.1.5.1.1 | STE ETU Detector Tests |  | 19d | 2001-08-31 A | 2001-09-27 A | 39 | 100% |  | 2001-08-31 | 2001-09-27 | 19d |  |  |  | STEREO | IMPACT | Boom Suite | STE | SWEA/STE-D and STE-U | STE | UC-B |  |  |
| 67 | 3.1.5.1.2 | STE CSA Breadboard/Test |  | 28d | 2001-08-31 A | 2001-10-11 A | 45 | 100% |  | 2001-08-31 | 2001-10-11 | 28d |  |  |  | STEREO | IMPACT | Boom Suite | STE | SWEA/STE-D and STE-U | STE | UC-B |  |  |
| 68 | 3.1.5.1.3 | STE ETU Detector Printed Wiring Board Test |  | 10d | 2003-04-07 A | 2003-04-18 A | 59 | 100% |  | 2003-02-14 | 2003-02-28 | 10d |  |  | start no earlier than 2003-03-31 | STEREO | IMPACT | Boom Suite | STE | SWEA/STE-D and STE-U | STE | UC-B |  | ETU Detector PWB Tested |
| 69 | 3.1.5.2 | **FM 1 & FM 2** |  | 58d | 2003-07-22 | 2003-10-13 |  |  |  | 2003-02-13 | 2003-09-05 | 143d | 0d |  |  | STEREO | IMPACT | Boom Suite | STE | SWEA/STE-D and STE-U | STE | UC-B |  |  |
| 70 | 3.1.5.2.1 | Test STE FM 1 & FM 2 Detectors |  | 18d | 2003-09-17 | 2003-10-13 | 43 |  |  | 2003-08-12 | 2003-09-05 | 18d | 129d |  | start no earlier than 2003-04-30 | STEREO | IMPACT | Boom Suite | STE | SWEA/STE-D and STE-U | STE | UC-B |  | Flight Detectors Tested |
| 71 | 3.1.5.2.2 | Coupon Test STE FM 1 & FM 2 Detector Printed Wiring Board |  | 15d | 2003-07-22 | 2003-08-11 | 54, 56 |  |  | 2003-02-13 | 2003-03-06 | 15d | 0d |  | start no earlier than 2003-04-30 | STEREO | IMPACT | Boom Suite | STE | SWEA/STE-D and STE-U | STE | UC-B |  | Flight Detector PWBs Coupon Tested |
| 72 | 3.1.5.3 | **FM 1** |  | 9d | 2003-09-03 | 2003-09-15 |  |  |  | 2003-04-11 | 2003-04-23 | 9d | 0d |  |  | STEREO | IMPACT | Boom Suite | STE | SWEA/STE-D and STE-U | STE | UC-B |  |  |
| 73 | 3.1.5.3.1 | Test STE FM 1 Detector Printed Wiring Board |  | 9d | 2003-09-03 | 2003-09-15 | 61 |  |  | 2003-04-11 | 2003-04-23 | 9d | 0d |  |  | STEREO | IMPACT | Boom Suite | STE | SWEA/STE-D and STE-U | STE | UC-B |  | FM 1 Detector PWB Tested |

| ID | WBS | Task | Duration | Start | Finish | Predecessors | Complete | Remaining | Baseline start | Baseline finish | Baseline duration | Total slack | Constraint | Text11 | Text12 | Text13 | Text14 | Text16 | Text17 | Text28 | Text23 | Text21 |
| --- | --- | --- | --- | --- | --- | --- | --- | --- | --- | --- | --- | --- | --- | --- | --- | --- | --- | --- | --- | --- | --- | --- |
| 74 | 3.1.5.4 | **FM 2** | 10d | 2003-10-08 | 2003-10-21 |  |  |  | 2003-12-22 | 2004-01-06 | 10d | 123d |  | STEREO | IMPACT | Boom Suite | STE | SWEA/STE-D and STE-U | STE | UC-B |  |  |
| 75 | 3.1.5.4.1 | Test STE FM 2 Detector Printed Wiring Board | 10d | 2003-10-08 | 2003-10-21 | 63 |  |  | 2003-12-22 | 2004-01-06 | 10d | 123d |  | STEREO | IMPACT | Boom Suite | STE | SWEA/STE-D and STE-U | STE | UC-B | FM 2 Detector PWB Tested |  |
| 76 | 4 | **Integration & Test** | 181d | 2003-05-01 A | 2004-01-21 |  | 22% | 141.94d | 2003-03-03 | 2004-03-23 | 267d | 62d |  | STEREO | IMPACT | Boom Suite | STE | SWEA/STE-D and STE-U | STE | UC-B |  |  |
| 77 | 4.1 | **ETU** | 30d | 2003-05-01 A | 2003-06-12 A |  | 100% |  | 2003-03-03 | 2003-04-24 | 39d |  |  | STEREO | IMPACT | Boom Suite | STE | SWEA/STE-D and STE-U | STE | UC-B |  |  |
| 78 | 4.1.1 | Integrate & Test STE-U/D ETU Detectors W/ ETU Housing | 30d | 2003-05-01 A | 2003-06-12 A | 28, 66, 68 | 100% |  | 2003-03-03 | 2003-04-24 | 39d |  | start no earlier than 2003-04-30 | STEREO | IMPACT | Boom Suite | STE | SWEA/STE-D and STE-U | STE | UC-B | ETU I & T Complete |  |
| 79 | 4.2 | **FM 1** | 63d | 2003-09-16 | 2003-12-16 |  |  |  | 2003-09-08 | 2003-12-08 | 63d | 0d |  | STEREO | IMPACT | Boom Suite | STE | SWEA/STE-D and STE-U | STE | UC-B |  |  |
| 80 | 4.2.1 | Integrate & Test STE-U/D FM 1 Detectors W/ FM 1 Housings | 19d | 2003-09-16 | 2003-10-13 | 31, 73 |  |  | 2003-09-08 | 2003-10-02 | 19d | 0d |  | STEREO | IMPACT | Boom Suite | STE | SWEA/STE-D and STE-U | STE | UC-B | FM 1 I & T Complete |  |
| 81 | 4.2.2 | Calibrate STE-U/D FM 1 | 20d | 2003-10-14 | 2003-11-11 | 80 |  |  | 2003-10-03 | 2003-10-31 | 20d | 0d |  | STEREO | IMPACT | Boom Suite | STE | SWEA/STE-D and STE-U | STE | UC-B | FM 1 Calibrated |  |
| 82 | 4.2.3 | Clean/Stake/Coat STE-U/D FM 1 | 10d | 2003-11-12 | 2003-11-25 | 81 |  |  | 2003-11-03 | 2003-11-17 | 10d | 0d |  | STEREO | IMPACT | Boom Suite | STE | SWEA/STE-D and STE-U | STE | UC-B |  |  |
| 83 | 4.2.4 | STE-U/D FM 1 Thermal Vacuum/Balance | 14d | 2003-11-26 | 2003-12-16 | 82 |  |  | 2003-11-18 | 2003-12-08 | 14d | 0d |  | STEREO | IMPACT | Boom Suite | STE | SWEA/STE-D and STE-U | STE | UC-B | FM 1 Enviornmental Testing Complete | Begin FM1 TVB TSt / FM1 STE-U Complete |
| 84 | 4.3 | **FM 2** | 47d | 2003-11-12 | 2004-01-21 |  |  |  | 2004-01-19 | 2004-03-23 | 46d | 0d |  | STEREO | IMPACT | Boom Suite | STE | SWEA/STE-D and STE-U | STE | UC-B |  |  |
| 85 | 4.3.1 | Integrate & Test STE-U/D FM 2 Detectors W/ FM 2 Housings | 9d | 2004-01-08 | 2004-01-21 | 33, 80 |  |  | 2004-01-19 | 2004-01-29 | 9d | 62d |  | STEREO | IMPACT | Boom Suite | STE | SWEA/STE-D and STE-U | STE | UC-B | FM 2 I & T Complete |  |
| 86 | 4.3.2 | Calibrate STE-U/D FM 2 | 18d | 2003-11-12 | 2003-12-08 | 81 |  |  | 2004-01-30 | 2004-02-25 | 18d | 0d |  | STEREO | IMPACT | Boom Suite | STE | SWEA/STE-D and STE-U | STE | UC-B | FM 2 Calibrated |  |
| 87 | 4.3.3 | Clean/Stake/Coat STE-U/D FM 2 | 9d | 2003-12-09 | 2003-12-19 | 86 |  |  | 2004-02-26 | 2004-03-09 | 9d | 0d |  | STEREO | IMPACT | Boom Suite | STE | SWEA/STE-D and STE-U | STE | UC-B |  |  |
| 88 | 4.3.4 | STE-U/D FM 2 Thermal Vacuum | 10d | 2003-12-22 | 2004-01-06 | 87 |  |  | 2004-03-10 | 2004-03-23 | 10d | 0d |  | STEREO | IMPACT | Boom Suite | STE | SWEA/STE-D and STE-U | STE | UC-B | FM 2 Enviornmental Testing Complete | FM2 TVB Tst |
